# 3GPP_Work Plan

Schedule from MS Project, 2000-01-01 to 2004-03-03, A marks actual dates.

## Calendars

- Standard: Mon-Fri 08:00-12:00, 13:00-17:00; Sat-Sun off.

## Resources

| Resource | Cost per use |
| --- | --- |
| NP | 25905600 |
| N1 |  |
| N2 |  |
| N3 |  |
| N4 |  |
| N5 |  |
| TP |  |
| T1 |  |
| T2 |  |
| T3 |  |
| RP |  |
| R1 |  |
| R2 |  |
| R3 |  |
| R4 |  |
| SP |  |
| S1 |  |
| S2 |  |
| S3 |  |
| S4 |  |
| S5 |  |
| PCG |  |
| GP |  |
| No |  |
| CN4 |  |
| ? |  |
| WG G2 |  |
| G2 |  |
| G1 |  |
| G4 |  |
| G3 |  |
| All |  |
| Generic |  |
| MLST |  |
| G5 |  |
| S3, G2 |  |
| WG T2 |  |
| GP,G1 |  |

## Schedule

| ID | WBS | Task | Type | Duration | Start | Finish | Complete | Remaining | Baseline start | Baseline finish | Baseline duration | Total slack | Free slack | Constraint | Resources | Work | Actual work | Text6 | Text9 | Text1 | Text2 | Text4 | Text7 | Text8 |
| --- | --- | --- | --- | --- | --- | --- | --- | --- | --- | --- | --- | --- | --- | --- | --- | --- | --- | --- | --- | --- | --- | --- | --- | --- |
| 1 | 1 | Rel-5 Work Plan - Version 2003 July 25th |  | 1d | 2000-01-03 | 2000-01-03 |  |  | 2000-01-03 | 2000-01-03 | 1d | 1087d |  |  |  |  |  | Rel | 2044 |  |  |  |  |  |
| 2 | 2 | "CTRL + a" to display all the 3GPP fields |  | 1d | 2000-01-03 | 2000-01-03 |  |  | 2000-01-03 | 2000-01-03 | 1d | 1129d |  |  |  |  |  |  | 1462 |  |  |  |  |  |
| 3 | 3 | Content of Rel-5. Frozen at TSG #16, June 2002 |  | 1d | 2000-01-03 | 2000-01-03 |  |  | 2000-01-03 | 2000-01-03 | 1d | 1087d |  |  |  |  |  | Rel | 2058 |  |  |  |  |  |
| 6 | 75 | IP transport in the UTRAN |  | 445d | 2000-07-17 A | 2002-03-29 A | 100% |  | 2000-07-17 | 2002-03-29 | 445d |  |  | finish no earlier than 2002-03-29 | R3 | 3560h | 3560h | Rel-5 | 625 | ETRAN-IPtrans | BaAS | Nicolas Drevon, Alcatel | TSG |  |
| 7 | 76 | FS on Usage of SUA |  | 205d | 2001-03-12 A | 2001-12-21 A | 100% |  | 2001-03-12 | 2001-12-21 | 205d |  |  | finish no earlier than 2001-12-21 | N4 | 1640h | 1640h | Rel-5 | 2455 | SS7IP |  |  |  |  |
| 8 | 77 | **High Speed Downlink Packet Access** |  | 570d | 2001-04-02 A | 2003-06-06 | 96% | 24.05d | 2001-04-02 | 2003-03-14 | 510d | 193d |  |  | R2 | 15272h | 14627.6h | Rel-5 | 2476 | HSDPA |  | Ravi Kuchibhotla, Motorola | TSG | Cesar |
| 9 | 77.1 | Physical Layer |  | 257d | 2001-04-05 A | 2002-03-29 A | 100% |  | 2001-04-05 | 2002-03-29 | 257d |  |  | finish no earlier than 2002-03-29 | R1 | 2056h | 2056h |  | 2477 | HSDPA-Phys |  | Amitava Ghosh, Motorola | TSG |  |
| 10 | 77.2 | Layer 2 and 3 aspects |  | 257d | 2001-04-05 A | 2002-03-29 A | 100% |  | 2001-04-05 | 2002-03-29 | 257d |  |  | finish no earlier than 2002-03-29 | R2 | 2056h | 2056h |  | 2478 | HSDPA-L23 |  | Ravi Kuchibhotla, Motorola | TSG |  |
| 11 | 77.3 | Iub/Iur protocol aspects |  | 260d | 2001-04-02 A | 2002-03-29 A | 100% |  | 2001-04-02 | 2002-03-29 | 260d |  |  | finish no earlier than 2002-03-29 | R3 | 2080h | 2080h |  | 2479 | HSDPA-IubIur |  | Mike Diesen, Motorola | TSG |  |
| 12 | 77.4 | RF Radio Transmission/ Reception, System Performance Requirements and Conformance Testing |  | 565d | 2001-04-09 A | 2003-06-06 | 90% | 56.5d | 2001-04-09 | 2003-03-14 | 505d | 193d |  | finish no earlier than 2003-06-06 | R4 | 4520h | 4068h |  | 2480 | HSDPA-RF |  | Howard Benn, Motorola | TSG |  |
| 13 | 78 | **Rel-5 Improvements of Radio Interface** |  | 535d | 2000-08-14 A | 2002-08-30 | 89% | 56.7d | 2000-08-14 | 2002-08-30 | 535d | 393d |  |  | RP | 30376h | 27009h | NA |  | RInImp |  |  | TSG | Tsukasa |
| 14 | 78.1 | **Base station classification** |  | 480d | 2000-08-14 A | 2002-06-14 A | 100% |  | 2000-08-14 | 2002-06-14 | 480d |  |  |  | R4 | 9208h | 9208h | Rel-5 | 1471 | RInImp-BSClass | BaAS | A. Toskala, Nokia | TSG |  |
| 15 | 78.1.1 | TDD Base station classification |  | 410d | 2000-08-14 A | 2002-03-08 A | 100% |  | 2000-08-14 | 2002-03-08 | 410d |  |  | finish no earlier than 2002-03-08 | R4 | 3280h | 3280h |  | 1477 | RInImp-BSClass-TDD | BaAs | A. Toskala, Nokia | TSG |  |
| 16 | 78.1.2 | Base Station Classification for 1.28 Mcps TDD option |  | 261d | 2001-06-15 A | 2002-06-14 A | 100% |  | 2001-06-15 | 2002-06-14 | 261d |  |  | finish no earlier than 2002-06-14 | R4 | 2088h | 2088h |  |  | RInImp-BSClass-LCRTDD |  | Meik Kottkamp, Siemens | TSG |  |
| 17 | 78.2 | Enhancement on the DSCH hard split mode |  | 271d | 2001-03-16 A | 2002-03-29 A | 100% |  | 2001-03-16 | 2002-03-29 | 271d |  |  | finish no earlier than 2002-03-29 | R1 | 2168h | 2168h | Rel-5 | 2469 | RInImp-DSCHhsp |  | Jaeyoel KIM, Samsung | TSG |  |
| 18 | 78.3 | Hybrid ARQ II/III |  | 355d | 2000-08-21 A | 2001-12-28 A | 100% |  | 2000-08-21 | 2001-12-28 | 355d |  |  | finish no earlier than 2001-12-28 | R2 | 2840h | 2840h | Rel-5 | 1217 | RInImp-HARQ |  | A. Sitte, Siemens | TSG |  |
| 19 | 78.4 | FS on USTS |  | 355d | 2000-08-14 A | 2001-12-21 A | 100% |  | 2000-08-14 | 2001-12-21 | 355d |  |  | finish no earlier than 2001-12-21 | R1 | 2840h | 2840h | Rel-5 | 1221 | RInImp-USTS | BaAS | D. Kim, SK Telecom | TSG |  |
| 20 | 78.5 | FS on UE antenna efficency test method performance requirements |  | 255d | 2000-09-25 A | 2001-09-14 A | 100% |  | 2000-09-25 | 2001-09-14 | 255d |  |  | finish no earlier than 2001-09-14 | R4 | 2040h | 2040h | Rel-5 | 1997 | RInImp-UEAnTM |  | O. Edvardsson, Allgon | TSG |  |
| 21 | 78.6 | FS on the re-introduction of the downlink SIR measurement |  | 200d | 2001-03-12 A | 2001-12-14 A | 100% |  | 2001-03-12 | 2001-12-14 | 200d |  |  | finish no earlier than 2001-12-14 | R4 | 1600h | 1600h | Rel-5 | 24002 | RInImp-SIR |  | Torgny Palenius, Ericsson | TSG | Cesar |
| 22 | 78.7 | FS on mitigating the effect of CPICH interference at the UE |  | 255d | 2001-03-19 A | 2002-03-08 A | 100% |  | 2001-03-19 | 2002-03-08 | 255d |  |  | finish no earlier than 2002-03-08 | R4 | 2040h | 2040h | Rel-5 | 24001 | RInImp-CPICH_Intf |  | Shimon Moshavi, Intel | TSG | Cesar |
| 23 | 78.8 | **Conformance Test Spec. improvements in Radio Interface** |  | 140d | 2002-02-18 | 2002-08-30 |  |  | 2002-02-18 | 2002-08-30 | 140d | 393d |  |  | T1 | 3360h |  |  |  |  |  |  |  |  |
| 24 | 78.8.1 | Testing improvement of inter-frequency and inter-system measurement |  | 140d | 2002-02-18 | 2002-08-30 |  |  | 2002-02-18 | 2002-08-30 | 140d | 393d |  | finish no earlier than 2002-08-30 | T1 | 1120h |  | Rel-5 | 2210 |  |  |  |  |  |
| 25 | 78.8.2 | Testing Hybrid ARQ II/III |  | 140d | 2002-02-18 | 2002-08-30 |  |  | 2002-02-18 | 2002-08-30 | 140d | 393d |  | finish no earlier than 2002-08-30 | T1 | 1120h |  | Rel-5 | 2211 |  |  |  |  |  |
| 26 | 79 | **Rel-5 RAN improvements** |  | 772d? | 2001-03-16 A | 2004-03-01 | 87% | 100.69d? | 2001-03-16 | 2002-09-03 | 383d | 2d |  |  | RP | 39984h | 28864h | NA |  | RANimp |  |  | TSG | Cesar |
| 27 | 79.1 | **RRM optimization for Iur and Iub** |  | 318d | 2001-03-16 A | 2002-06-04 A | 100% |  | 2001-03-16 | 2002-06-04 | 318d |  |  |  | R3 | 8904h | 8904h | Rel-5 | 656 | RANimp-RRMopt | BaAS | Gert-Jan van Lieshout, Ericsson | TSG |  |
| 28 | 79.1.1 | Iur common transport channel efficiency optimisation |  | 271d | 2001-03-16 A | 2002-03-29 A | 100% |  | 2001-03-16 | 2002-03-29 | 271d |  |  | finish no earlier than 2002-03-29 | R3 | 2168h | 2168h |  |  | RANimp-RRMopt-ctc |  | Shahrokh Amirijoo, Ericsson | TSG |  |
| 29 | 79.1.2 | Iur neighbouring cell reporting efficiency optimisation |  | 271d | 2001-03-16 A | 2002-03-29 A | 100% |  | 2001-03-16 | 2002-03-29 | 271d |  |  | finish no earlier than 2002-03-29 | R3 | 2168h | 2168h |  |  | RANimp-RRMopt-ncr |  | Shahrokh Amirijoo, Ericsson | TSG |  |
| 30 | 79.1.3 | FS Introduction of direct transport bearers between SRNC and Node-B |  | 253d | 2001-06-15 A | 2002-06-04 A | 100% |  | 2001-06-15 | 2002-06-04 | 253d |  |  | finish no earlier than 2002-06-28 | R3 | 2024h | 2024h |  |  | RAN-imp-RRMopt-DTB |  | Risto Sepponen, Ericsson | TSG |  |
| 31 | 79.2 | RL Timing Adjustment |  | 271d | 2001-03-16 A | 2002-03-29 A | 100% |  | 2001-03-16 | 2002-03-29 | 271d |  |  | finish no earlier than 2002-03-29 | R3 | 2168h | 2168h | Rel-5 | 22003 | RANimp-RLTA |  | Elena Voltolina, Ericsson | TSG |  |
| 32 | 79.3 | Separation of resource reservation and radio link activation |  | 271d | 2001-03-16 A | 2002-03-29 A | 100% |  | 2001-03-16 | 2002-03-29 | 271d |  |  | finish no earlier than 2002-03-29 | R3 | 2168h | 2168h | Rel-5 | 22004 | RANimp-SepRR |  | Gert-Jan van Lieshout, Ericsson | TSG |  |
| 33 | 79.4 | FS SRNS Relocation Procedure Enhancement |  | 318d | 2001-06-15 A | 2002-09-03 A | 100% |  | 2001-06-15 | 2002-09-03 | 318d |  |  | finish no earlier than 2002-09-06 | R3 | 2544h | 2544h | Rel-5 |  | RANimp-SRNS |  | Olivier Guyot, Nokia | TSG |  |
| 34 | 79.5 | FS Improvement of Radio Resource Management across RNS and RNS/PSS |  | 201d | 2001-03-16 A | 2001-12-21 A | 100% |  | 2001-03-16 | 2001-12-21 | 201d |  |  | finish no earlier than 2001-12-21 | R3 | 1608h | 1608h | Rel-5 | 22001 | RANimp-ImpRRM |  | Antti Toskala, Nokia | TSG |  |
| 35 | 79.6 | Re-arrangements of Iub transport bearers |  | 271d | 2001-03-16 A | 2002-03-29 A | 100% |  | 2001-03-16 | 2002-03-29 | 271d |  |  | finish no earlier than 2002-03-29 | R3 | 2168h | 2168h | Rel-5 | 22002 | RANimp-TTPS |  | Antti Toskala, Nokia | TSG |  |
| 36 | 79.7 | RAB support enhancement for Rel-5 |  | 325d | 2001-04-02 A | 2002-06-28 A | 100% |  | 2001-04-02 | 2002-06-28 | 325d |  |  | finish no earlier than 2002-06-28 | R2 | 2600h | 2600h | Rel-5 |  | RANimp-RABSE5 |  | Juha Mikola, Nokia | TSG |  |
| 37 | 79.8 | Beamforming requirements for UE |  | 61d | 2001-09-21 A | 2001-12-14 A | 100% |  | 2001-09-21 | 2001-12-14 | 61d |  |  | finish no earlier than 2001-12-14 | R1 | 488h | 488h | Rel-5 |  | RANimp-BFR-UE |  | Jussi Kähtävä, Nokia | TSG |  |
| 38 | 79.9 | Support of Site Selection Diversity Transmission in UTRAN |  | 123d | 2001-12-14 A | 2002-06-04 A | 100% |  | 2001-12-14 | 2002-06-04 | 123d |  |  | finish no earlier than 2002-06-04 | R1 | 984h | 984h | Rel-5 |  | RANimp-SSDT |  | NEC | TSG |  |
| 39 | 79.10 | Node B Synchronisation for 1.28 Mcps TDD |  | 271d | 2001-03-16 A | 2002-03-29 A | 100% |  | 2001-03-16 | 2002-03-29 | 271d |  |  | finish no earlier than 2002-03-29 | R1 | 2168h | 2168h | Rel-5 | 2472 | RANimp-NBSLCR |  | Jinling HU, CWTS/CATT | TSG |  |
| 40 | 79.11 | Start Testing | milestone | 0d | 2001-12-03 | 2001-12-03 |  |  | 2001-12-03 | 2001-12-03 | 0d | 327d | 21d | start no earlier than 2001-12-03 | MLST |  |  |  | 1912 |  |  |  |  |  |

Notes:
- 7: update WID / 30.11.2001: To CN #14 for approval
- 10: 30 November: Completion date shifted to March 2002
- 18: Stopped at RAN#14; work on this task was performed as part of High Speed Downlink Packet Access feature
- 24: start/finish dates set / Not started due to lack of supporting companies
- 25: start/finish dates set / Not started yet due to lack of supporting companies
- 30: FS was closed and introduction of WI not agreed at RAN #16
- 34: FS was closed and WI was introduced at RAN #14
- 36: RFC 3095 context relocation
- 38: RP-020356

| ID | WBS | Task | Duration | Start | Finish | Predecessors | Complete | Remaining | Baseline start | Baseline finish | Baseline duration | Total slack | Constraint | Resources | Work | Actual work | Text3 | Text9 | Text1 | Text6 | Text7 | Text4 | Text8 | Text2 |
| --- | --- | --- | --- | --- | --- | --- | --- | --- | --- | --- | --- | --- | --- | --- | --- | --- | --- | --- | --- | --- | --- | --- | --- | --- |
| 41 | 79.12 | **Conformance Test Aspects - RAN Improvements** | 565d? | 2002-01-01 | 2004-03-01 | 40 |  |  | 2002-01-01 | 2002-09-02 | 175d | 2d |  | T1 | 8008h |  | 0% | 2102 |  |  |  |  |  |  |
| 42 | 79.12.1 | Testing Radio access bearer support enhancments | 175d | 2002-01-01 | 2002-09-02 |  |  |  | 2002-01-01 | 2002-09-02 | 175d | 392d | finish no earlier than 2002-09-02 | T1 | 1400h |  |  | 2222 |  |  |  |  |  |  |
| 43 | 8.12.2 | General changes to TS34.121 and TS34.122 corresponding to release 5 | 261d? | 2003-03-03 | 2004-03-01 |  |  |  | 2003-03-03 | 2004-03-01 | 261d? | 2d | finish no earlier than 2004-03-01 | T1 | 2088h |  | 34.108, 34.121, 34.122 |  | RANimp-test | Rel-5 | TSG |  |  |  |
| 44 | 80 | UTRAN Sharing in Connected Mode | 197d | 2001-12-03 A | 2002-09-03 A |  | 100% |  | 2001-12-03 | 2002-09-03 | 197d |  | finish no earlier than 2002-09-06 | R3 | 1576h | 1576h |  |  | NETSHARE | Rel-5 |  | Martin Israelsson, Ericsson |  |  |
| 45 | 81 | **Provisioning of IP-based multimedia services** | 1088d | 2000-01-03 A | 2004-03-03 |  | 92% | 90.44d | 2000-01-03 | 2003-09-30 | 977d | 0d |  | S1 | 185185h | 155140h |  |  | IMS | NA | TSG | Mark Cataldo, Openwave | MichaelC/Alain |  |
| 46 | 81.1 | **Call control and roaming to support IMS in UMTS** | 640d | 2000-01-03 A | 2002-06-14 |  | 98% | 12.24d | 2000-01-03 | 2002-06-14 | 640d | 448d |  | S2 | 82726.6h | 72776.6h |  |  | IMS-CCR | Rel-5 | TSG | Liz Daniel, Lucent |  |  |
| 47 | 81.1.1 | Stage 1 | 215d | 2000-02-21 A | 2000-12-15 A |  | 100% |  | 2000-02-21 | 2000-12-15 | 215d |  | finish no earlier than 2000-09-21 | S1 | 1720h | 1720h | 22.228 | 1633 |  |  |  | Mark Cataldo, Motorola |  | CCaR |
| 48 | 81.1.2 | Stage 2 (Architecture and Main flows) | 246d | 2000-04-14 A | 2001-03-23 A |  | 100% |  | 2000-04-14 | 2001-03-23 | 246d |  | finish no earlier than 2001-03-23 | S2 | 1968h | 1968h | 23.228 | 1514 |  |  | TSG | Liz Daniel, Lucent |  | CCaR |
| 49 | 81.1.3 | Impact on MM/CC/SM | 400d | 2000-08-28 A | 2002-03-08 A |  | 100% |  | 2000-08-28 | 2002-03-08 | 400d |  | finish no earlier than 2002-03-08 | N1 | 3200h | 3200h |  | 1296 | IMS-CCR-IWMM |  |  | Keith Drage, Lucent |  | CCaR |
| 50 | 81.1.4 | **SIP Call Control protocol for the IMS** | 640d | 2000-01-03 A | 2002-06-14 |  | 98% | 13.73d | 2000-01-03 | 2002-06-14 | 640d | 448d |  | N1 | 70800h | 65682h | TS 24.228, TS 24.229, TS 23.218 |  |  |  | TSG | Keith Drage, Lucent |  |  |
| 51 | 81.1.4.1 | IMS signalling flows | 385d | 2000-10-02 A | 2002-03-22 A |  | 100% |  | 2000-10-02 | 2002-03-22 | 385d |  | finish no earlier than 2002-03-22 | N1 | 3080h | 3080h | TS 24.228 | 1998 |  |  | TSG |  |  | CCaR |
| 52 | 81.1.4.2 | IMS stage 3 | 385d | 2000-10-02 A | 2002-03-22 A |  | 100% |  | 2000-10-02 | 2002-03-22 | 385d |  | finish no earlier than 2002-03-22 | N1 | 3080h | 3080h | TS 24.229 | 1278 |  |  | TSG |  |  | CCaR |
| 53 | 81.1.4.3 | IMS Session Handling; stage 2 | 385d | 2000-10-02 A | 2002-03-22 A |  | 100% |  | 2000-10-02 | 2002-03-22 | 385d |  | finish no earlier than 2002-03-22 | N1 | 3080h | 3080h | TS 23.218 | 2255 |  |  | TSG |  |  |  |
| 54 | 81.1.4.4 | **Main IETF dependencies** | 635d | 2000-01-03 A | 2002-06-07 |  | 99% | 0d | 2000-01-03 | 2002-06-07 | 635d | 0d |  | NP | 45392h | 43712h |  |  |  |  |  |  |  |  |
| 55 | 81.1.4.4.1 | IETF: RFC 3261 (Session Initiation Protocol) | 346d | 2000-11-24 A | 2002-03-22 A |  | 100% |  | 2000-11-24 | 2002-03-22 | 346d |  | finish no earlier than 2002-03-22 | N1 | 2768h | 2768h |  |  |  |  |  |  |  |  |
| 56 | 81.1.4.4.2 | IETF: RFC 3262 (Reliability of provisional responses) | 346d | 2000-11-24 A | 2002-03-22 A |  | 100% |  | 2000-11-24 | 2002-03-22 | 346d |  | finish no earlier than 2002-03-22 | N1 | 2768h | 2768h |  |  |  |  |  |  |  |  |
| 57 | 81.1.4.4.3 | IETF: RFC 3312 (Without COMET)(Integration of resource management and SIP) | 382d | 2000-11-24 A | 2002-05-13 A |  | 100% |  | 2000-11-24 | 2002-05-13 | 382d |  | finish no earlier than 2002-05-13 | N1 | 3056h | 3056h |  |  |  |  |  |  |  |  |
| 58 | 81.1.4.4.4 | IETF: RFC 3323 (SIP extensions for caller identity and privacy) | 382d | 2000-11-24 A | 2002-05-13 A |  | 100% |  | 2000-11-24 | 2002-05-13 | 382d |  | finish no earlier than 2002-05-13 | N1 | 3056h | 3056h |  |  |  |  |  |  |  |  |
| 59 | 81.1.4.4.5 | IETF: RFC 3313 (SIP extensions for media authorization) | 382d | 2000-11-24 A | 2002-05-13 A |  | 100% |  | 2000-11-24 | 2002-05-13 | 382d |  | finish no earlier than 2002-05-13 | N1 | 3056h | 3056h |  |  |  |  |  |  |  |  |
| 60 | 81.1.4.4.6 | IETF: RFC 3265 (specific event notification) | 346d | 2000-11-24 A | 2002-03-22 A |  | 100% |  | 2000-11-24 | 2002-03-22 | 346d |  | finish no earlier than 2002-03-22 | N1 | 2768h | 2768h |  |  |  |  |  |  |  |  |
| 61 | 81.1.4.4.7 | IETF: RFC editor Queue (refer method) | 401d | 2000-11-24 A | 2002-06-07 A |  | 100% |  | 2000-11-24 | 2002-06-07 | 401d |  | finish no earlier than 2002-06-07 | N1 | 3208h | 3208h |  |  |  |  |  |  |  |  |
| 62 | 81.1.4.4.8 | IETF: RFC editor Queue (DHCP options for SIP servers) | 382d | 2000-11-24 A | 2002-05-13 A |  | 100% |  | 2000-11-24 | 2002-05-13 | 382d |  | finish no earlier than 2002-05-13 | N1 | 3056h | 3056h |  |  |  |  |  |  |  |  |
| 63 | 81.1.4.4.10 | IETF: RFC 3267 (AMR and AMR WB RTP and SDP) | 346d | 2000-11-24 A | 2002-03-22 A |  | 100% |  | 2000-11-24 | 2002-03-22 | 346d |  | finish no earlier than 2002-03-22 | N1 | 2768h | 2768h |  |  |  |  |  |  |  |  |
| 64 | 81.1.4.4.11 | IETF: RFC 3266 (IPv6 support within SDP) | 580d | 2000-01-03 A | 2002-03-22 A |  | 100% |  | 2000-01-03 | 2002-03-22 | 580d |  | finish no earlier than 2002-03-22 | N1 | 4640h | 4640h |  |  |  |  |  |  |  |  |
| 65 | 81.1.4.4.12 | IETF: RFC 3311 (The Update method) | 382d | 2000-11-24 A | 2002-05-13 A |  | 100% |  | 2000-11-24 | 2002-05-13 | 382d |  | finish no earlier than 2002-05-13 | N1 | 3056h | 3056h |  |  |  |  |  |  |  |  |
| 66 | 81.1.4.4.13 | IETF: RFC 3324 (Network Asserted Identity) | 382d | 2000-11-24 A | 2002-05-13 A |  | 100% |  | 2000-11-24 | 2002-05-13 | 382d |  | finish no earlier than 2002-05-13 | N1 | 3056h | 3056h |  |  |  |  |  |  |  |  |
| 67 | 81.1.4.4.14 | IETF: RFC editor Queue (Various 3GPP Private Extensions) | 382d | 2000-11-24 A | 2002-05-13 A |  | 100% |  | 2000-11-24 | 2002-05-13 | 382d |  | finish no earlier than 2002-05-13 | N1 | 3056h | 3056h |  |  |  |  |  |  |  |  |

Notes:
- 42: duration set to 6 months (was 0) / Task not started due to lack of supporting companies
- 44: Formerly 'Shared Network support in connected mode', renamed at RAN #16.
- 45: S1 WI proposed S1-000290 / TR22.976, WI Rapporteur, Mark Cataldo, Motorola
- 47: Issues include e.g.: Roaming requirements, Requirements on supplementary services, Interworking requirements / Text5: 17.-21.7., S1#9, Completion of CR's against 22 series [dates taken from 22.976]
- 48: Issues include e.g.: Mobile IP, RAB selection principles, Optimized VoIP bearer mechanisms, SIP multimedia protocol / Text5: R00 stage 2 at least 80 % complete in TSGS #8 21.-23.6.2000 [WI dates need revision. To be revised by TSG#8]
- 49: Per 26/2-02: This is understood to be the PCO & TFT CRs which CN1 provides to TSGN #15 for approval. If this is correct understanding, then the task is 100 % complete. / Text5: drage@lucent.com
- 50: TSGN_10 approved the change:CN1 - SA2 SIP joint meeting spotted one more place for improvement: work tasks with ID 1998 and 1278 are actually subtasks under of single CN1 WT. One WI has been approved for the CN1 WT with title "SIP Call Control protocol... / Text5: drage@lucent.com
- 51: TS 24.228...
- 52: TS 24.229...
- 53: TS 23.218...

| ID | WBS | Task | Duration | Start | Finish | Complete | Remaining | Baseline start | Baseline finish | Baseline duration | Total slack | Constraint | Resources | Work | Actual work | Text2 | Text9 | Text1 | Text3 | Text5 | Text7 | Text6 |
| --- | --- | --- | --- | --- | --- | --- | --- | --- | --- | --- | --- | --- | --- | --- | --- | --- | --- | --- | --- | --- | --- | --- |
| 68 | 81.1.4.5 | **Addressing** | 380d | 2000-10-09 A | 2002-03-22 A | 100% |  | 2000-10-09 | 2002-03-22 | 380d |  |  | S2 | 7744h | 7744h | CCaR | 1290 |  |  |  |  |  |
| 69 | 81.1.4.5.1 | Architectural issues | 235d | 2000-10-09 A | 2001-08-31 A | 100% |  | 2000-10-09 | 2001-08-31 | 235d |  | finish no earlier than 2001-03-16 | S2 | 1880h | 1880h | CCaR | 1291 |  |  |  |  |  |
| 70 | 81.1.4.5.2 | Impact on HSS | 353d | 2000-11-15 A | 2002-03-22 A | 100% |  | 2000-11-15 | 2002-03-22 | 353d |  | finish no earlier than 2002-03-22 | N4 | 2824h | 2824h | CCaR | 1292 |  |  |  |  |  |
| 71 | 81.1.4.6 | **Service Examples (Work stopped)** | 304d | 2001-04-17 A | 2002-06-14 | 50% | 152d | 2001-04-17 | 2002-06-14 | 304d | 448d |  | S1 | 4864h | 1502.4h |  |  | IMS-Sex | 22.928 | mcatald1@email.mot.com | TSG |  |
| 72 | 81.1.4.6.1 | IMS Framework Report (work stopped) | 304d | 2001-04-17 A | 2002-06-14 | 50% | 152d | 2001-04-17 | 2002-06-14 | 304d | 448d | finish no earlier than 2002-06-14 | S1 | 2432h | 1216h |  |  | IMS-FrWk | 22.941 | rwohlert@tri.sbc.com | TSG |  |
| 73 | 81.2 | **Access Security for IMS** | 190d | 2001-10-08 A | 2002-06-28 A | 100% |  | 2001-06-25 | 2002-07-05 | 270d |  |  | S3 | 4120h | 4120h |  | 1298 | IMS-ASEC |  | krister.boman@emw.ericsson.se | TSG | Rel-5 |
| 74 | 81.2.2 | IMS impacts on UICC (ISIM application) | 185d | 2001-10-08 A | 2002-06-21 A | 100% |  | 2001-10-08 | 2002-06-21 | 185d |  | finish no earlier than 2002-06-21 | T3 | 1480h | 1480h |  |  |  |  |  |  |  |
| 75 | 81.2.3 | SIP extensions for Integrity protection | 140d | 2001-12-17 A | 2002-06-28 A | 100% |  | 2001-12-17 | 2002-06-28 | 140d |  | finish no earlier than 2002-06-28 | N1 | 1120h | 1120h |  |  |  |  |  |  |  |
| 76 | 81.3 | Security Aspects of Requirement for Network Configuration Independence | 130d | 2001-07-02 A | 2001-12-28 A | 100% |  | 2001-07-02 | 2001-12-28 | 130d |  | finish no earlier than 2001-12-28 | S3 | 1040h | 1040h |  |  | SEC1-NCI |  | hugh.shieh@attws.com | TSG | Rel-5 |
| 77 | 81.4 | Lawful interception | 410d | 2000-09-04 A | 2002-03-29 A | 100% |  | 2000-09-04 | 2002-03-29 | 410d |  | finish no earlier than 2002-03-29 | S3 | 3280h | 3280h | CCaR | 1299 | IMS-LI |  | berthold.wilhelm@regtp.de | TSG | Rel-5 |
| 78 | 81.5 | Charging and OAM&P for IMS | 383d | 2000-12-25 A | 2002-06-12 A | 100% |  | 2000-12-25 | 2002-06-12 | 383d |  | finish no earlier than 2002-06-12 | S5 | 3064h | 3064h | CCaR | 1303 | IMS-OAM | 32-series | Albert.Yuhan@voicestream.com; Michael.Truss@MOTOROLA.COM | TSG | Rel-5 |
| 79 | 81.6 | **Multimedia codecs and protocols for conversational PS services** | 568d | 2000-07-26 A | 2002-09-27 A | 100% |  | 2000-07-26 | 2002-09-27 | 568d |  |  | S4 | 15640h | 15640h |  |  | IMS-CODEC | 26.235, 26.236 | pasi.s.ojala@nokia.com | TSG | Rel-5 |
| 80 | 81.6.1 | Codecs | 427d | 2000-07-26 A | 2002-03-14 A | 100% |  | 2000-07-26 | 2002-03-14 | 427d |  | finish no earlier than 2001-03-21 | S4 | 3416h | 3416h |  | 2039 |  | 26.235, 26.236 |  | TSG |  |
| 81 | 81.6.2 | Transport protocols | 1d | 2002-03-12 A | 2002-03-12 A | 100% |  | 2002-03-12 | 2002-03-12 | 1d |  | finish no earlier than 2002-03-12 | S4 | 8h | 8h |  |  | IMS-CODEC | 26.236 |  |  | Rel-5 |
| 82 | 81.6.4 | recommendation for QoS parameter values for various media types | 195d | 2001-12-31 A | 2002-09-27 A | 100% |  | 2001-12-31 | 2002-09-27 | 195d |  | finish no earlier than 2002-09-27 | S4 | 1560h | 1560h |  |  |  |  |  | TSG |  |
| 83 | 81.6.5 | IETF: RFC 3310 (HTTP Digest Authentication using AKA) | 382d | 2000-11-24 A | 2002-05-13 A | 100% |  | 2000-11-24 | 2002-05-13 | 382d |  | finish no earlier than 2002-05-13 | N1 | 3056h | 3056h |  |  |  |  |  |  |  |
| 84 | 81.6.6 | IETF: RFC 3329 (Security mechanism agreement for SIP connections) | 382d | 2000-11-24 A | 2002-05-13 A | 100% |  | 2000-11-24 | 2002-05-13 | 382d |  | finish no earlier than 2002-05-13 | N1 | 3056h | 3056h |  |  |  |  |  |  |  |
| 85 | 81.7 | **SIP message compression** | 185d | 2001-09-24 A | 2002-06-07 A | 100% |  | 2001-09-24 | 2002-06-07 | 185d |  |  | S2 | 3128h | 3128h |  |  |  |  |  |  | Rel-5 |
| 86 | 81.7.1 | Stage 2 | 25d | 2001-09-24 A | 2001-10-26 A | 100% |  | 2001-09-24 | 2001-10-26 | 25d |  | finish no earlier than 2001-10-26 | S2 | 200h | 200h |  |  |  |  |  |  |  |
| 87 | 81.7.2 | Compression signalling | 181d | 2001-09-28 A | 2002-06-07 A | 100% |  | 2001-09-28 | 2002-06-07 | 181d |  | finish no earlier than 2002-06-07 | N1 | 1448h | 1448h |  |  |  |  |  |  |  |
| 88 | 81.8 | **Stage 3 description of IMS interfaces** | 383d | 2001-03-14 A | 2002-08-30 | 99% | 4.93d | 2001-03-14 | 2002-08-30 | 383d | 393d |  | NP | 29531.6h | 29151.4h |  |  |  |  |  |  | Rel-5 |
| 89 | 81.8.1 | Cx interface (HSS to CSCF) | 135.95d | 2001-03-14 A | 2002-06-07 A | 100% |  | 2001-03-14 | 2002-06-07 | 135.95d |  | finish no earlier than 2002-06-07 | N4 | 1087.58h | 1087.58h |  |  |  |  |  | TSG |  |
| 90 | 81.8.2 | Mp interface (MRFC - MRFP) enhancements | 258d | 2001-03-14 A | 2002-03-08 A | 100% |  | 2001-03-14 | 2002-03-08 | 258d |  | finish no earlier than 2002-06-07 | N4 | 2064h | 2064h |  |  |  |  |  |  |  |
| 91 | 81.8.3 | Mw interface (CSCF to P-CSCF) | 323d | 2001-03-14 A | 2002-06-07 A | 100% |  | 2001-03-14 | 2002-06-07 | 323d |  | finish no earlier than 2002-06-07 | N1 | 2584h | 2584h |  |  |  |  |  |  |  |
| 92 | 81.8.4 | Mr interface (CSCF to MRF) | 273d | 2001-03-14 A | 2002-03-29 A | 100% |  | 2001-03-14 | 2002-03-29 | 273d |  | finish no earlier than 2002-03-29 | N1 | 2184h | 2184h |  |  |  |  |  |  |  |
| 93 | 81.8.5 | Dx interface (I-CSCF to SLF) | 323d | 2001-03-14 A | 2002-06-07 A | 100% |  | 2001-03-14 | 2002-06-07 | 323d |  | finish no earlier than 2002-06-07 | N4 | 2584h | 2584h |  |  |  |  |  |  |  |
| 94 | 81.8.6 | Go interface (GGSN to PCF) | 323d | 2001-03-14 A | 2002-06-07 A | 100% |  | 2001-03-14 | 2002-06-07 | 323d |  | finish no earlier than 2002-06-07 | N3 | 2584h | 2584h |  |  |  |  |  |  |  |
| 95 | 81.8.7 | ISC (IMS Service Control) Interface | 323d | 2001-03-14 A | 2002-06-07 A | 100% |  | 2001-03-14 | 2002-06-07 | 323d |  | finish no earlier than 2002-06-07 | N1 | 2584h | 2584h |  |  |  |  |  |  |  |
| 96 | 81.8.8 | Sh interface (HSS to AS) | 82d | 2002-02-14 A | 2002-06-07 A | 100% |  | 2002-02-14 | 2002-06-07 | 82d |  | finish no earlier than 2002-06-07 | N4 | 656h | 656h |  |  |  |  |  |  |  |
| 97 | 81.8.9 | Si interface (HSS to IM-SSF) | 162.5d | 2002-01-16 A | 2002-08-30 | 72% | 45d | 2002-01-16 | 2002-08-30 | 162.5d | 393d | finish no earlier than 2002-06-07 | N4 | 1300h | 940h |  |  |  |  |  |  |  |
| 98 | 81.8.10 | Gm interface (UE to CSCF) | 323d | 2001-03-14 A | 2002-06-07 A | 100% |  | 2001-03-14 | 2002-06-07 | 323d |  | finish no earlier than 2002-06-07 | N1 | 2584h | 2584h |  |  |  |  |  |  |  |
| 99 | 81.8.11 | Mi interface (CSCF to BGCF) | 323d | 2001-03-14 A | 2002-06-07 A | 100% |  | 2001-03-14 | 2002-06-07 | 323d |  | finish no earlier than 2002-06-07 | N1 | 2584h | 2584h |  |  |  |  |  |  |  |
| 100 | 81.8.12 | Mj interface (BGCF to MGCF) | 323d | 2001-03-14 A | 2002-06-07 A | 100% |  | 2001-03-14 | 2002-06-07 | 323d |  | finish no earlier than 2002-06-07 | N1 | 2584h | 2584h |  |  |  |  |  |  |  |
| 101 | 81.8.13 | Mk interface (BGCF to BGCF) | 323d | 2001-03-14 A | 2002-06-07 A | 100% |  | 2001-03-14 | 2002-06-07 | 323d |  | finish no earlier than 2002-06-07 | N1 | 2584h | 2584h |  |  |  |  |  |  |  |
| 102 | 81.9 | Support of VHE/OSA by entities and protocols of the IMS (e.g. CSCF) | 186d | 2001-09-21 A | 2002-06-07 A | 100% |  | 2001-09-21 | 2002-06-07 | 186d |  | finish no earlier than 2002-06-07 | N5 | 1488h | 1488h | CCaR | 1310 | IMS-ONOSA | 29.198, 29.998 | Ard.Jan.Moerdijk@eln.ericsson.se | TSG | Rel-5 |

Notes:
- 70: 17th May, KK: This is cover by 29.228 & 29228. Work complete.
- 71: Text4: Mark Cataldo, Motorola
- 72: Text4: Randolph Wohlert, SBC Technology Resources, Inc.
- 73: TS33.203 will be presented for info at SA#14 and is scheduled for approval at SA#15. Dependencies on IETF exist. Approved SA#15 / Text4: Krister Boman, Ericsson
- 74: Text4: Jeremy Norris (Vodafone)
- 75: Per 26/2-02: CN1 is not aware of any requirements and is not doing anything on this task.
- 76: Incorporated into IMS access security TS (33.203) which will be presented for info at SA#14 and is scheduled for approval at SA#15.Editors notes removed SA#16&17 / Text4: Hugh Shieh, AT&T Wireless Services
- 77: Rel-5 33.106 and 33.107 approved at SA#12.Revised WID including new Rel-5 specification (33.108) scheduled for approval at SA#14. 33.108 approved SA#16. CR at SA#17 / Text4: Berthold Wilhelm, Reg TP
- 78: Text4: Albert YUHAN (VoiceStream Wireless), Michael TRUSS (Motorola)
- 79: Text4: B. Aronson, Toshiba, and P. Ojala, Nokia
- 81: Text4: P. Ojala, Nokia
- 89: DAB 12/12/01 to 75% / CN4 14/02/02 to 79% / 17th May work complete. 3GPP TSs 29.228 and 29.229 will be sent for proval in CN#16
- 90: [DAB 08-03-02] - No work required in CN4
- 93: CN4#11 30/11/01: No inputs received in CN4 / 14/02/02 Completed(introduced in 29.228)
- 94: [DAB - 23/05/03] - 100 % complete
- 96: CN4#11 30/11/01: No inputs received in CN4 / CN4#12bis 14/02/02: WID approved / 17th May 100% complete. 3GPP TS 29.329 will be sent for approval in CN#16
- 97: SA16: Part of Rel5 only if completed in September 02
- 102: Text4: Ard-Jan MOERDIJK (Ericsson)

| ID | WBS | Task | Type | Duration | Start | Finish | Predecessors | Complete | Remaining | Baseline start | Baseline finish | Baseline duration | Total slack | Free slack | Constraint | Resources | Work | Actual work | Text1 | Text2 | Text4 | Text6 | Text9 | Text3 | Text5 | Text7 | Text8 |
| --- | --- | --- | --- | --- | --- | --- | --- | --- | --- | --- | --- | --- | --- | --- | --- | --- | --- | --- | --- | --- | --- | --- | --- | --- | --- | --- | --- |
| 103 | 81.10 | **CAMEL control of IMS services** |  | 365d | 2001-04-16 A | 2002-09-06 |  | 91% | 34.05d | 2001-04-16 | 2002-09-06 | 365d | 388d |  |  | N2 | 9952h | 9023.6h | IMS-CAMEL | CCaR | Angelica Remoquillo, Lucent | Rel-5 | 1310 |  |  |  |  |
| 104 | 81.10.1 | Stage2 work 'general' |  | 365d | 2001-04-16 A | 2002-09-06 A |  | 100% |  | 2001-04-16 | 2002-09-06 | 365d |  |  | finish no earlier than 2002-09-06 | N2 | 2920h | 2920h |  |  |  |  |  |  |  |  |  |
| 105 | 81.10.2 | Stage3 work 'CAP' |  | 175d | 2002-01-07 A | 2002-09-06 A |  | 100% |  | 2002-01-07 | 2002-09-06 | 175d |  |  | finish no earlier than 2002-09-06 | N2 | 1400h | 1400h |  |  |  |  |  |  |  |  |  |
| 106 | 81.10.3 | Stage2 work 'Si interface' |  | 175d | 2002-01-07 A | 2002-09-06 A |  | 100% |  | 2002-01-07 | 2002-09-06 | 175d |  |  | finish no earlier than 2002-09-06 | N2 | 1400h | 1400h |  |  |  |  |  |  |  |  |  |
| 107 | 81.10.4 | Stage3 work 'Si interface' |  | 82d | 2002-02-14 A | 2002-06-07 A |  | 100% |  | 2002-02-14 | 2002-06-07 | 82d |  |  | finish no earlier than 2002-06-07 | N4 | 656h | 656h |  |  |  |  |  |  |  |  |  |
| 108 | 81.10.5 | SDM issues for CAMEL control of IMS |  | 82d | 2002-02-14 | 2002-06-07 |  |  |  | 2002-02-14 | 2002-06-07 | 82d | 453d |  | finish no earlier than 2002-06-07 | N4 | 656h |  |  |  |  |  |  |  |  |  |  |
| 109 | 81.11 | Pre-pay/real-time charging in IMS |  | 196d | 2001-06-15 A | 2002-03-15 |  | 60% | 78.4d | 2001-06-15 | 2002-03-15 | 196d | 513d |  | finish no earlier than 2002-03-15 | S1 | 1568h | 940.8h |  |  |  | TBD |  |  |  |  |  |
| 110 | 81.12 | **Charging** |  | 289d | 2001-08-06 A | 2002-09-12 A |  | 100% |  | 2001-08-06 | 2002-09-12 | 289d |  |  |  | S5 | 4624h | 4624h | OAM-CH |  | Karl-Heinz NENNER (T-Mobile) | Rel-5 |  | 32.2xy | karl-heinz.nenner@t-mobile.de | TSG |  |
| 111 | 81.12.1 | Charging Implications of IMS architecture |  | 75d | 2001-08-06 A | 2001-11-16 A |  | 100% |  | 2001-08-06 | 2001-11-16 | 75d |  |  | finish no earlier than 2001-11-16 | S2 | 600h | 600h |  |  |  |  |  |  |  |  |  |
| 112 | 81.12.2 | Charging management for IMS (off-line & on-line) |  | 214d | 2001-11-19 A | 2002-09-12 A | 111 | 100% |  | 2001-11-19 | 2002-09-12 | 214d |  |  | finish no earlier than 2002-09-12 | S5 | 1712h | 1712h | OAM-CH |  |  | Rel-5 |  |  |  | TSG |  |
| 113 | 81.13 | **Other IETF depencies** |  | 401d | 2000-11-24 A | 2002-06-07 |  | 70% | 120.3d | 2000-11-24 | 2002-06-07 | 401d | 453d |  |  | NP | 9624h | 6736.8h |  |  |  | Rel-5 |  |  |  |  |  |
| 114 | 81.13.1 | IETF: draft-ietf-aaa-diameter - should be CN4 |  | 401d | 2000-11-24 A | 2002-06-07 |  | 90% | 40.1d | 2000-11-24 | 2002-06-07 | 401d | 453d |  | finish no earlier than 2002-06-07 | NP | 3208h | 2887.2h |  |  |  |  |  |  |  |  |  |
| 115 | 81.13.2 | IETF: draft-johansson-aaa-diameter-mm-app - should be CN4 |  | 401d | 2000-11-24 A | 2002-06-07 |  | 50% | 200.5d | 2000-11-24 | 2002-06-07 | 401d | 453d |  | finish no earlier than 2002-06-07 | NP | 3208h | 1604h |  |  |  |  |  |  |  |  |  |
| 116 | 81.14 | Start Testing | milestone | 0d | 2002-03-18 | 2002-03-18 |  |  |  | 2002-03-18 | 2002-03-18 | 0d | 308d | 0d | start no earlier than 2002-03-18 | MLST |  |  |  |  |  | Rel-5 | 1913 |  |  |  |  |
| 117 | 81.15 | Conformance Test Aspects - Provisioning of IMS |  | 205d | 2002-03-18 | 2002-12-27 | 116 |  |  | 2002-03-18 | 2002-12-27 | 205d | 308d |  | finish no earlier than 2002-12-27 | T1 | 1640h |  | IMS-TEST |  |  |  | 1844 |  |  |  |  |
| 118 | 81.16 | Testing of support for IMS - prose |  | 270d | 2002-09-18 | 2003-09-30 |  |  |  | 2002-09-18 | 2003-03-31 | 139d | 111d |  | finish no earlier than 2003-09-30 | T1 | 2160h |  |  |  | Dan Fox, Anritsu | Rel-5 |  | 34.108, 34.123 | dan.fox@eu.anritsu.com | TSG |  |
| 119 | 81.17 | Testing of support for IMS - TTCN |  | 381d | 2002-09-18 | 2004-03-03 |  |  |  | 2002-09-18 | 2003-09-30 | 270d | 0d |  | finish no earlier than 2004-03-03 | T1 | 3048h |  |  |  | Dan Fox, Anritsu | Rel-5 |  | 34.108, 34.123 | dan.fox@eu.anritsu.com | TSG |  |
| 120 | 82 | **Extended Transparent End-to-End PS Streaming Service** |  | 313d? | 2002-01-03 A | 2003-03-17 |  | 86% | 44.84d? | 2002-01-03 | 2003-03-17 | 313d? | 252d |  |  | S4 | 6224h | 4687.31h | PSS-E |  | O. Franceschi, Ericsson | Rel-5 |  | 26.233, 26.234 | olle.franceschi@nrj.ericsson.se | TSG | Paolo |
| 121 | 82.1 | **Stage 1** |  | 86d? | 2002-11-18 A | 2003-03-17 |  | 65% | 30.1d? | 2002-11-18 | 2003-03-17 | 86d? | 252d |  |  | S1 | 1376h | 1015.2h |  |  | Stephen Wolak, VODAFONE Group Plc |  |  | 22.233 | stephen.wolak@vodafone.com | TSG |  |
| 122 | 11.1.1 | Interaction with other services |  | 86d? | 2002-11-18 A | 2003-03-17 |  | 65% | 30.1d? | 2002-11-18 | 2003-03-17 | 86d? | 252d |  | finish no earlier than 2003-03-17 | S1 | 688h | 447.2h |  |  | Stephen Wolak, VODAFONE Group Plc |  |  | 22.233 | stephen.wolak@vodafone.com | TSG |  |
| 123 | 82.2 | Stage 2 (version Rel5 of TS 26.234) |  | 51d | 2002-01-03 A | 2002-03-14 A |  | 100% |  | 2002-01-03 | 2002-03-14 | 51d |  |  | finish no earlier than 2002-03-26 | S4 | 408h | 408h |  |  |  |  |  | 26.234 |  | TSG |  |
| 124 | 82.3 | RTP usage model |  | 242d | 2002-01-03 A | 2002-12-06 |  | 90% | 24.2d | 2002-01-03 | 2002-12-06 | 242d | 323d |  | finish no earlier than 2002-12-06 | S4 | 1936h | 1742.4h |  |  |  |  |  | 26.937 |  |  |  |
| 125 | 83 | **Rel-5 OSA enhancements** |  | 639d | 2000-07-11 A | 2002-12-20 |  | 96% | 24.93d | 2000-07-11 | 2002-06-14 | 504d | 313d |  |  | S1 | 62480h | 57172.1h | OSA1 |  | Jörg Swetina, SIEMENS AG | NA |  | 22.127, 23.127, 29.198-x, 29.998-x |  | TSG | Adrian |
| 126 | 83.1 | General Stage 2 for Rel5 |  | 194d | 2001-09-11 A | 2002-06-07 |  | 47% | 103d | 2001-09-11 | 2002-06-07 | 194d | 453d |  |  | S2 | 1232h | 408h |  |  |  |  | 2116 |  |  |  |  |

Notes:
- 103: SA16: Part of Rel5 only if Si completed in September 02
- 104: DAB 12.12.01 split into cn4 and cn2 parts
- 105: DAB 12.12.01 split into cn4 and cn2 parts
- 106: DAB 12.12.01 split into cn4 and cn2 parts
- 107: [DAB 08-03-02] - UID 12004 is MASTER of UID 14998 / 17 May need to be recearch possible impact on 23.008 & 23.016, changes to 29.002 are done.
- 108: [DAB 08-03-02] - No activity on this in CN4
- 110: Changed Rapp email
- 113: Was introduced at SA#13 by Ileana Leuca (exact position in the WP and related WG have to be defined)
- 117: The task is a building block, individual work items are being considered but are constrained by lack of supporting companies
- 121: 2nd resp SA4
- 122: 2nd resp SA4
- 123: 2nd resp SA2

| ID | WBS | Task | Duration | Start | Finish | Predecessors | Complete | Remaining | Baseline start | Baseline finish | Baseline duration | Total slack | Constraint | Resources | Work | Actual work | Text1 | Text6 | Text7 | Text2 | Text3 | Text4 | Text5 | Text8 | Text9 |
| --- | --- | --- | --- | --- | --- | --- | --- | --- | --- | --- | --- | --- | --- | --- | --- | --- | --- | --- | --- | --- | --- | --- | --- | --- | --- |
| 127 | 83.2 | **OSA APIs for Multimedia Call Control** | 499d | 2000-07-11 A | 2002-06-07 A |  | 100% |  | 2000-07-11 | 2002-06-07 | 499d |  |  | S2 | 5960h | 5960h | OSA1-CSCF | Rel-5 | TSG |  |  |  |  |  |  |
| 128 | 83.2.1 | Stage 1 | 438d | 2000-07-11 A | 2002-03-14 A |  | 100% |  | 2000-07-11 | 2002-03-14 | 438d |  | finish no earlier than 2002-03-14 | S1 | 3504h | 3504h |  |  | TSG | Ser | 22.127 | Manfred Leitgeb, SIEMENS AG | Manfred.leitgeb@siemens.at | Michael | 1430 |
| 129 | 83.2.2 | (Multimedia) Call Control - Stages 2 and 3 | 194d | 2001-09-11 A | 2002-06-07 A |  | 100% |  | 2001-09-11 | 2002-06-07 | 194d |  | finish no earlier than 2002-06-07 | N5 | 1552h | 1552h |  |  | TSG |  | 29.198-04 |  |  |  |  |
| 130 | 83.3 | Generic user interaction - Stage 3 | 194d | 2001-09-11 A | 2002-06-07 A |  | 100% |  | 2001-09-11 | 2002-06-07 | 194d |  | finish no earlier than 2002-06-07 | N5 | 1552h | 1552h |  | Rel-5 | TSG |  | 29.198-05 |  |  |  |  |
| 131 | 83.4 | Charging - Stage 3 | 194d | 2001-09-11 A | 2002-06-07 A |  | 100% |  | 2001-09-11 | 2002-06-07 | 194d |  | finish no earlier than 2002-06-07 | N5 | 1552h | 1552h |  | Rel-5 | TSG |  | 29.198-12 |  |  |  |  |
| 132 | 83.5 | Call Control Service Mapping; Multiparty Call Control SIP - Stage 3 | 194d | 2001-09-11 A | 2002-06-07 A |  | 100% |  | 2001-09-11 | 2002-06-07 | 194d |  | finish no earlier than 2002-06-07 | N5 | 1552h | 1552h |  | Rel-5 | TSG |  | 29.998-04-4 |  |  |  |  |
| 133 | 83.6 | WSDL APIs for SOAP/HTTP - Stage 3 | 455d | 2000-09-11 A | 2002-06-07 A |  | 100% |  | 2000-09-11 | 2002-06-07 | 455d |  | finish no earlier than 2002-06-07 | N5 | 3640h | 3640h |  | Rel-5 | TSG |  | 29.198, 29.998 |  |  |  |  |
| 134 | 83.7 | **OSA security** | 639d | 2000-07-11 A | 2002-12-20 |  | 93% | 44.46d | 2000-07-11 | 2002-06-14 | 504d | 313d |  | S3 | 15000h | 13956.3h | OSA1-SEC | Rel-5 | TSG | Ser |  | Colin Blanchard, BT | colin.blanchard@bt.com |  | 1419 |
| 135 | 83.7.1 | Stage 1 | 349d | 2000-07-11 A | 2001-11-09 A |  | 100% |  | 2000-07-11 | 2001-11-09 | 349d |  | finish no earlier than 2001-11-09 | S1 | 2792h | 2792h |  |  | TSG |  | 22.127 | Manfred Leitgeb, SIEMENS AG | Manfred.leitgeb@siemens.at | Michael | 2121 |
| 136 | 83.7.2 | Stage 3 | 430d | 2000-10-23 A | 2002-06-14 |  | 80% | 86d | 2000-10-23 | 2002-06-14 | 430d | 448d | finish no earlier than 2002-06-14 | S3 | 3440h | 2752h |  |  | TSG | Ser | ??? |  |  |  | 1421 |
| 137 | 83.7.3 | security related SCF(s) definition | 186d | 2001-09-21 A | 2002-06-07 A |  | 100% |  | 2001-09-21 | 2002-06-07 | 186d |  | finish no earlier than 2002-06-07 | N5 | 1488h | 1488h |  |  | TSG | Ser | 29.198, 29.998 | Ard-Jan MOERDIJK (Ericsson) | Ard.Jan.Moerdijk@eln.ericsson.se |  | 1422 |
| 138 | 83.7.4 | (possibly) changes required from supporting platforms, e.g. gsmSCF, HLR | 69d | 2000-09-11 A | 2000-12-14 A |  | 100% |  | 2000-09-11 | 2000-12-14 | 69d |  | finish no earlier than 2000-12-14 | S3 | 552h | 552h |  |  | TSG | Ser | ??? |  |  |  | 1423 |
| 139 | 12.7.5 | Security (moved from Rel-6) | 202d | 2002-03-14 A | 2002-12-20 A |  | 100% |  | 2002-03-14 | 2002-12-20 | 202d |  | finish no earlier than 2002-12-20 | S3 | 1616h | 1616h |  |  | TSG |  |  |  |  |  |  |
| 140 | 83.8 | **Interactions OSA - e-commerce** | 499d | 2000-07-11 A | 2002-06-07 |  | 96% | 17.51d | 2000-07-11 | 2002-06-07 | 499d | 453d |  | S2 | 6152h | 5976.8h | OSA1-ECOM | Rel-5 | TSG |  |  |  |  |  | 1424 |
| 141 | 83.8.1 | Stage 1 | 438d | 2000-07-11 A | 2002-03-14 |  | 95% | 21.9d | 2000-07-11 | 2002-03-14 | 438d | 514d | finish no earlier than 2000-12-28 | S1 | 3504h | 3328.8h |  |  | TSG |  | 22.127 | Jörg Swetina, SIEMENS AG |  |  | 1425 |
| 142 | 83.8.2 | Stages 2 and 3 | 186d | 2001-09-21 A | 2002-06-07 A |  | 100% |  | 2001-09-21 | 2002-06-07 | 186d |  | finish no earlier than 2002-06-07 | N5 | 1488h | 1488h |  |  | TSG |  | 29.198, 29.998 | Ard-Jan MOERDIJK (Ericsson) | Ard.Jan.Moerdijk@eln.ericsson.se |  | 1529 |
| 143 | 83.9 | Policy Management - Stage 3 | 194d | 2001-09-11 A | 2002-06-07 A |  | 100% |  | 2001-09-11 | 2002-06-07 | 194d |  | finish no earlier than 2002-06-07 | N5 | 1552h | 1552h |  | Rel-5 | TSG |  | 29.198-13 |  |  |  |  |
| 144 | 83.10 | Presence and Availability Management (PAM) - Stage 3 | 194d | 2001-09-11 A | 2002-06-07 A |  | 100% |  | 2001-09-11 | 2002-06-07 | 194d |  | finish no earlier than 2002-06-07 | N5 | 1552h | 1552h |  | Rel-5 | TSG |  | 29.198-14 |  |  |  |  |
| 145 | 83.11 | **CHECK STATUS - LCS - OSA interfaces** | 455d | 2000-09-11 A | 2002-06-07 |  | 99% | 0d | 2000-09-11 | 2002-06-07 | 455d | 0d |  | S1 | 5656h | 2590.4h | OSA1-LCSI | Rel-5 | TSG | Ser |  | Jörg Swetina, SIEMENS AG |  |  | 1786 |
| 146 | 83.11.1 | Stage 1 | 65d | 2000-09-11 A | 2000-12-08 A |  | 100% |  | 2000-09-11 | 2000-12-08 | 65d |  | finish no earlier than 2000-12-08 | S1 | 520h | 520h |  |  | TSG | Ser | 22.127 | Jörg Swetina, SIEMENS AG |  |  | 1787 |
| 147 | 83.11.2 | Stage 2 | 1d | 2000-12-11 A | 2000-12-11 A | 146 | 100% |  | 2000-12-11 | 2000-12-11 | 1d |  | finish no earlier than 2000-12-11 | S2 | 8h | 8h |  |  | TSG |  | 23.127 | Christophe GOURRAUD, Ericsson Canada |  |  | 2124 |
| 148 | 83.11.3 | Stage 3 | 186d | 2001-09-21 A | 2002-06-07 A | 147 | 100% |  | 2001-09-21 | 2002-06-07 | 186d |  | finish no earlier than 2002-06-07 | N5 | 1488h | 1488h |  |  | TSG | Ser | 29.198, 29.998 | Ard-Jan MOERDIJK (Ericsson) | Ard.Jan.Moerdijk@eln.ericsson.se |  | 1788 |
| 149 | 12.12 | Access to User Profile | 145d | 2001-06-01 A | 2001-12-20 A |  | 100% |  | 2001-06-01 | 2001-12-20 | 145d |  | finish no earlier than 2001-12-20 | S1 | 1160h | 1160h | OSA2-UP |  | TSG |  |  |  |  |  |  |
| 150 | 12.13 | **Retrieval of Terminal capabilities** | 634d | 2000-07-11 A | 2002-12-13 A |  | 100% |  | 2000-07-11 | 2002-12-13 | 634d |  |  | S2 | 10808h | 10808h | OSA2-TC |  | TSG | Ser |  |  |  |  | 1433 |
| 151 | 12.13.1 | Stage 1 | 132d | 2000-07-11 A | 2001-01-10 A |  | 100% |  | 2000-07-11 | 2001-01-10 | 132d |  | finish no earlier than 2001-01-10 | S1 | 1056h | 1056h |  |  | TSG | Ser | 22.127 | Jörg Swetina, SIEMENS AG |  |  | 1434 |
| 152 | 12.13.2 | Stages 2 and 3 | 321d | 2001-09-21 A | 2002-12-13 A | 151 | 100% |  | 2001-09-21 | 2002-12-13 | 321d |  | finish no earlier than 2002-12-13 | N5 | 2568h | 2568h |  |  | TSG | Ser | 29.198, 29.998 | Ard-Jan MOERDIJK (Ericsson) | Ard.Jan.Moerdijk@eln.ericsson.se |  | 1436 |
| 153 | 12.13.3 | Provisionning of the terminal capabilities | 445d | 2001-04-02 A | 2002-12-13 A |  | 100% |  | 2001-04-02 | 2001-11-30 | 175d |  | finish no earlier than 2002-12-13 | T2 | 3560h | 3560h |  |  | TSG |  | 23.057 |  |  |  | 2122 |

Notes:
- 127: For Rel5 even if completed by March
- 134: CR to correct security specifications in 29.198 scheduled for approval at CN#15
- 136: ??
- 139: Contribution at S3#25
- 145: az: CN#13 - changed to Rel5
- 147: az 24/05/01: Rel4 completion 90->100%.
- 153: According to T2 SWG1 M. Cataldo this is automatically supported by the MExE support of UAProf therefore 100% complete

| ID | WBS | Task | Duration | Start | Finish | Predecessors | Complete | Remaining | Baseline start | Baseline finish | Baseline duration | Total slack | Constraint | Resources | Work | Actual work | Text1 | Text4 | Text5 | Text6 | Text7 | Text8 | Text9 | Text2 | Text3 |
| --- | --- | --- | --- | --- | --- | --- | --- | --- | --- | --- | --- | --- | --- | --- | --- | --- | --- | --- | --- | --- | --- | --- | --- | --- | --- |
| 154 | 84 | **CAMEL phase 4** | 625d | 2000-04-17 A | 2002-09-06 |  | 99% | 0d | 2000-04-17 | 2002-09-06 | 625d | 0d |  | S1 | 41104h | 36244h | CAMEL4 | Keijo Palviainen, Nokia | keijo.palviainen@nokia.com | Rel-5 | WG | Andrijana | 1638 |  |  |
| 155 | 84.1 | Service requirements | 565d | 2000-04-17 A | 2002-06-14 A |  | 100% |  | 2000-04-17 | 2002-06-14 | 565d |  | finish no earlier than 2002-06-14 | S1 | 4520h | 4520h |  |  |  |  | WG |  | 1461 | Ser |  |
| 156 | 84.2 | Call Party Handling | 500d | 2000-07-10 A | 2002-06-07 A |  | 100% |  | 2000-07-10 | 2002-06-07 | 500d |  | finish no earlier than 2002-06-07 | N2 | 4000h | 4000h | CAMEL4-CPH |  |  |  | WG |  | 2012 | Ser |  |
| 157 | 84.3 | Mid call procedure for MO and MT calls | 495d | 2000-07-17 A | 2002-06-07 A |  | 100% |  | 2000-07-17 | 2002-06-07 | 495d |  | finish no earlier than 2002-06-07 | N2 | 3960h | 3960h | CAMEL4-MCP |  |  |  | WG |  | 2013 | Ser |  |
| 158 | 84.4 | Interactions with Optimal Routing | 430d | 2000-07-17 A | 2002-03-08 A |  | 100% |  | 2000-07-17 | 2002-03-08 | 430d |  | finish no earlier than 2002-03-08 | N2 | 3440h | 3440h | CAMEL4-IOR |  |  |  | WG |  | 2014 | Ser |  |
| 159 | 84.5 | Inclusion of flexible tone injection | 430d | 2000-07-17 A | 2002-03-08 A |  | 100% |  | 2000-07-17 | 2002-03-08 | 430d |  | finish no earlier than 2002-03-08 | N2 | 3440h | 3440h | CAMEL4-IFTI |  |  |  | WG |  | 2015 | Ser |  |
| 160 | 84.6 | CSE control over MT SMS | 430d | 2000-07-17 A | 2002-03-08 A |  | 100% |  | 2000-07-17 | 2002-03-08 | 430d |  | finish no earlier than 2002-03-08 | N2 | 3440h | 3440h | CAMEL4-CCSMS |  |  |  | WG |  | 2016 | Ser |  |
| 161 | 84.7 | Notification of GPRS mobility management to CSE | 331d | 2001-03-02 A | 2002-06-07 A |  | 100% |  | 2001-03-02 | 2002-06-07 | 331d |  | finish no earlier than 2002-06-07 | N2 | 2648h | 2648h | CAMEL4-NMM |  |  |  | WG |  | 2460 |  |  |
| 162 | 84.8 | Provision of location information of called subscriber | 266d | 2001-03-02 A | 2002-03-08 A |  | 100% |  | 2001-03-02 | 2002-03-08 | 266d |  | finish no earlier than 2002-03-08 | N2 | 2128h | 2128h | CAMEL4-LOCB |  |  |  | WG |  | 2458 |  |  |
| 163 | 84.9 | Inclusion of ODB data in the CSE_HLR interface | 175d | 2001-07-09 A | 2002-03-08 A |  | 100% |  | 2001-07-09 | 2002-03-08 | 175d |  | finish no earlier than 2002-03-08 | N2 | 1400h | 1400h | CAMEL4-ODB |  |  |  | WG |  |  |  |  |
| 164 | 84.10 | Location information during an ongoing call (Handover DP) | 280d | 2001-05-14 A | 2002-06-07 A |  | 100% |  | 2001-05-14 | 2002-06-07 | 280d |  | finish no earlier than 2002-06-07 | N2 | 2240h | 2240h | CAMEL4-HODP |  |  |  | WG |  |  |  |  |
| 165 | 84.11 | GPRS Any Time Interrogation | 240d | 2001-07-09 A | 2002-06-07 A |  | 100% |  | 2001-07-09 | 2002-06-07 | 240d |  | finish no earlier than 2002-06-07 | N2 | 1920h | 1920h | CAMEL4-ATI |  |  |  | WG |  |  |  |  |
| 166 | 84.12 | Transfer of IMEI (with SW version) to CSE | 240d | 2001-07-09 A | 2002-06-07 A |  | 100% |  | 2001-07-09 | 2002-06-07 | 240d |  | finish no earlier than 2002-06-07 | N2 | 1920h | 1920h | CAMEL4-ATI |  |  |  | WG |  |  |  |  |
| 167 | 84.13 | Handling of partial implementations of CAMEL4 | 131d | 2002-03-08 A | 2002-09-06 A |  | 100% |  | 2002-03-08 | 2002-09-06 | 131d |  | finish no earlier than 2002-06-07 | N2 | 1048h | 1048h | CAMEL4-SUB |  |  |  | WG |  |  |  |  |
| 168 | 85 | **Rel-5 MExE enhancements** | 250d | 2001-03-26 A | 2002-03-08 A |  | 100% |  | 2001-03-26 | 2002-03-08 | 250d |  |  | T2 | 2880h | 2880h | MEXE5 |  |  | Rel-5 | TSG | Friedhelm | 2464 | Ter |  |
| 169 | 85.1 | MExE Rel-5 Improvements and Investigations | 110d | 2001-03-26 A | 2002-03-08 A |  | 100% |  | 2001-03-26 | 2002-03-08 | 110d |  | finish no earlier than 2001-12-17 | T2 | 880h | 880h | MEXE5-ENHANC | Mark CATALDO, Motorola | mcatald1@MOTOROLA.COM |  | TSG |  | 2466 | Ter | 22.057, 23.057 |
| 170 | 86 | **Wideband Telephony Service - AMR** | 1035d | 2000-01-01 A | 2003-12-19 |  | 83% | 179.73d | 2000-01-01 | 2003-12-19 | 1035d | 53d |  | S4 | 83992h | 65964.1h | AMRWB | Imre Varga, Siemens AG | Imre.Varga@mch.siemens.de | Rel-5 | TSG | Paolo |  |  |  |
| 171 | 86.1 | **Specification** | 704d | 2000-01-01 A | 2002-09-12 |  | 99% | 0.4d | 2000-01-01 | 2002-09-12 | 704d | 384d |  | S4 | 22512h | 22481.9h |  |  |  |  |  |  |  |  |  |
| 172 | 86.1.1 | Stage 1 | 125d | 2001-10-01 A | 2002-03-22 A |  | 100% |  | 2001-10-01 | 2002-03-22 | 125d |  | finish no earlier than 2002-03-22 | S1 | 1000h | 1000h |  |  |  |  |  |  |  |  |  |
| 173 | 86.1.2 | **Stage 2** | 76d | 2000-01-03 A | 2000-04-17 A |  | 100% |  | 2000-01-03 | 2000-04-17 | 76d |  |  | S4 | 1224h | 1224h |  |  |  |  |  |  |  |  |  |
| 174 | 86.1.2.1 | Design Constraints | 26d | 2000-01-03 A | 2000-02-07 A |  | 100% |  | 2000-01-03 | 2000-02-07 | 26d |  |  | S4 | 208h | 208h |  |  |  |  |  |  | 1459 | Cod |  |
| 175 | 86.1.2.2 | General Description | 51d | 2000-02-07 A | 2000-04-17 A | 174 | 100% |  | 2000-02-07 | 2000-04-17 | 51d |  | start no earlier than 2000-09-25 | S4 | 408h | 408h |  |  |  |  |  |  | 1460 | Cod |  |
| 176 | 86.1.3 | Feasibility Study | 26d | 2000-04-28 A | 2000-06-02 A | 175 | 100% |  | 2000-04-28 | 2000-06-02 | 26d |  | finish no earlier than 2000-06-02 | S4 | 208h | 208h |  |  |  |  | TSG |  | 1626 | Cod | TR 26.901 |
| 177 | 86.1.4 | N1 Aspects | 66d | 2001-09-21 A | 2001-12-21 A |  | 100% |  | 2001-09-21 | 2001-12-21 | 66d |  | finish no earlier than 2001-12-21 | N1 | 528h | 528h |  |  |  |  | TSG |  | 1656 |  |  |
| 178 | 86.1.5 | N4 work | 83d | 2002-02-13 A | 2002-06-07 A |  | 100% |  | 2002-02-13 | 2002-06-07 | 83d |  | finish no earlier than 2002-06-07 | N4 | 664h | 664h |  |  |  |  | TSG |  | 1656 |  |  |

Notes:
- 163: Added on May 29, 2001
- 167: stage2 and stage3 CRs for approval at CN#17
- 176: S4,TD SP-000024: TR 26.901 v.4.0.0
- 177: Some of N1 tasks: Indication of supported codecs by the MS, Bearer cap negociation, codec indication to MS... / One common set of codec negotiation procedures will be specified as in ID1657.
- 178: CN4#11 30/11/01: No inputs to CN4 at this meeting / 14/02/02 work started 50% reached / 17 May work is done 100%

| ID | WBS | Task | Type | Duration | Start | Finish | Predecessors | Complete | Remaining | Baseline start | Baseline finish | Baseline duration | Total slack | Constraint | Resources | Work | Actual work | Text2 | Text7 | Text9 | Text1 | Text3 | Text4 | Text5 | Text6 | Text8 |
| --- | --- | --- | --- | --- | --- | --- | --- | --- | --- | --- | --- | --- | --- | --- | --- | --- | --- | --- | --- | --- | --- | --- | --- | --- | --- | --- |
| 179 | 86.1.6 | **Codec issues** |  | 704d | 2000-01-03 A | 2002-09-12 |  | 99% | 0.54d | 2000-01-03 | 2002-09-12 | 704d | 384d |  | S4 | 11504h | 11496h |  |  |  |  |  |  |  |  |  |
| 180 | 86.1.6.1 | Codec qualification |  | 86d | 2000-02-01 A | 2000-05-30 A |  | 100% |  | 2000-02-01 | 2000-05-30 | 86d |  | finish no earlier than 2000-05-31 | S4 | 688h | 688h | Cod | TSG | 1627 |  |  |  |  |  |  |
| 181 | 86.1.6.2 | Codec selection tests |  | 102d | 2000-06-01 A | 2000-10-20 A | 180 | 100% |  | 2000-06-01 | 2000-10-20 | 102d |  | finish no earlier than 2000-10-20 | S4 | 816h | 816h | Cod |  | 74 |  |  |  |  |  |  |
| 182 | 86.1.6.3 | Codec selection |  | 5d | 2000-10-23 A | 2000-10-27 A | 181 | 100% |  | 2000-10-23 | 2000-10-27 | 5d |  | finish no earlier than 2000-10-27 | S4 | 40h | 40h | Cod |  | 891 |  |  |  |  |  |  |
| 183 | 86.1.6.4 | TFO AMR-WB |  | 63d | 2001-12-18 A | 2002-03-14 A |  | 100% |  | 2001-12-18 | 2002-03-14 | 63d |  | finish no earlier than 2002-03-14 | S4 | 504h | 504h |  |  |  | AMRWB-TFO |  |  |  |  |  |
| 184 | 86.1.6.5 | Other codec issues (verif., caracterisation) |  | 441d | 2000-09-29 A | 2002-06-07 A |  | 100% |  | 2000-09-29 | 2002-06-07 | 441d |  | finish no earlier than 2002-06-07 | S4 | 3528h | 3528h | Cod |  | 890 |  | TR 26.976 |  |  |  |  |
| 185 | 86.1.6.6 | AMR-WB and narrrowband interworking |  | 121d | 2001-09-27 A | 2002-03-14 A |  | 100% |  | 2001-09-27 | 2002-03-14 | 121d |  | finish no earlier than 2002-03-14 | S4 | 968h | 968h |  |  |  | AMRWB-IWG |  |  |  |  |  |
| 186 | 86.1.6.7 | Interworking with fixed broadband networks |  | 121d | 2001-09-27 A | 2002-03-14 A |  | 100% |  | 2001-09-27 | 2002-03-14 | 121d |  | finish no earlier than 2002-03-14 | S4 | 968h | 968h |  |  |  |  |  |  |  |  |  |
| 187 | 86.1.6.8 | Tones and announcements |  | 121d | 2001-09-27 A | 2002-03-14 A |  | 100% |  | 2001-09-27 | 2002-03-14 | 121d |  | finish no earlier than 2002-03-14 | S4 | 968h | 968h |  |  |  |  |  |  |  |  |  |
| 188 | 86.1.6.9 | WB Conferencing and WB Voice Group calls (deleted) |  | 1d | 2000-01-03 | 2000-01-03 |  |  |  | 2000-01-03 | 2000-01-03 | 1d | 1087d | finish no earlier than 2000-01-03 | S1 | 8h |  |  |  |  |  |  |  |  |  |  |
| 189 | 86.1.6.10 | Billing, accounting and call detail record aspects |  | 251d | 2001-09-27 A | 2002-09-12 A |  | 100% |  | 2001-09-27 | 2002-09-12 | 251d |  | finish no earlier than 2002-09-12 | S5 | 2008h | 2008h |  |  |  |  | 32.2xy | Karl-Heinz NENNER (T-Mobile) | Karl-Heinz.Nenner@T-MOBILE.DE | Rel-5 |  |
| 190 | 86.1.7 | Start Testing | milestone | 0d | 2002-02-25 | 2002-02-25 |  |  |  | 2002-02-25 | 2002-02-25 | 0d | 528d | start no earlier than 2002-02-25 | MLST |  |  |  |  | 1989 |  |  |  |  |  |  |
| 191 | 86.1.8 | **Conformance tests (CRs to 34 series)** |  | 73d | 2000-01-01 A | 2000-04-12 A | 190 | 100% |  | 2000-01-01 | 2000-04-12 | 73d |  |  | T1 | 1752h | 1752h | Cod |  | 1855 |  |  |  |  |  |  |
| 192 | 86.1.8.1 | **Terminal Acoustic Characteristics** |  | 73d | 2000-01-01 A | 2000-04-12 A |  | 100% |  | 2000-01-01 | 2000-04-12 | 73d |  |  | S4 | 1168h | 1168h | Cod |  | 76 |  |  |  |  |  |  |
| 193 | 86.1.8.1.1 | Definition |  | 21d | 2000-01-01 A | 2000-01-31 A |  | 100% |  | 2000-01-01 | 2000-01-31 | 21d |  | finish no earlier than 2000-01-28 | S4 | 168h | 168h | Cod | TSG | 1628 |  | 26.131 |  |  |  |  |
| 194 | 86.1.8.1.2 | Test specification |  | 52d | 2000-02-01 A | 2000-04-12 A | 193 | 100% |  | 2000-02-01 | 2000-04-12 | 52d |  | finish no earlier than 2000-03-13 | S4 | 416h | 416h | Cod | TSG | 1629 |  | 26.132 |  |  |  |  |
| 195 | 86.2 | Floating-point ANSI-C code for the AMR-WB speech codec |  | 123d | 2001-09-25 A | 2002-03-14 A |  | 100% |  | 2001-09-25 | 2002-03-14 | 123d |  | finish no earlier than 2002-03-14 | S4 | 984h | 984h |  | TSG |  | AMRWB-FP | TS 26.204 | J. Vainio (Nokia) | janne.m.vainio@nokia.com |  |  |
| 196 | 86.3 | **Support of AMR-WB in GERAN: GMSK and 8PSK WB FR / HR** |  | 650d | 2000-01-03 A | 2002-06-28 A |  | 100% |  | 2000-01-03 | 2002-06-28 | 650d |  |  | GP | 23480h | 23480h | Cod | TSG | 80 | GAMRWB |  |  |  |  | Paolo |
| 197 | 86.3.1 | Channel coding in 45.003 |  | 590d | 2000-01-03 A | 2002-04-05 A |  | 100% |  | 2000-01-03 | 2002-04-05 | 590d |  |  | GP | 4720h | 4720h |  | TSG | 2265 |  |  |  |  |  |  |
| 198 | 86.3.2 | Signalling for the A interface |  | 390d | 2000-01-03 A | 2001-06-29 A |  | 100% |  | 2000-01-03 | 2001-06-29 | 390d |  | finish no earlier than 2001-06-29 | GP | 3120h | 3120h |  | TSG | 2266 |  |  |  |  |  |  |
| 199 | 86.3.3 | Signalling for Iu |  | 650d | 2000-01-03 A | 2002-06-28 A |  | 100% |  | 2000-01-03 | 2002-06-28 | 650d |  | finish no earlier than 2002-06-28 | GP | 5200h | 5200h |  | TSG | 2267 |  |  |  |  |  |  |
| 200 | 86.3.4 | Receiver performance in TS 45.005 |  | 325d | 2001-04-02 A | 2002-06-28 A |  | 100% |  | 2001-04-02 | 2002-06-28 | 325d |  | finish no earlier than 2002-06-28 | GP | 2600h | 2600h |  | TSG | 2268 |  |  |  |  |  |  |
| 201 | 86.3.5 | Link Adaptation in 45.009 |  | 330d | 2001-03-26 A | 2002-06-28 A |  | 100% |  | 2001-03-26 | 2002-06-28 | 330d |  | finish no earlier than 2002-06-28 | GP | 2640h | 2640h |  |  |  |  |  |  |  |  |  |
| 202 | 86.4 | **GERAN MS conformance test for AMR-WB** |  | 1035d | 2000-01-03 | 2003-12-19 |  |  |  | 2000-01-03 | 2003-12-19 | 1035d | 53d |  | GP | 16560h |  |  | TSG | 2269 |  |  |  |  |  | Paolo |
| 203 | 86.4.1 | MS test |  | 1035d | 2000-01-03 | 2003-12-19 |  |  |  | 2000-01-03 | 2003-12-19 | 1035d | 53d | finish no earlier than 2003-12-19 | GP | 8280h |  |  | TSG | 2270 |  |  |  |  |  |  |

Notes:
- 184: ANSI C-Code , Test Sequences, Speech Transcoding Functions, Error Concealment of lost frames, Source Controlled Bit-Rate Operation, Voice Activity Detector, Frame Structure
- 202: Not started

| ID | WBS | Task | Duration | Start | Finish | Complete | Remaining | Baseline start | Baseline finish | Baseline duration | Total slack | Constraint | Resources | Work | Actual work | Text7 | Text8 | Text9 | Text1 | Text2 | Text6 | Text3 | Text4 | Text5 |
| --- | --- | --- | --- | --- | --- | --- | --- | --- | --- | --- | --- | --- | --- | --- | --- | --- | --- | --- | --- | --- | --- | --- | --- | --- |
| 204 | 86.5 | **GERAN BTS conformance test for AMR-WB** | 761d | 2000-01-03 A | 2002-12-02 A | 100% |  | 2000-01-03 | 2002-12-02 | 761d |  |  | GP | 12176h | 12176h | TSG | Paolo | 2271 |  |  |  |  |  |  |
| 205 | 86.5.1 | BTS test | 761d | 2000-01-03 A | 2002-12-02 A | 100% |  | 2000-01-03 | 2002-12-02 | 761d |  | finish no earlier than 2002-12-02 | GP | 6088h | 6088h | TSG |  | 2272 |  |  |  |  |  |  |
| 206 | 11 | **Terminal interfaces** | 223d | 2001-05-14 A | 2002-03-20 A | 100% |  | 2001-05-14 | 2002-03-20 | 223d |  |  | T2 | 3568h | 3568h |  | Friedhelm | 1826 | TI | Ter | NA |  |  |  |
| 207 | 87 | Terminal local model enhancements | 223d | 2001-05-14 A | 2002-03-20 A | 100% |  | 2001-05-14 | 2002-03-20 | 223d |  | finish no earlier than 2002-03-20 | T2 | 1784h | 1784h | TSG |  | 1832 | TLM5 | Ter | Rel-5 | 23.227 |  |  |
| 208 | 88 | **Rel-5 Location Services enhancements** | 845d | 2000-04-03 A | 2003-06-27 | 81% | 162.63d | 2000-04-03 | 2003-06-27 | 845d | 178d |  | S2 | 175255h | 147349h | TSG | Alain |  | LCS1 |  | Rel-5 |  | Jan Kall, Nokia |  |
| 209 | 88.1 | **UE positioning** | 315d | 2001-01-15 A | 2002-03-29 | 99% | 0d | 2001-01-15 | 2002-03-29 | 315d | 0d |  | RP | 5560h | 5368.13h | TSG |  | 1600 | LCS1-UEpos |  | NA |  |  |  |
| 210 | 88.1.1 | UE positioning enhancements for 1.28 Mcps TDD | 255d | 2001-04-09 A | 2002-03-29 A | 100% |  | 2001-04-09 | 2002-03-29 | 255d |  | finish no earlier than 2002-03-29 | R2 | 2040h | 2040h | TSG |  | 2474 | LCS-128Pos |  | Rel-5 |  | Xiaohua Mei, CATT |  |
| 211 | 88.1.2 | Open SMLC-SRNC Interface within the UTRAN to support A-GPS Positioning | 195d | 2001-01-15 A | 2001-10-12 A | 100% |  | 2001-01-15 | 2001-10-12 | 195d |  |  | R2 | 1560h | 1560h | TSG |  | 2125 | LCS-INTF |  | Rel-5 |  | Kirk Burroughs, Qualcomm |  |
| 212 | 88.2 | **Event based and Periodic LCS** | 535d | 2000-05-22 A | 2002-06-07 | 88% | 62.67d | 2000-05-22 | 2002-06-07 | 535d | 453d |  | S1 | 6288h | 5551.48h |  |  | 1171 | LCS1-EBP | Loc | Rel-5 |  |  |  |
| 213 | 88.2.1 | Stage 1 | 130d | 2000-05-22 A | 2000-11-17 A | 100% |  | 2000-05-22 | 2000-11-17 | 130d |  | finish no earlier than 2000-07-21 | S1 | 1040h | 1040h |  |  | 1641 |  | Loc |  | 22.071 | Randolph Wohlert, Pacific Bell Wireless | rwohlert@tri.sbc.com |
| 214 | 88.2.2 | Stage 2 specification | 60d | 2000-11-06 A | 2001-01-26 | 51% | 29.4d | 2000-11-06 | 2001-01-26 | 60d | 808d | finish no earlier than 2001-01-26 | S2 | 480h | 244.8h |  |  | 1538 |  | Loc |  |  |  |  |
| 215 | 88.2.3 | Impact on MAP | 61d | 2002-03-15 A | 2002-06-07 A | 100% |  | 2002-03-15 | 2002-06-07 | 61d |  | finish no earlier than 2002-06-07 | N4 | 488h | 488h |  |  | 1179 |  | Loc |  |  |  |  |
| 216 | 88.3 | **Location Services for GERAN in A/Gb Mode** | 485d | 2000-04-03 A | 2002-02-08 A | 100% |  | 2000-04-03 | 2002-02-08 | 485d |  |  | GP | 24032h | 24032h | TSG | Paolo | 2436 | LCS-GERAN |  | Rel-5 |  |  |  |
| 217 | 88.3.1 | GERAN LCS Stage 2 (first release) | 485d | 2000-04-03 A | 2002-02-08 A | 100% |  | 2000-04-03 | 2002-02-08 | 485d |  | finish no earlier than 2002-02-08 | GP; S2; G1; G2 | 13152h | 13152h | TSG |  | 2437 |  |  |  |  |  |  |
| 218 | 88.3.2 | Gb interface support for LCS | 370d | 2000-04-03 A | 2001-08-31 A | 100% |  | 2000-04-03 | 2001-08-31 | 370d |  | finish no earlier than 2001-08-31 | GP | 2960h | 2960h | TSG |  | 2438 |  |  |  |  |  |  |
| 219 | 88.3.3 | L3 protocol support for LCS | 305d | 2000-04-03 A | 2001-06-01 A | 100% |  | 2000-04-03 | 2001-06-01 | 305d |  | finish no earlier than 2001-06-01 | GP | 2440h | 2440h | TSG |  | 2440 |  |  |  |  |  |  |
| 220 | 88.3.4 | Stage 3 specifications | 305d | 2000-04-03 A | 2001-06-01 A | 100% |  | 2000-04-03 | 2001-06-01 | 305d |  | finish no earlier than 2001-06-01 | GP | 2440h | 2440h | TSG |  | 2441 |  |  |  |  |  |  |
| 221 | 88.4 | **Location Services for GERAN in Iu Mode** | 585d | 2000-04-03 A | 2002-06-28 A | 100% |  | 2000-04-03 | 2002-06-28 | 585d |  |  | GP | 78498.6h | 78498.6h | TSG | Paolo |  |  |  | Rel-5 |  |  |  |
| 222 | 88.4.1 | GERAN LCS Stage 2 | 585d | 2000-04-03 A | 2002-06-28 A | 100% |  | 2000-04-03 | 2002-06-28 | 585d |  | finish no earlier than 2002-06-28 | GP; R2; R3; S2; G1; G2 | 22880.9h | 22880.9h | TSG |  | 2443 |  |  |  |  |  |  |
| 223 | 88.4.2 | Iu-ps interface support for LCS | 585d | 2000-04-03 A | 2002-06-28 A | 100% |  | 2000-04-03 | 2002-06-28 | 585d |  | finish no earlier than 2002-06-28 | GP; R2; R3; S2; G1; G2 | 19000.9h | 19000.9h | TSG |  |  |  |  |  |  |  |  |
| 224 | 88.4.3 | Iu-cs interface support for LCS | 585d | 2000-04-03 A | 2002-06-28 A | 100% |  | 2000-04-03 | 2002-06-28 | 585d |  | finish no earlier than 2002-06-28 | GP; R2; R3; S2; G1; G2 | 19000.9h | 19000.9h | TSG |  | 2445 |  |  |  |  |  |  |
| 225 | 88.4.4 | Iur-g interface support for LCS | 62.5d | 2002-01-23 A | 2002-04-19 A | 100% |  | 2002-01-23 | 2002-04-19 | 62.5d |  | finish no earlier than 2002-04-19 | GP; R2; R3; S2; G1; G2 | 3000h | 3000h | TSG |  | 2446 |  |  |  |  |  |  |
| 226 | 88.4.5 | RRC protocol support for LCS | 75d | 2001-08-20 A | 2001-11-30 A | 100% |  | 2001-08-20 | 2001-11-30 | 75d |  | finish no earlier than 2001-11-30 | GP; R2; R3; S2; G1; G2 | 3600h | 3600h | TSG |  | 2447 |  |  |  |  |  |  |
| 227 | 88.4.6 | Additional impacts on Broadcast of LCS data on packet channels | 77.5d | 2001-08-20 A | 2001-12-05 A | 100% |  | 2001-08-20 | 2001-12-05 | 77.5d |  | finish no earlier than 2001-12-05 | GP; R2; R3; S2; G1; G2 | 3000h | 3000h | TSG |  | 2448 |  |  |  |  |  |  |
| 228 | 88.4.7 | Stage 3 specifications | 69.5d | 2002-03-25 A | 2002-06-28 A | 100% |  | 2002-03-25 | 2002-06-28 | 69.5d |  | finish no earlier than 2002-06-28 | GP; R2; R3; S2; G1; G2 | 3336h | 3336h | TSG |  | 2449 |  |  |  |  |  |  |

Notes:
- 211: Finished at RAN#13
- 213: Evaluate Event based and Periodic LCS to be included in R00, corresponding Stage 1 description
- 215: Possible impact on UTRAN of LCS quality level request / 17 May No stage 2 for event-based & periodic LCS. Work 100% completefor current stage 2
- 225: FFS

| ID | WBS | Task | Duration | Start | Finish | Predecessors | Complete | Remaining | Baseline start | Baseline finish | Baseline duration | Total slack | Constraint | Resources | Work | Actual work | Text1 | Text2 | Text9 | Text6 | Text7 | Text8 | Text3 | Text5 |
| --- | --- | --- | --- | --- | --- | --- | --- | --- | --- | --- | --- | --- | --- | --- | --- | --- | --- | --- | --- | --- | --- | --- | --- | --- |
| 229 | 88.5 | **GERAN MS Conformance test for LCS** | 280d | 2002-06-03 A | 2003-06-27 |  | 60% | 112d | 2002-06-03 | 2003-06-27 | 280d | 178d |  | GP | 11200h | 6720h | LCS-GERAN-MSconf |  |  |  |  |  |  |  |
| 230 | 88.5.1 | Develop LCS MS test case work plan (Release 98/99/4) | 280d | 2002-06-03 A | 2003-06-27 |  | 60% | 112d | 2002-06-03 | 2003-06-27 | 280d | 178d | finish no earlier than 2003-06-27 | G4; G5 | 4480h | 2688h |  |  |  |  |  |  |  |  |
| 231 | 88.5.2 | Develop LCS MS test cases | 280d | 2002-06-03 A | 2003-06-27 |  | 60% | 112d | 2002-06-03 | 2003-06-27 | 280d | 178d | finish no earlier than 2003-06-27 | G4; G5 | 4480h | 2688h |  |  |  |  |  |  |  |  |
| 232 | 88.6 | **GERAN BTS Conformance test for LCS** | 280d | 2002-06-03 | 2003-06-27 |  |  |  | 2002-06-03 | 2003-06-27 | 280d | 178d |  | GP | 11200h |  | LCS-GERAN-BTSconf |  |  |  |  |  |  |  |
| 233 | 88.6.1 | Develop LCS BTS test case work plan (Release 98/99/4) | 280d | 2002-06-03 | 2003-06-27 |  |  |  | 2002-06-03 | 2003-06-27 | 280d | 178d | finish no earlier than 2003-06-27 | G4; G5 | 4480h |  |  |  |  |  |  |  |  |  |
| 234 | 88.6.2 | Develop LCS BTS test cases | 280d | 2002-06-03 | 2003-06-27 |  |  |  | 2002-06-03 | 2003-06-27 | 280d | 178d | finish no earlier than 2003-06-27 | G4; G5 | 4480h |  |  |  |  |  |  |  |  |  |
| 235 | 88.7 | LCS interoperation stage 2 aspects | 480d | 2000-08-28 A | 2002-06-28 |  | 17% | 400.8d | 2000-08-28 | 2002-06-28 | 480d | 438d |  | S2 | 3840h | 633.6h |  | Loc | 544 |  |  |  |  |  |
| 236 | 88.8 | **LCS interoperability aspects to GERAN** | 480d | 2000-08-28 A | 2002-06-28 A |  | 100% |  | 2000-08-28 | 2002-06-28 | 480d |  |  | GP | 19632h | 19632h | LCS-GERAN |  | 2434 | Rel-5 | TSG | Paolo |  |  |
| 237 | 88.8.1 | Co-ordinated development of GSM LCS Phase 2 and UMTS LCS, S2 and GERAN | 480d | 2000-08-28 A | 2002-06-28 A |  | 100% |  | 2000-08-28 | 2002-06-28 | 480d |  | finish no earlier than 2002-06-28 | GP; S2; S5; R2; R3; G2; G1 | 15792h | 15792h | LCS-GERAN |  | 2435 |  | TSG |  |  |  |
| 238 | 88.9 | FS on LCS support in the IMS | 90d | 2001-02-12 A | 2002-01-18 |  | 75% | 22.5d | 2001-02-12 | 2002-01-18 | 90d | 553d | start no earlier than 2001-02-12 | S1 | 720h | 540h |  | Loc | 1183 |  |  |  |  |  |
| 239 | 88.10 | Charging and OAM&P for LCS enhancements | 201d | 2001-09-21 A | 2002-06-28 A |  | 100% |  | 2001-09-21 | 2002-06-28 | 201d |  | finish no earlier than 2002-06-28 | S5 | 1608h | 1608h | LCS1-OAM |  | 519 | Rel-5 | TSG |  | 32-series | Albert.Yuhan@voicestream.com; Michael.Truss@MOTOROLA.COM |
| 240 | 88.11 | New security aspects of LCS (not identified) | 446d | 2000-04-14 A | 2001-12-28 A |  | 100% |  | 2000-04-14 | 2001-12-28 | 446d |  | finish no earlier than 2001-12-28 | S3 | 3568h | 3568h | LCS1-SEC | Loc | 521 | Rel-5 |  |  |  | valtteri.niemi@nokia.com |
| 241 | 88.12 | Specification for the Le Interface | 45d | 2002-01-14 A | 2002-03-15 A |  | 100% |  | 2002-01-14 | 2002-03-15 | 45d |  | start no earlier than 2002-01-14 | S2 | 360h | 360h | LCS1-Le |  |  | Rel-5 | TSG |  |  |  |
| 242 | 88.13 | CHECK STATUS - Inter-GMLC interface | 153d | 2002-05-30 | 2002-12-30 |  |  |  | 2002-05-30 | 2002-12-30 | 153d | 307d | finish no earlier than 2002-12-30 | S2 | 1224h |  |  |  |  |  |  |  |  |  |
| 243 | 89 | **Rel-5 Security enhancements** | 615d | 2000-02-21 A | 2002-06-28 |  | 99% | 4.24d | 2000-02-21 | 2002-06-28 | 615d | 438d |  | S3 | 29974.9h | 28371.3h | SEC1 |  |  | NA | TSG | Maurice |  | Peter.Howard@vodafone.com |
| 244 | 89.1 | **Network domain security** | 615d | 2000-02-21 A | 2002-06-28 |  | 99% | 4.24d | 2000-02-21 | 2002-06-28 | 615d | 438d |  | S3 | 25054.9h | 23451.3h | SEC1-NDS | Sec | 1576 | Rel-5 | TSG |  |  | Geir-myrdahl.koien@telenor.com |
| 245 | 89.1.1 | **Control plane protection in core network (e.g., GTP, CAP, MAP/IP, provided by IPsec)** | 541d | 2000-05-12 A | 2002-06-07 |  | 99% | 0d | 2000-05-12 | 2002-06-07 | 541d | 0d |  | S3 | 7118.9h | 5722.99h |  | Sec | 1577 |  |  |  |  |  |
| 246 | 89.1.1.1 | Main aspects | 290d | 2000-05-12 A | 2001-06-21 A |  | 100% |  | 2000-05-12 | 2001-06-21 | 290d |  | finish no earlier than 2001-06-21 | S3 | 2320h | 2320h |  | Sec | 1578 |  |  |  |  |  |
| 247 | 89.1.1.2 | Integration of GTP signalling security architecture | 191d | 2001-09-14 A | 2002-06-07 A |  | 100% |  | 2001-09-14 | 2002-06-07 | 191d |  | finish no earlier than 2002-06-07 | N4 | 1528h | 1528h |  | Sec | 1579 |  |  |  |  |  |
| 248 | 89.1.2 | **User plane protection in core network (e.g., provided by IPsec)** | 615d | 2000-02-21 A | 2002-06-28 |  | 98% | 11.41d | 2000-02-21 | 2002-06-28 | 615d | 438d |  | S3 | 9360h | 9186.29h |  | Sec | 1580 |  |  |  |  |  |
| 249 | 89.1.2.1 | Main aspects | 349d | 2000-02-21 A | 2001-06-21 A |  | 100% |  | 2000-02-21 | 2001-06-21 | 349d |  | finish no earlier than 2001-06-21 | S3 | 2792h | 2792h |  | Sec | 1581 |  |  |  |  |  |
| 250 | 89.1.2.2 | Integration of GTP signalling security architecture | 206d | 2001-09-14 A | 2002-06-28 |  | 95% | 10.3d | 2001-09-14 | 2002-06-28 | 206d | 438d | finish no earlier than 2002-06-28 | N4 | 1648h | 1565.6h |  | Sec | 1582 |  |  |  |  |  |
| 251 | 89.1.3 | IP network layer security (NDS/IP) | 457d | 2000-06-15 A | 2002-03-15 A |  | 100% |  | 2000-06-15 | 2002-03-15 | 457d |  | finish no earlier than 2002-03-15 | S3 | 3656h | 3656h | SEC1-NDS-IP |  |  |  | WG |  | TS 33.210 | Geir-myrdahl.koien@telenor.com |
| 252 | 90 | **Intra Domain Connection of RAN Nodes to Multiple CN Nodes** | 455d | 2000-10-02 A | 2002-06-28 A |  | 100% |  | 2000-10-02 | 2002-06-28 | 455d |  |  | S2 | 15136h | 15136h | IUFLEX |  |  | Rel-5 | TSG | Alain | 23.236 |  |
| 253 | 90.1 | Overall System Architecture | 188d | 2001-01-03 A | 2001-09-21 A |  | 100% |  | 2001-01-03 | 2001-09-21 | 188d |  | finish no earlier than 2001-06-01 | S2 | 1504h | 1504h |  |  | 2244 |  | TSG |  |  |  |
| 254 | 90.2 | Stage 3: RAN node selecting CN node | 130d | 2001-09-24 A | 2002-03-22 A | 253 | 100% |  | 2001-09-24 | 2002-03-22 | 130d |  | finish no earlier than 2002-03-22 | R3 | 1040h | 1040h |  |  |  |  | TSG |  |  |  |
| 255 | 90.3 | N1 work | 205d | 2001-09-17 A | 2002-06-28 A |  | 100% |  | 2001-09-17 | 2002-06-28 | 205d |  | start no earlier than 2001-09-17 | N1 | 1640h | 1640h |  |  |  |  | TSG |  | 24.008 and check 29.018 |  |
| 256 | 90.4 | N4 work | 375d | 2000-10-02 A | 2002-03-08 A |  | 100% |  | 2000-10-02 | 2002-03-08 | 375d |  | finish no earlier than 2002-03-15 | N4 | 3000h | 3000h |  |  | 2249 |  | TSG |  |  |  |

Notes:
- 229: On-going
- 232: Not started
- 239: Text4: Albert YUHAN (VoiceStream Wireless), Michael TRUSS (Motorola)
- 240: 14/09/00: End date 28/12/01 WI may need to be split to improve on this date. S3#17 15% complete. No progress since S3#17 / Text4: Valtteri Niemi, Nokia
- 243: Added BB UE authentication and rapporteur added. TO BE DELETED / Text4: Peter Howard, Vodafone
- 244: S3#17: All due in Rel5. (WI Update at S3#18). Replaced by NDS-IP and NDS-MAP. TO BE DELETED OR MOVED TO HISTORY FILE / Text4: Geir M. Køien, Telenor
- 246: TO BE DELETED
- 247: Waiting for input from SA3! / 14/02/2002 requirements are not clear/not received / 17 May 100% complete
- 248: TO BE DELETED
- 249: ??
- 250: 14/02/2002 requirements are not clear/not received
- 251: TS 33.210 will be presented for info at SA#14 and is scheduled for approval at SA#15. 2002/12: All IPsec RFCs are stable STD Track RFCs. WID updated SA#17 / Text4: Geir M. Køien, Telenor
- 252: No clear indication on the end date. Put to Rel5 by AS. / Text4: Stephen Terrill, Ericsson
- 254: Not identified / Text4: Brendan McWilliams, Vodafone
- 256: DAB 12.12.01 - % complete to 66% / 14/02/02 Work completed

| ID | WBS | Task | Duration | Start | Finish | Complete | Remaining | Baseline start | Baseline finish | Baseline duration | Total slack | Constraint | Resources | Work | Actual work | Text1 | Text5 | Text6 | Text7 | Text8 | Text9 | Text3 | Text2 |
| --- | --- | --- | --- | --- | --- | --- | --- | --- | --- | --- | --- | --- | --- | --- | --- | --- | --- | --- | --- | --- | --- | --- | --- |
| 257 | 90.5 | **GERAN work for Intra Domain Connection of RAN Nodes to Multiple CN Nodes** | 101d | 2002-02-08 A | 2002-06-28 A | 100% |  | 2002-02-08 | 2002-06-28 | 101d |  |  | GP | 4848h | 4848h | IDCRAN-GERAN | ingemar.backlund@era.ericsson.se | Rel-5 |  |  |  |  |  |
| 258 | 90.5.1 | Stage 2 (changes to ) | 101d | 2002-02-08 A | 2002-06-28 A | 100% |  | 2002-02-08 | 2002-06-28 | 101d |  | finish no earlier than 2002-06-28 | G1 | 808h | 808h |  |  |  |  |  |  |  |  |
| 259 | 90.5.2 | 43.051 Introduction of support for IDNNS in GERAN Iu mode | 101d | 2002-02-08 A | 2002-06-28 A | 100% |  | 2002-02-08 | 2002-06-28 | 101d |  | finish no earlier than 2002-06-28 | G1 | 808h | 808h |  |  |  |  |  |  |  |  |
| 260 | 90.5.3 | Stage 3 (changes to ) | 101d | 2002-02-08 A | 2002-06-28 A | 100% |  | 2002-02-08 | 2002-06-28 | 101d |  | finish no earlier than 2002-06-28 | G2 | 808h | 808h |  |  |  |  |  |  |  |  |
| 261 | 90.5.4 | 48.016 Use of Gb interface concepts when a network applies IDNNS | 101d | 2002-02-08 A | 2002-06-28 A | 100% |  | 2002-02-08 | 2002-06-28 | 101d |  | finish no earlier than 2002-06-28 | G2 | 808h | 808h |  |  |  |  |  |  |  |  |
| 262 | 90.5.5 | 48.018 Include MSC/VLR identity in CS IMSI paging | 101d | 2002-02-08 A | 2002-06-28 A | 100% |  | 2002-02-08 | 2002-06-28 | 101d |  | finish no earlier than 2002-06-28 | G2 | 808h | 808h |  |  |  |  |  |  |  |  |
| 263 | 91 | **GERAN improvements 3 (new transport layer on interface A)** | 446d | 2001-04-06 | 2002-12-20 |  |  | 2001-04-06 | 2002-12-20 | 446d | 313d |  | GP | 14272h |  | GEIMP3 |  | Rel-5 | TSG | Paolo | 2320 |  |  |
| 264 | 91.1 | **Evolution of the transport for A** | 446d | 2001-04-06 | 2002-12-20 |  |  | 2001-04-06 | 2002-12-20 | 446d | 313d |  | GP | 10704h |  | GEIMP3-EtA |  |  | TSG | Paolo | 2321 |  |  |
| 265 | 91.1.1 | Definition of a new A/Ater interface Transport Layer option based on the Iu Interface Transport Layer | 446d | 2001-04-06 | 2002-12-20 |  |  | 2001-04-06 | 2002-12-20 | 446d | 313d | finish no earlier than 2002-12-20 | GP | 3568h |  |  |  |  | TSG |  | 2322 |  |  |
| 266 | 91.1.2 | Adaptation of the Layer 3 BSSMAP procedures as required | 446d | 2001-04-06 | 2002-12-20 |  |  | 2001-04-06 | 2002-12-20 | 446d | 313d | finish no earlier than 2002-12-20 | GP | 3568h |  |  |  |  | TSG |  | 2323 |  |  |
| 267 | 92 | **Rel-5 Charging and OAM&P** | 264d | 2001-09-10 A | 2002-09-12 A | 100% |  | 2001-09-10 | 2002-09-12 | 264d |  |  | S5 | 9976h | 9976h | OAM | Albert.Yuhan@voicestream.com; Michael.Truss@MOTOROLA.COM | NA | TSG | Adrian |  | 32-series |  |
| 268 | 92.1 | Rel5 Principles, high level Requirements and Architecture | 205d | 2001-09-17 A | 2002-06-28 A | 100% |  | 2001-09-17 | 2002-06-28 | 205d |  | finish no earlier than 2002-06-28 | S5 | 1640h | 1640h | OAM-AR/PR | Michael.Truss@MOTOROLA.COM | Rel-5 | TSG |  | 2089 | 32.101, 32.102 | BCaM |
| 269 | 92.2 | Rel5 Performance Management | 259d | 2001-09-17 A | 2002-09-12 A | 100% |  | 2001-09-17 | 2002-09-12 | 259d |  | finish no earlier than 2002-09-12 | S5 | 2072h | 2072h | OAM-PM | toche@NORTELNETWORKS.COM | Rel-5 | TSG |  | 2088 | 32.4xy, 52.402 | BCaM |
| 270 | 92.3 | Rel5 Charging Management | 264d | 2001-09-10 A | 2002-09-12 A | 100% |  | 2001-09-10 | 2002-09-12 | 264d |  | finish no earlier than 2002-09-12 | S5 | 2112h | 2112h | OAM-CH | Karl-Heinz.Nenner@T-MOBILE.DE | Rel-5 | TSG |  | 2083 | 32.2xy |  |
| 271 | 92.4 | Rel5 Network Infrastructure Management | 255d | 2001-09-21 A | 2002-09-12 A | 100% |  | 2001-09-21 | 2002-09-12 | 255d |  | finish no earlier than 2002-09-12 | S5 | 2040h | 2040h | OAM-NIM | Thomas.Tovinger@emw.ericsson.se | Rel-5 | TSG |  |  | 32.6xy, 32.3xy |  |
| 272 | 93 | **GERAN enhancements for streaming services 1 (RLC enhancements)** | 430d | 2000-11-06 A | 2002-06-28 A | 100% |  | 2000-11-06 | 2002-06-28 | 430d |  |  | GP | 8944h | 8944h |  |  | Rel-5 |  | Paolo | 2392 |  |  |
| 273 | 93.1 | Concept | 258d | 2000-11-06 A | 2001-10-31 A | 100% |  | 2000-11-06 | 2001-10-31 | 258d |  | finish no earlier than 2001-10-31 | GP | 2064h | 2064h |  |  |  |  |  | 2394 |  |  |
| 274 | 93.2 | RLC protocol enhancement (SDU Discard) | 430d | 2000-11-06 A | 2002-06-28 A | 100% |  | 2000-11-06 | 2002-06-28 | 430d |  | finish no earlier than 2002-06-28 | GP | 3440h | 3440h |  |  |  |  |  | 2395 |  |  |
| 275 | 94 | **GERAN enhancements for streaming services 2 (usage of ECSD)** | 430d | 2000-11-06 A | 2002-06-28 | 99% | 0d | 2000-11-06 | 2002-06-28 | 430d | 0d |  | GP | 19840h | 16400h |  |  | Rel-5 |  | Paolo | 2396 |  |  |
| 276 | 94.1 | Usage of ECSD Concept | 380d | 2000-11-06 A | 2002-04-19 A | 100% |  | 2000-11-06 | 2002-04-19 | 380d |  | finish no earlier than 2002-04-19 | GP | 3040h | 3040h |  |  |  |  |  | 2398 |  |  |
| 277 | 94.2 | Stage 2 | 380d | 2000-11-06 A | 2002-04-19 A | 100% |  | 2000-11-06 | 2002-04-19 | 380d |  | finish no earlier than 2002-04-19 | GP | 3040h | 3040h |  |  |  |  |  | 2399 |  |  |
| 278 | 94.3 | Stage 3 | 430d | 2000-11-06 A | 2002-06-28 A | 100% |  | 2000-11-06 | 2002-06-28 | 430d |  | finish no earlier than 2002-06-28 | GP | 3440h | 3440h |  |  |  |  |  | 2400 |  |  |
| 279 | 94.4 | RLC PDU formats | 430d | 2000-11-06 A | 2002-06-28 A | 100% |  | 2000-11-06 | 2002-06-28 | 430d |  | finish no earlier than 2002-06-28 | GP | 3440h | 3440h |  |  |  |  |  | 2401 |  |  |
| 280 | 94.5 | MAC header | 430d | 2000-11-06 A | 2002-06-28 A | 100% |  | 2000-11-06 | 2002-06-28 | 430d |  | finish no earlier than 2002-06-28 | GP | 3440h | 3440h |  |  |  |  |  | 2402 |  |  |

Notes:
- 257: Accept changes Gb over IP / Text4: Ingemar Backlund, Ericsson
- 261: Closed, accept changes for Gb over IP
- 263: TERMINATED - NOT STANDARDIZED
- 264: TERMINATED - NOT STANDARDIZED
- 265: TERMINATED - NOT STANDARDIZED
- 266: TERMINATED - NOT STANDARDIZED
- 267: Text4: Albert YUHAN (VoiceStream Wireless), Michael TRUSS (Motorola)
- 268: Text4: Michael TRUSS (Motorola)
- 269: Text4: Christian TOCHE (Nortel Networks)
- 270: Text4: Karl-Heinz NENNER (T-Mobile)
- 271: Text4: Thomas TOVINGER (Ericsson)
- 275: AWS, Nokia, Ericsson, Nortel, Siemens, Motorola, Vodafone / Text4: Frank Muller, Ericsson

| ID | WBS | Task | Duration | Start | Finish | Predecessors | Complete | Remaining | Baseline start | Baseline finish | Baseline duration | Total slack | Constraint | Resources | Work | Actual work | Text1 | Text6 | Text8 | Text9 | Text5 | Text7 | Text2 |
| --- | --- | --- | --- | --- | --- | --- | --- | --- | --- | --- | --- | --- | --- | --- | --- | --- | --- | --- | --- | --- | --- | --- | --- |
| 281 | 95 | **GERAN/UTRAN interface evolution 1 (evolution of Iu PS)** | 476d | 2000-09-01 A | 2002-06-28 A |  | 100% |  | 2000-09-01 | 2002-06-28 | 476d |  |  | GP; R3 | 17825.6h | 17825.6h | GERUEV1 | Rel-5 | Paolo | 2412 |  |  |  |
| 282 | 95.1 | **Evolution of Iu ps** | 476d | 2000-09-01 A | 2002-06-28 A |  | 100% |  | 2000-09-01 | 2002-06-28 | 476d |  |  | GP; R3 | 12205.6h | 12205.6h | GERUEV1-IuPS |  |  | 2413 |  |  |  |
| 283 | 95.1.1 | Identification of GERAN requirements on Iu ps | 326d | 2000-09-01 A | 2001-11-30 A |  | 100% |  | 2000-09-01 | 2001-11-30 | 326d |  | finish no earlier than 2001-11-30 | GP; R3 | 4185.6h | 4185.6h |  |  |  | 2414 |  |  |  |
| 284 | 95.1.2 | Update of specifications | 150d | 2001-12-03 A | 2002-06-28 A | 283 | 100% |  | 2001-12-03 | 2002-06-28 | 150d |  | finish no earlier than 2002-06-28 | GP; R3 | 2400h | 2400h |  |  |  | 2415 |  |  |  |
| 285 | 96 | **GERAN/UTRAN interface evolution 2 (evolution of Iu CS)** | 476d | 2000-09-01 A | 2002-06-28 A |  | 100% |  | 2000-09-01 | 2002-06-28 | 476d |  |  | GP; R3 | 23025.6h | 23025.6h | GERUEV2 | Rel-5 | Paolo | 2416 |  |  |  |
| 286 | 96.1 | **Evolution of Iu cs** | 476d | 2000-09-01 A | 2002-06-28 A |  | 100% |  | 2000-09-01 | 2002-06-28 | 476d |  |  | GP; R3 | 17845.6h | 17845.6h | GERUEV2-IuCS |  | Paolo | 2417 |  |  |  |
| 287 | 96.1.1 | Identification of GERAN requirements on Iu cs | 426d | 2000-09-01 A | 2002-04-19 A |  | 100% |  | 2000-09-01 | 2002-04-19 | 426d |  | finish no earlier than 2002-04-19 | GP; R3 | 5049.6h | 5049.6h |  |  |  | 2418 |  |  |  |
| 288 | 96.1.2 | Update of specifications | 476d | 2000-09-01 A | 2002-06-28 A |  | 100% |  | 2000-09-01 | 2002-06-28 | 476d |  | finish no earlier than 2002-06-28 | GP; R3 | 7616h | 7616h |  |  |  | 2419 |  |  |  |
| 289 | 97 | **End to End QoS for PS Domain including IMS** | 480d | 2000-08-28 A | 2002-06-28 |  | 97% | 13.22d | 2000-08-28 | 2002-06-28 | 480d | 438d |  | S2 | 9856h | 9584.49h | E2EQoS | Rel-5 | Alain |  | Johnson.oyama@era.ericcson.se | TSG |  |
| 290 | 97.1 | E2E QoSConcept and Architecture | 178d | 2001-01-03 A | 2001-09-07 A |  | 100% |  | 2001-01-03 | 2001-09-07 | 178d |  | finish no earlier than 2001-09-07 | S2 | 1424h | 1424h |  |  |  |  |  | TSG |  |
| 291 | 97.2 | E2E QoS interworking | 465d | 2000-08-28 A | 2002-06-07 |  | 95% | 23.25d | 2000-08-28 | 2002-06-07 | 465d | 453d | finish no earlier than 2002-06-07 | N3 | 3720h | 3534h | E2EQoS-IW |  |  |  | yokota@lucent.com | WG |  |
| 292 | 97.3 | QoS Management (Provisioning and Monitoring) | 201d | 2001-09-21 A | 2002-06-28 A |  | 100% |  | 2001-09-21 | 2002-06-28 | 201d |  | finish no earlier than 2002-06-28 | S5 | 1608h | 1608h | E2EQoS-OAM | Rel-5 |  |  | Albert.Yuhan@voicestream.com; Michael.Truss@MOTOROLA.COM | TSG |  |
| 293 | 98 | **Messaging enhancements Rel-5** | 467d | 2001-06-15 A | 2003-03-31 |  | 93% | 34.87d | 2001-06-15 | 2002-06-07 | 256d | 242d |  | T2 | 19000h | 12726.5h | MESS5 | Rel-5 | Friedhelm | 1818 |  | TSG | Mes |
| 294 | 98.1 | **Multimedia Messaging (MMS) enhancements** | 467d | 2001-06-15 A | 2003-03-31 |  | 91% | 43.88d | 2001-06-15 | 2002-06-07 | 256d | 242d |  | T2 | 11688h | 7212.8h | MESS5-MMS |  |  | 1819 | Josef.Laumen@SAL.SIEMENS.DE | TSG | Mes |
| 295 | 98.1.1 | Definition of service requirements | 196d | 2001-06-15 A | 2002-03-15 A |  | 100% |  | 2001-06-15 | 2002-03-15 | 196d |  | finish no earlier than 2002-03-15 | S1 | 1568h | 1568h | MESS5-SR | Rel-5 |  |  | Josef.Laumen@SAL.SIEMENS.DE |  |  |
| 296 | 98.1.2 | Technical realization | 256d | 2001-06-15 A | 2002-06-07 A |  | 100% |  | 2001-06-15 | 2002-06-07 | 256d |  | finish no earlier than 2002-06-07 | T2 | 2048h | 2048h |  |  |  |  | Josef.Laumen@SAL.SIEMENS.DE |  |  |
| 297 | 98.1.3 | WAP Forum dependency: MM1 stage 3 | 467d | 2001-06-15 A | 2003-03-31 |  | 80% | 93.4d | 2001-06-15 | 2002-06-07 | 256d | 242d | finish no earlier than 2003-03-31 | T2 | 3736h | 2988.8h |  |  |  |  |  |  |  |
| 298 | 98.1.4 | MMS formats and codecs | 75d | 2001-12-03 A | 2002-03-15 A |  | 100% |  | 2001-12-03 | 2002-03-15 | 75d |  | finish no earlier than 2002-03-15 | S4 | 600h | 600h |  |  |  |  |  |  |  |
| 299 | 98.2 | **Enhanced Messaging Service (EMS) enhancements** | 191d | 2001-06-15 A | 2002-03-08 |  | 99% | 0d | 2001-06-15 | 2002-03-08 | 191d | 0d |  | T2 | 3584h | 2064h | MESS5-EMS |  |  | 1820 | Alan.Baldwin@EML.ERICSSON.SE | TSG | Mes |
| 300 | 98.2.1 | Definition of service requirements | 66d | 2001-06-15 A | 2001-09-14 A |  | 100% |  | 2001-06-15 | 2001-09-14 | 66d |  | finish no earlier than 2001-09-14 | S1 | 528h | 528h |  |  |  |  | Alan.Baldwin@EML.ERICSSON.SE |  |  |
| 301 | 98.2.2 | Technical realization | 191d | 2001-06-15 A | 2002-03-08 A |  | 100% |  | 2001-06-15 | 2002-03-08 | 191d |  | finish no earlier than 2002-03-08 | T2 | 1528h | 1528h |  |  |  |  | Alan.Baldwin@EML.ERICSSON.SE |  |  |
| 302 | 99 | **GERAN Inter BSC NACC improvements over the Gb Interface** | 215d | 2001-09-03 A | 2002-06-28 A |  | 100% |  | 2001-09-03 | 2002-06-28 | 215d |  |  | GP | 11184h | 11184h | GERNACC | Rel-5 | Paolo |  |  |  |  |
| 303 | 99.1 | **Modification of core network protocols for GERAN Inter BSC NACC over Gb Interface** | 165d | 2001-09-03 A | 2002-04-19 A |  | 100% |  | 2001-09-03 | 2002-04-19 | 165d |  |  | N4; S2 | 7048h | 7048h | GERNACC-Cnmod |  |  |  |  |  |  |
| 304 | 99.1.1 | Stage 2 - Concept | 43d | 2001-09-03 A | 2001-10-31 A |  | 100% |  | 2001-09-03 | 2001-10-31 | 43d |  | finish no earlier than 2001-10-31 | N4; S2 | 688h | 688h |  |  |  |  |  |  |  |
| 305 | 99.1.2 | Stage 2 - 23.060 change - Definition of Inter BSC NACC | 165d | 2001-09-03 A | 2002-04-19 A |  | 100% |  | 2001-09-03 | 2002-04-19 | 165d |  | finish no earlier than 2002-04-19 | N4; S2 | 2640h | 2640h |  |  |  |  |  |  |  |
| 306 | 99.1.3 | Stage 3 (changes to TS 29.060) | 135d | 2001-09-03 A | 2002-03-08 A |  | 100% |  | 2001-09-03 | 2002-03-08 | 135d |  | finish no earlier than 2002-03-08 | N4 | 1080h | 1080h |  |  |  |  |  |  |  |

Notes:
- 281: SBC, Motorola, Nokia, Ericsson, Nortel / Text4: Marc Grant , SBC
- 286: Lucent, Ericsson, AWS, Nortel / Text4: Krishna Balachandran, Lucent
- 289: Text4: Johnson Oyama, Ericsson
- 290: Text3: 23.207
- 291: [DAB - 30/07/02] - % complete to 95% (if we exclude Diffserv) / Text3: 29.208, 29.207, 27.060, 29.061, 24.008, 24.228, , 24.229, 29.060, 29.163 / Text4: Daisuke Yokota, Lucent
- 292: Text3: 32-series / Text4: Albert YUHAN (VoiceStream Wireless), Michael TRUSS (Motorola)
- 293: support of UAProf, so this in my opinion is 100% complete
- 294: Text4: Josef Laumen, Siemens
- 295: Text3: 22.140 / Text4: Josef Laumen, Siemens
- 296: stage 3 MM7 is missing / Text3: 23.140 / Text4: Josef Laumen, Siemens
- 298: Text3: 26.140
- 299: Text3: 23.040 / Text4: Alan Baldwin, Ericsson
- 300: Text4: Alan Baldwin, Ericsson
- 301: Text3: 23.040 / Text4: Alan Baldwin, Ericsson
- 306: IP 30/11/01: Input awaited from GERAN2 to CN4 / 17 May Work complete 100%

| ID | WBS | Task | Duration | Start | Finish | Complete | Remaining | Baseline start | Baseline finish | Baseline duration | Total slack | Constraint | Resources | Work | Actual work | Text1 | Text6 | Text8 | Text3 | Text4 | Text5 | Text7 | Text2 | Text9 |
| --- | --- | --- | --- | --- | --- | --- | --- | --- | --- | --- | --- | --- | --- | --- | --- | --- | --- | --- | --- | --- | --- | --- | --- | --- |
| 307 | 99.2 | **Modification of Gb protocols for GERAN Inter BSC NACC over Gb Interface** | 151d | 2001-11-30 A | 2002-06-28 A | 100% |  | 2001-11-30 | 2002-06-28 | 151d |  |  | GP | 2416h | 2416h | GERNACC-Gbmod |  |  |  |  |  |  |  |  |
| 308 | 99.2.1 | Stage 3 (changes to TS 48.018) | 151d | 2001-11-30 A | 2002-06-28 A | 100% |  | 2001-11-30 | 2002-06-28 | 151d |  | finish no earlier than 2002-06-28 | GP | 1208h | 1208h |  |  |  |  |  |  |  |  |  |
| 309 | 100 | **Enhanced Power Control** | 540d | 2001-11-26 A | 2003-12-19 |  | 537.46d | 2001-11-26 | 2003-12-19 | 540d | 53d |  | GP | 12840h | 60.28h | EPC | Rel-5 |  |  |  |  |  |  |  |
| 310 | 100.1 | Realization of Enhanced power control and signaling support | 5d | 2001-11-26 A | 2001-11-30 A | 100% |  | 2001-11-26 | 2001-11-30 | 5d |  | finish no earlier than 2001-11-30 | GP | 40h | 40h |  |  |  |  |  |  |  |  |  |
| 311 | 100.2 | GERAN MS Conformance test for Enhanced Power Control | 530d | 2001-12-10 | 2003-12-19 |  |  | 2001-12-10 | 2003-12-19 | 530d | 53d | finish no earlier than 2003-12-19 | GP | 4240h |  |  |  |  |  |  |  |  |  |  |
| 312 | 100.3 | GERAN BTS Conformance test for Enhanced Power Control | 530d | 2001-12-10 | 2003-12-19 |  |  | 2001-12-10 | 2003-12-19 | 530d | 53d | finish no earlier than 2003-12-19 | GP | 4240h |  |  |  |  |  |  |  |  |  |  |
| 313 | 101 | **8PSK AMR HR** | 530d | 2001-12-10 A | 2003-12-19 | 73% | 143.32d | 2001-12-10 | 2003-12-19 | 530d | 53d |  | GP | 21080h | 15693.5h | 8PSK-AH | Rel-5 | Paolo |  |  |  |  |  |  |
| 314 | 101.1 | **Definition of channel coding, performance requirements and signaling support** | 145d | 2001-12-10 A | 2002-06-28 A | 100% |  | 2001-12-10 | 2002-06-28 | 145d |  |  | GP | 10440h | 10440h |  |  |  |  |  |  |  |  |  |
| 315 | 101.1.1 | Concept | 145d | 2001-12-10 A | 2002-06-28 A | 100% |  | 2001-12-10 | 2002-06-28 | 145d |  | finish no earlier than 2002-06-28 | GP | 1160h | 1160h |  |  |  |  |  |  |  |  |  |
| 316 | 101.1.2 | Changes to 44.018 | 145d | 2001-12-10 A | 2002-06-28 A | 100% |  | 2001-12-10 | 2002-06-28 | 145d |  | finish no earlier than 2002-06-28 | G2 | 1160h | 1160h |  |  |  |  |  |  |  |  |  |
| 317 | 101.1.3 | Changes to 45.001 | 145d | 2001-12-10 A | 2002-06-28 A | 100% |  | 2001-12-10 | 2002-06-28 | 145d |  | finish no earlier than 2002-06-28 | G1 | 1160h | 1160h |  |  |  |  |  |  |  |  |  |
| 318 | 101.1.4 | Changes to 45.002 | 145d | 2001-12-10 A | 2002-06-28 A | 100% |  | 2001-12-10 | 2002-06-28 | 145d |  | finish no earlier than 2002-06-28 | G1 | 1160h | 1160h |  |  |  |  |  |  |  |  |  |
| 319 | 101.1.5 | Changes to 45.003 | 145d | 2001-12-10 A | 2002-06-28 A | 100% |  | 2001-12-10 | 2002-06-28 | 145d |  | finish no earlier than 2002-06-28 | G1 | 1160h | 1160h |  |  |  |  |  |  |  |  |  |
| 320 | 101.1.6 | Changes to 45.005 | 145d | 2001-12-10 A | 2002-06-28 A | 100% |  | 2001-12-10 | 2002-06-28 | 145d |  | finish no earlier than 2002-06-28 | G1 | 1160h | 1160h |  |  |  |  |  |  |  |  |  |
| 321 | 101.1.7 | Changes to 24.008 | 145d | 2001-12-10 A | 2002-06-28 A | 100% |  | 2001-12-10 | 2002-06-28 | 145d |  | finish no earlier than 2002-06-28 | G2 | 1160h | 1160h |  |  |  |  |  |  |  |  |  |
| 322 | 101.1.8 | Changes to 48.058 | 145d | 2001-12-10 A | 2002-06-28 A | 100% |  | 2001-12-10 | 2002-06-28 | 145d |  | finish no earlier than 2002-06-28 | G2 | 1160h | 1160h |  |  |  |  |  |  |  |  |  |
| 323 | 101.2 | GERAN MS Conformance test for 8PSK HR | 530d | 2001-12-10 | 2003-12-19 |  |  | 2001-12-10 | 2003-12-19 | 530d | 53d | finish no earlier than 2003-12-19 | GP | 4240h |  |  |  |  |  |  |  |  |  |  |
| 324 | 101.3 | GERAN BTS Conformance test for 8PSK HR | 270d | 2001-12-10 A | 2002-12-20 A | 100% |  | 2001-12-10 | 2002-12-20 | 270d |  | finish no earlier than 2002-12-20 | GP | 2160h | 2160h |  |  |  |  |  |  |  |  |  |
| 325 | 102 | Service Change and UDI Fallback | 175d | 2001-10-08 A | 2002-06-07 A | 100% |  | 2001-10-08 | 2002-06-07 | 175d |  | finish no earlier than 2002-06-07 | N3 | 1400h | 1400h | SCUDIF | Rel-5 | David | 29.007, 27.001, 24.008 | Rune Werner Wiik, Ericsson AS | Rune.Werner.Wiik@ericsson.no | WG |  |  |
| 326 | 103 | **Rel-5 USIM toolkit enhancements** | 865d | 2000-06-05 A | 2003-09-26 | 51% | 425.77d | 2000-06-05 | 2003-09-26 | 865d | 113d |  | T3 | 24352h | 13591.2h | USAT1 | NA | Claus |  |  |  |  | Ter | 1800 |
| 327 | 103.1 | Test specification for USIM toolkit security mechanims | 349d | 2002-05-28 | 2003-09-26 |  |  | 2002-05-28 | 2003-09-26 | 349d | 113d | finish no earlier than 2003-09-26 | T3 | 2792h |  |  |  |  |  | Sophie Viallet (Gemplus) |  |  |  |  |
| 328 | 103.2 | **Protocol Standardisation of a SIM Toolkit Interpreter** | 688d | 2000-06-05 A | 2003-01-22 | 64% | 250.88d | 2000-06-05 | 2003-01-22 | 688d | 290d |  | T3 | 12512h | 7949.4h | USAT1-Interpr | Rel-5 |  | 27.103 | Michael Meyer, G & D |  | TSG | Ter | 1801 |
| 329 | 103.2.1 | Stage 1 | 205d | 2000-06-05 A | 2001-03-16 A | 100% |  | 2000-06-05 | 2001-03-16 | 205d |  | finish no earlier than 2001-03-16 | T3 | 1640h | 1640h |  |  |  |  |  |  | TSG |  |  |
| 330 | 103.2.2 | Stage 2 and 3 | 308d | 2001-01-03 A | 2002-03-08 A | 100% |  | 2001-01-03 | 2002-03-08 | 308d |  | finish no earlier than 2002-03-08 | T3 | 2464h | 2464h |  |  |  |  |  |  | TSG |  |  |
| 331 | 103.2.3 | Test specification | 363d | 2001-09-03 A | 2003-01-22 | 12% | 319.44d | 2001-09-03 | 2003-01-22 | 363d | 290d | finish no earlier than 2003-01-22 | T3 | 2904h | 348.48h |  |  |  |  | Gérald MAUNIER (Gemplus) |  | TSG |  |  |

Notes:
- 310: Ready
- 311: Not started
- 312: Not started
- 313: Completed for Rel-5
- 325: [DAB - 23/05/03] - 100 % complete some issues with CAMEL
- 328: 28/5/2001: T3-19 proposed that since the stage 2 and 3 will not be presented to TP-12 for approval as expected, the WI will be moved to rel-5, with completion expected at TP-13.
- 329: 5/10/2001: Stage one comepeted at TP-12.
- 330: 5/10/2001: TS 31.112 and 31.113 approved at TP-13. TS 31.114 to be presented to TP-14.
- 331: 5/10/2001: Work started on test specification

| ID | WBS | Task | Duration | Start | Finish | Complete | Remaining | Baseline start | Baseline finish | Baseline duration | Total slack | Constraint | Resources | Work | Actual work | Text1 | Text6 | Text4 | Text7 | Text9 | Text5 | Text8 | Text3 |
| --- | --- | --- | --- | --- | --- | --- | --- | --- | --- | --- | --- | --- | --- | --- | --- | --- | --- | --- | --- | --- | --- | --- | --- |
| 332 | 103.4 | **(U)SIM API** | 133d | 2002-03-20 A | 2002-09-20 A | 100% |  | 2002-03-20 | 2002-09-20 | 133d |  |  | T3 | 2128h | 2128h | USAT1-API | NA |  |  |  |  |  |  |
| 333 | 103.4.1 | Java API Test specification | 133d | 2002-03-20 A | 2002-09-20 A | 100% |  | 2002-03-20 | 2002-09-20 | 133d |  | finish no earlier than 2002-09-20 | T3 | 1064h | 1064h |  |  | Mario Pérez (Microelectrónica Española) |  |  |  |  |  |
| 334 | 104 | small Technical Enhancements and Improvements for Rel5 | 325d | 2000-12-25 A | 2002-03-22 A | 100% |  | 2000-12-25 | 2002-03-22 | 325d |  | start no earlier than 2000-12-25 | Generic | 2600h | 2600h | TEI5 | Rel-5 |  | TSG | 1993 |  |  |  |
| 335 | 105 | Technical Report on UE Functionality Split (Work stopped) | 86d | 2000-01-03 | 2000-05-01 |  |  | 2000-01-03 | 2000-05-01 | 86d | 1002d |  | S1 | 688h |  | UESPLIT | Rel-5 | Sanjay Gupta, Motorola | TSG |  | sanjay.gupta@motorola.com | Michael |  |
| 336 | 106 | **User Equipment Management** | 267d | 2001-06-21 A | 2002-06-28 | 99% | 0d | 2001-06-21 | 2002-06-28 | 267d | 0d |  | S5 | 3752h | 3752h | UEM | NA | John Mudge (Vodafone) | TSG |  | john.mudge@vf.vodafone.co.uk | Adrian |  |
| 337 | 106.1 | FS on User Equipment (UE) Management | 267d | 2001-06-21 A | 2002-06-28 A | 100% |  | 2001-06-21 | 2002-06-28 | 267d |  | finish no earlier than 2002-06-28 | S5 | 2136h | 2136h | OAM-UEM | Rel-5 | John Mudge (Vodafone) | TSG |  | john.mudge@VF.VODAFONE.CO.UK | Adrian | 32.802 |
| 338 | 107 | **Flow control supporting an MS with multiple data flows with different QoS over the Gb interface** | 50d | 2002-06-24 A | 2002-08-30 A | 100% |  | 2002-06-24 | 2002-08-30 | 50d |  |  | GP | 1288h | 1288h | FlowCon | Rel-5 | Ingemar Backlund, Ericsson | TSG |  |  |  |  |
| 339 | 107.1 | **Update of stage 2 specifications** | 50d | 2002-06-24 A | 2002-08-30 A | 100% |  | 2002-06-24 | 2002-08-30 | 50d |  |  | GP | 808h | 808h |  |  |  | TSG |  |  |  |  |
| 340 | 107.1.1 | Concept document 23.060 (changes to) | 46d | 2002-06-28 A | 2002-08-30 A | 100% |  | 2002-06-28 | 2002-08-30 | 46d |  | finish no earlier than 2002-08-30 | S2 | 368h | 368h |  |  |  |  |  |  |  |  |
| 341 | 107.1.2 | Flow Control | 5d | 2002-06-24 A | 2002-06-28 A | 100% |  | 2002-06-24 | 2002-06-28 | 5d |  | finish no earlier than 2002-06-28 | GP | 40h | 40h |  |  |  |  |  |  |  |  |
| 342 | 107.2 | **Modification of BSSGP protocol** | 5d | 2002-06-24 A | 2002-06-28 A | 100% |  | 2002-06-24 | 2002-06-28 | 5d |  |  | GP | 80h | 80h |  |  | Ingemar Backlund, Ericsson | TSG |  |  |  |  |
| 343 | 107.2.1 | Stage 3 (changes to 48.018) | 5d | 2002-06-24 A | 2002-06-28 A | 100% |  | 2002-06-24 | 2002-06-28 | 5d |  | finish no earlier than 2002-06-28 | G2 | 40h | 40h |  |  |  |  |  |  |  |  |
| 344 | 108 | **Multiple TBF in A/Gb mode** | 421d | 2002-04-19 A | 2003-11-28 | 17% | 349.82d | 2002-04-19 | 2003-11-28 | 421d | 68d |  | GP | 17480h | 2716.74h | MULTBF | Rel-5 | Gunnar Mildh, Ericsson | TSG |  | gunnar.mildh@era.ericsson.se |  |  |
| 345 | 108.1 | **Multiple TBF in A/Gb mode** | 351d | 2002-04-19 A | 2003-08-22 | 26% | 258.09d | 2002-04-19 | 2003-08-22 | 351d | 138d |  | GP | 8112h | 2147.29h | MULTBF-Agbmode |  |  |  |  |  |  |  |
| 346 | 108.1.1 | Multiple TBF Concept paper | 351d | 2002-04-19 A | 2003-08-22 | 50% | 175.5d | 2002-04-19 | 2003-08-22 | 351d | 138d | finish no earlier than 2003-08-22 | GP | 2808h | 1404h |  |  |  |  |  |  |  |  |
| 347 | 108.1.2 | Multiple TBF Stage 2 (43.064) CRs | 156d | 2002-04-19 | 2002-11-22 |  |  | 2002-04-19 | 2002-11-22 | 156d | 333d | finish no earlier than 2002-11-22 | G1 | 1248h |  |  |  |  |  |  |  |  |  |
| 348 | 108.1.3 | Multiple TBF Stage 3 (44.060) CRs | 156d | 2002-04-19 | 2002-11-22 |  |  | 2002-04-19 | 2002-11-22 | 156d | 333d | finish no earlier than 2002-11-22 | G2 | 1248h |  |  |  |  |  |  |  |  |  |
| 349 | 108.2 | **Multiple TBF in A/Gb mode – MS testing** | 375d | 2002-06-24 | 2003-11-28 |  |  | 2002-06-24 | 2003-11-28 | 375d | 68d |  | GP | 6000h |  |  |  | Ingemar Backlund, Ericsson |  |  |  |  |  |
| 350 | 108.2.1 | MS conformance tests | 375d | 2002-06-24 | 2003-11-28 |  |  | 2002-06-24 | 2003-11-28 | 375d | 68d | finish no earlier than 2003-11-28 | G4 | 3000h |  |  |  |  |  |  |  |  |  |
| 351 | 109 | **Alignment of 3G functional split and Iu** | 922d | 2000-06-08 A | 2003-12-19 | 85% | 141.74d | 2000-06-08 | 2003-12-19 | 922d | 53d |  | GP | 161582h | 123264h | GER3GAL | Rel-5 | Frank Muller, Ericsson | TSG | 2345 |  | Paolo |  |
| 352 | 109.1 | **GERAN user / control plane** | 540d | 2000-08-07 A | 2002-08-30 | 99% | 0d | 2000-08-07 | 2002-08-30 | 540d | 0d |  | GP | 36232h | 32092h | GER3GAL-GUCOPL |  | Frank Muller, Ericsson | TSG | 2346 |  | Paolo |  |
| 353 | 109.1.1 | **Alignment with UMTS bearer concept** | 540d | 2000-08-07 A | 2002-08-30 | 99% | 0d | 2000-08-07 | 2002-08-30 | 540d | 0d |  | GP | 24952h | 22392h |  |  |  | TSG | 2347 |  |  |  |
| 354 | 109.1.1.1 | Enhanced power control | 1d | 2001-08-31 A | 2001-08-31 A | 100% |  | 2001-08-31 | 2001-08-31 | 1d |  | finish no earlier than 2001-08-31 | GP | 8h | 8h |  |  |  | TSG |  |  |  |  |
| 355 | 109.1.1.2 | Stage 2 | 235d | 2000-08-07 A | 2001-06-29 A | 100% |  | 2000-08-07 | 2001-06-29 | 235d |  | finish no earlier than 2001-06-29 | GP | 1880h | 1880h |  |  |  | TSG | 2423 |  |  |  |
| 356 | 109.1.1.3 | Adoption of the UTRAN PDCP | 295d | 2000-11-06 A | 2001-12-21 A | 100% |  | 2000-11-06 | 2001-12-21 | 295d |  | finish no earlier than 2001-12-21 | GP | 2360h | 2360h |  |  |  | TSG | 2348 |  |  |  |
| 357 | 109.1.1.4 | Development of RLC / MAC | 261d | 2001-08-31 A | 2002-08-30 A | 100% |  | 2001-08-31 | 2002-08-30 | 261d |  | finish no earlier than 2002-08-30 | GP | 2088h | 2088h |  |  |  | TSG |  |  |  |  |
| 358 | 109.1.1.5 | Development of GERAN RRC | 266d | 2001-06-22 A | 2002-06-28 A | 100% |  | 2001-06-22 | 2002-06-28 | 266d |  | finish no earlier than 2002-06-28 | GP | 2128h | 2128h |  |  |  | TSG |  |  |  |  |
| 359 | 109.1.1.6 | Ciphering and integrity protection concept paper | 166d | 2001-08-31 A | 2002-04-19 A | 100% |  | 2001-08-31 | 2002-04-19 | 166d |  | finish no earlier than 2002-04-19 | GP | 1328h | 1328h |  |  |  | TSG |  |  |  |  |
| 360 | 109.1.1.7 | Multiple TBF or equivalent Concept paper | 116d | 2001-08-31 A | 2002-02-08 A | 100% |  | 2001-08-31 | 2002-02-08 | 116d |  | finish no earlier than 2002-02-08 | GP | 928h | 928h |  |  |  | TSG |  |  |  |  |
| 361 | 109.1.1.8 | Paging concept | 166d | 2001-08-31 A | 2002-04-19 A | 100% |  | 2001-08-31 | 2002-04-19 | 166d |  | finish no earlier than 2002-04-19 | GP | 1328h | 1328h |  |  |  | TSG |  |  |  |  |
| 362 | 109.1.1.9 | Dedicated Physical subchannels, includes traffic and control channels | 66d | 2001-08-31 A | 2001-11-30 A | 100% |  | 2001-08-31 | 2001-11-30 | 66d |  | finish no earlier than 2001-11-30 | GP | 528h | 528h |  |  |  | TSG |  |  |  |  |
| 363 | 109.1.1.10 | Iu support and broadcast concept | 166d | 2001-08-31 A | 2002-04-19 A | 100% |  | 2001-08-31 | 2002-04-19 | 166d |  | finish no earlier than 2002-04-19 | GP | 1328h | 1328h |  |  |  | TSG |  |  |  |  |
| 364 | 109.1.1.11 | Impact of using RLC instead of LAPDm concept | 116d | 2001-08-31 A | 2002-02-08 A | 100% |  | 2001-08-31 | 2002-02-08 | 116d |  | finish no earlier than 2002-02-08 | GP | 928h | 928h |  |  |  | TSG |  |  |  |  |
| 365 | 109.1.1.12 | Contention resolution, mobile station identity, and access concept | 66d | 2001-08-31 A | 2001-11-30 A | 100% |  | 2001-08-31 | 2001-11-30 | 66d |  | finish no earlier than 2001-11-30 | GP | 528h | 528h |  |  |  | TSG |  |  |  |  |
| 366 | 109.1.1.13 | PDCP concept | 166d | 2001-08-31 A | 2002-04-19 A | 100% |  | 2001-08-31 | 2002-04-19 | 166d |  | finish no earlier than 2002-04-19 | GP | 1328h | 1328h |  |  |  | TSG |  |  |  |  |
| 367 | 109.1.1.14 | Downlink delayed TBF release | 261d | 2001-08-31 A | 2002-08-30 A | 100% |  | 2001-08-31 | 2002-08-30 | 261d |  | finish no earlier than 2002-08-30 | GP | 2088h | 2088h |  |  |  | TSG |  |  |  |  |
| 368 | 109.1.1.15 | Add transparent RLC Concept | 116d | 2001-08-31 A | 2002-02-08 A | 100% |  | 2001-08-31 | 2002-02-08 | 116d |  | finish no earlier than 2002-02-08 | GP | 928h | 928h |  |  |  | TSG |  |  |  |  |
| 369 | 109.1.1.16 | Handover concept | 116d | 2001-08-31 A | 2002-02-08 A | 100% |  | 2001-08-31 | 2002-02-08 | 116d |  | finish no earlier than 2002-02-08 | GP | 928h | 928h |  |  |  |  |  |  |  |  |

Notes:
- 332: 8/3/2001: test spec is based on R99 core spec, so deleted from Workplan
- 334: "Joker" WI, to be used for a Rel 5 CR not related to any feature and with very limited impact on the system
- 336: az: Rel-5->NA (to cover also Rel-6)
- 345: Started
- 350: Not started
- 351: AWS, Nokia, Ericsson, Nortel, Siemens, Vodafone
- 352: AWS, Nokia, Ericsson, Nortel, Siemens, Vodafone
- 356: Responsible is GERAN; RAN WG2 help may be needed.

| ID | WBS | Task | Duration | Start | Finish | Complete | Remaining | Baseline start | Baseline finish | Baseline duration | Total slack | Constraint | Resources | Work | Actual work | Text7 | Text9 | Text1 | Text4 | Text8 |
| --- | --- | --- | --- | --- | --- | --- | --- | --- | --- | --- | --- | --- | --- | --- | --- | --- | --- | --- | --- | --- |
| 370 | 109.1.2 | **Physical layer alignment with UMTS bearer concept** | 280d | 2000-11-06 A | 2001-11-30 | 99% | 0d | 2000-11-06 | 2001-11-30 | 280d | 0d |  | GP | 6960h | 5380h | TSG | 2424 |  |  |  |
| 371 | 109.1.2.1 | PDTCH/TCH in 45.003 | 155d | 2000-11-06 A | 2001-06-08 A | 100% |  | 2000-11-06 | 2001-06-08 | 155d |  | finish no earlier than 2001-06-08 | GP | 1240h | 1240h | TSG | 2356 |  |  |  |
| 372 | 109.1.2.2 | Control channels in 45.003 | 155d | 2000-11-06 A | 2001-06-08 A | 100% |  | 2000-11-06 | 2001-06-08 | 155d |  | finish no earlier than 2001-06-08 | GP | 1240h | 1240h | TSG | 2357 |  |  |  |
| 373 | 109.1.2.3 | Receiver performance in 45.005 for PDTCH/TCH and control channels | 280d | 2000-11-06 A | 2001-11-30 A | 100% |  | 2000-11-06 | 2001-11-30 | 280d |  | finish no earlier than 2001-11-30 | GP | 2240h | 2240h | TSG | 2358 |  |  |  |
| 374 | 109.2 | **Iu rg interface** | 430d | 2000-11-06 A | 2002-06-28 A | 100% |  | 2000-11-06 | 2002-06-28 | 430d |  |  | GP; RP | 59660h | 56220h | TSG | 2359 | GER3GAL-Iurg | Frank Muller, Ericsson | Paolo |
| 375 | 109.2.1 | **Inter BSS interface** | 430d | 2000-11-06 A | 2002-06-28 A | 100% |  | 2000-11-06 | 2002-06-28 | 430d |  |  | GP; RP | 24080h | 24080h |  | 2425 |  |  |  |
| 376 | 109.2.1.1 | Identification of requirements | 430d | 2000-11-06 A | 2002-06-28 A | 100% |  | 2000-11-06 | 2002-06-28 | 430d |  | finish no earlier than 2002-06-28 | GP | 3440h | 3440h |  | 2360 |  |  |  |
| 377 | 109.2.1.2 | Stage 2 | 430d | 2000-11-06 A | 2002-06-28 A | 100% |  | 2000-11-06 | 2002-06-28 | 430d |  | finish no earlier than 2002-06-28 | GP | 3440h | 3440h |  | 2361 |  |  |  |
| 378 | 109.2.1.3 | Adoption of relevant parts from Iur | 430d | 2000-11-06 A | 2002-06-28 A | 100% |  | 2000-11-06 | 2002-06-28 | 430d |  | finish no earlier than 2002-06-28 | GP | 3440h | 3440h |  | 2362 |  |  |  |
| 379 | 109.2.1.4 | Complementation with GERAN specifics | 430d | 2000-11-06 A | 2002-06-28 A | 100% |  | 2000-11-06 | 2002-06-28 | 430d |  | finish no earlier than 2002-06-28 | GP | 3440h | 3440h |  | 2363 |  |  |  |
| 380 | 109.2.1.5 | Stage 3 | 430d | 2000-11-06 A | 2002-06-28 A | 100% |  | 2000-11-06 | 2002-06-28 | 430d |  | finish no earlier than 2002-06-28 | GP | 3440h | 3440h |  | 2364 |  |  |  |
| 381 | 109.2.2 | **Inter BSS-RNS interface** | 430d | 2000-11-06 A | 2002-06-28 A | 100% |  | 2000-11-06 | 2002-06-28 | 430d |  |  | GP; RP | 28700h | 28700h |  | 2426 |  |  |  |
| 382 | 109.2.2.1 | Identification of requirements | 430d | 2000-11-06 A | 2002-06-28 A | 100% |  | 2000-11-06 | 2002-06-28 | 430d |  | start no earlier than 2000-11-06 | GP; R3 | 6880h | 6880h |  | 2365 |  |  |  |
| 383 | 109.2.2.2 | Stage 2 | 430d | 2000-11-06 A | 2002-06-28 A | 100% |  | 2000-11-06 | 2002-06-28 | 430d |  | finish no earlier than 2002-06-28 | GP; R3 | 5744.8h | 5744.8h |  | 2366 |  |  |  |
| 384 | 109.2.2.3 | Adoption of relevant parts from Iur | 430d | 2000-11-06 A | 2002-06-28 A | 100% |  | 2000-11-06 | 2002-06-28 | 430d |  | finish no earlier than 2002-06-28 | GP; R3 | 6880h | 6880h |  | 2367 |  |  |  |
| 385 | 109.2.2.4 | Complementation with GERAN specifics | 107.5d | 2002-01-30 A | 2002-06-28 A | 100% |  | 2002-01-30 | 2002-06-28 | 107.5d |  | finish no earlier than 2002-06-28 | GP; R3 | 1720h | 1720h |  | 2368 |  |  |  |
| 386 | 109.2.2.5 | Stage 3 | 107.5d | 2002-01-30 A | 2002-06-28 A | 100% |  | 2002-01-30 | 2002-06-28 | 107.5d |  | finish no earlier than 2002-06-28 | GP; R3 | 1720h | 1720h |  | 2369 |  |  |  |
| 387 | 109.3 | **Voice over GERAN PS and CS concept** | 430d | 2000-11-06 A | 2002-06-28 A | 100% |  | 2000-11-06 | 2002-06-28 | 430d |  |  | GP; R3 | 33338.4h | 33338.4h |  | 2370 |  |  | Paolo |
| 388 | 109.3.1 | Architecture for A, Iu cs and Iu ps | 430d | 2000-11-06 A | 2002-06-28 A | 100% |  | 2000-11-06 | 2002-06-28 | 430d |  | finish no earlier than 2002-06-28 | GP; R3 | 6412.8h | 6412.8h |  | 2371 |  |  |  |
| 389 | 109.3.2 | Transcoder position/operation | 115d | 2000-11-06 A | 2001-04-13 A | 100% |  | 2000-11-06 | 2001-04-13 | 115d |  | finish no earlier than 2001-04-13 | GP | 920h | 920h |  | 2372 |  |  |  |
| 390 | 109.3.3 | Handover | 430d | 2000-11-06 A | 2002-06-28 A | 100% |  | 2000-11-06 | 2002-06-28 | 430d |  | finish no earlier than 2002-06-28 | GP; R3 | 6412.8h | 6412.8h |  | 2373 |  |  |  |
| 391 | 109.3.4 | RTP payload | 430d | 2000-11-06 A | 2002-06-28 A | 100% |  | 2000-11-06 | 2002-06-28 | 430d |  | finish no earlier than 2002-06-28 | GP; R3 | 6412.8h | 6412.8h |  | 2374 |  |  |  |
| 392 | 109.3.5 | Codec renegotiation concept | 365d | 2000-11-06 A | 2002-03-29 A | 100% |  | 2000-11-06 | 2002-03-29 | 365d |  | finish no earlier than 2002-03-29 | GP; R3 | 5840h | 5840h |  |  |  |  |  |
| 393 | 109.3.6 | LA | 115d | 2000-11-06 A | 2001-04-13 A | 100% |  | 2000-11-06 | 2001-04-13 | 115d |  | finish no earlier than 2001-04-13 | GP | 920h | 920h |  |  |  |  |  |

Notes:
- 374: AWS, Nokia, Ericsson, Nortel, Siemens, Vodafone

| ID | WBS | Task | Duration | Start | Finish | Complete | Remaining | Baseline start | Baseline finish | Baseline duration | Total slack | Constraint | Resources | Work | Actual work | Text8 | Text9 | Text1 | Text4 | Text6 | Text7 |
| --- | --- | --- | --- | --- | --- | --- | --- | --- | --- | --- | --- | --- | --- | --- | --- | --- | --- | --- | --- | --- | --- |
| 394 | 109.4 | **GERAN MS Conformance test for GERAN interface evolution** | 660d | 2001-06-11 | 2003-12-19 |  |  | 2001-06-11 | 2003-12-19 | 660d | 53d |  | GP | 10560h |  | Paolo | 2388 |  |  |  |  |
| 395 | 109.4.1 | MS test | 660d | 2001-06-11 | 2003-12-19 |  |  | 2001-06-11 | 2003-12-19 | 660d | 53d | finish no earlier than 2003-12-19 | GP | 5280h |  |  | 2389 |  |  |  |  |
| 396 | 109.5 | **GERAN BSS Conformance test for GERAN interface evolution** | 922d | 2000-06-08 | 2003-12-19 |  |  | 2000-06-08 | 2003-12-19 | 922d | 53d |  | GP | 14752h |  | Paolo | 2390 |  |  |  |  |
| 397 | 109.5.1 | BSS test | 922d | 2000-06-08 | 2003-12-19 |  |  | 2000-06-08 | 2003-12-19 | 922d | 53d | finish no earlier than 2003-12-19 | GP | 7376h |  |  | 2391 |  |  |  |  |
| 398 | 110 | **GERAN support for IMS** | 690d | 2000-05-01 A | 2002-12-20 | 59% | 286.24d | 2000-05-01 | 2002-12-20 | 690d | 313d |  | GP | 66591.8h | 29961h | Paolo |  | GERIMS | Shkumbin Hamiti, Nokia | Rel-5 | TSG |
| 399 | 110.1 | **GERAN Header adaptation** | 690d | 2000-05-01 A | 2002-12-20 | 100% | 0d | 2000-05-01 | 2002-12-20 | 690d | 0d |  | GP; S2; RP | 27325.8h | 18525.8h | Paolo |  | GERIMS-HEADAPT | Shkumbin Hamiti, Nokia |  | TSG |
| 400 | 110.1.1 | Definition of compression and removal modes for PDCP protocol | 22.1d | 2000-05-01 A | 2000-11-10 A | 100% |  | 2000-05-01 | 2000-11-10 | 22.1d |  | finish no earlier than 2000-09-01 | GP; S2; RP | 248.4h | 248.4h |  | 2332 |  |  |  | TSG |
| 401 | 110.1.2 | Conceptual description in stage 2 | 393d | 2000-05-01 A | 2001-10-31 A | 100% |  | 2000-05-01 | 2001-10-31 | 393d |  | finish no earlier than 2001-10-31 | GP; S2; RP | 5989.92h | 5989.92h |  | 2333 |  |  |  | TSG |
| 402 | 110.1.3 | Necessary changes on stage 3 regarding header removal | 439.8d | 2000-11-06 A | 2002-12-20 A | 100% |  | 2000-11-06 | 2002-12-20 | 439.8d |  | finish no earlier than 2002-12-20 | GP; S2; RP | 6767.47h | 6767.47h |  |  |  |  |  | TSG |
| 403 | 110.2 | **GERAN Radio access bearer design for IMS** | 430d | 2000-11-06 A | 2002-06-28 | 89% | 46.49d | 2000-11-06 | 2002-06-28 | 430d | 438d |  | GP; S2; RP | 21658h | 8621.71h | Paolo | 2335 | GERIMS-RABDES | Shkumbin Hamiti, Nokia |  | TSG |
| 404 | 110.2.1 | **MuM control signalling for conversational multimedia services** | 430d | 2000-11-06 A | 2002-06-28 | 89% | 46.49d | 2000-11-06 | 2002-06-28 | 430d | 438d |  | GP; S2; RP | 12458h | 5553.6h |  | 2422 |  |  |  | TSG |
| 405 | 110.2.1.1 | Identification of requirements | 330d | 2000-11-06 A | 2002-02-08 A | 100% |  | 2000-11-06 | 2002-02-08 | 330d |  | finish no earlier than 2002-02-08 | GP; S2; RP | 5545.6h | 5545.6h |  | 2431 |  |  |  | TSG |
| 406 | 110.2.1.2 | Necessary modifications due to SIP | 40d | 2002-05-06 | 2002-06-28 |  |  | 2002-05-06 | 2002-06-28 | 40d | 438d | finish no earlier than 2002-06-28 | GP; S2; RP | 960h |  |  | 2337 |  |  |  | TSG |
| 407 | 110.3 | **GERAN MS Conformance test for support of IMS** | 400d | 2001-06-11 | 2002-12-20 |  |  | 2001-06-11 | 2002-12-20 | 400d | 313d |  | GP | 6400h |  | Paolo | 2341 | GERIMS-MSconf | Shkumbin Hamiti, Nokia |  | TSG |
| 408 | 110.3.1 | MS test | 400d | 2001-06-11 | 2002-12-20 |  |  | 2001-06-11 | 2002-12-20 | 400d | 313d | finish no earlier than 2002-12-20 | G4 | 3200h |  |  | 2342 |  |  |  | TSG |
| 409 | 110.4 | **GERAN BTS Conformance test for support of IMS** | 400d | 2001-06-11 | 2002-12-20 |  |  | 2001-06-11 | 2002-12-20 | 400d | 313d |  | GP | 6400h |  | Paolo | 2343 | GERIMS-BTSconf | Shkumbin Hamiti, Nokia |  | TSG |
| 410 | 110.4.1 | BTS test | 400d | 2001-06-11 | 2002-12-20 |  |  | 2001-06-11 | 2002-12-20 | 400d | 313d | finish no earlier than 2002-12-20 | G3 | 3200h |  |  | 2344 |  |  |  | TSG |
| 411 | 40 | MS Conformance Testing of Dual Transfer Mode | 65d? | 2002-11-11 A | 2003-02-07 A | 100% |  | 2002-11-11 | 2003-02-07 | 65d? |  | finish no earlier than 2003-02-07 | G4; G5 | 1040h | 1040h |  |  | MSCTDTM | Dave Fox, Vodafone | NA | TSG |
| 412 | 41 | **Handling of early UEs** | 910d? | 2000-01-03 A | 2003-06-27 | 99% | 2.45d? | 2002-10-07 | 2003-06-27 | 190d? | 178d |  | S2 | 4480h | 4475.9h | Alain |  | LATE_UE |  | Rel-5 | TSG |
| 413 | 41.1 | Feasibility Study | 50d? | 2002-10-07 A | 2002-12-13 A | 100% |  | 2002-10-07 | 2002-12-13 | 50d? |  | finish no earlier than 2002-12-13 | S2 | 400h | 400h |  |  |  |  |  | WG |
| 414 | 41.2 | Stage 2 | 125d? | 2003-01-06 A | 2003-06-27 A | 100% |  | 2003-01-06 | 2003-06-27 | 125d? |  | start no earlier than 2003-01-06 | S2 | 1000h | 1000h |  |  |  |  |  | WG |
| 415 | 41.3 | FS for the Early Mobile Handling in UTRAN | 195d | 2002-09-09 A | 2003-06-06 A | 100% |  | 2002-09-09 | 2003-03-14 | 135d |  | finish no earlier than 2003-06-06 | R2 | 1560h | 1560h |  |  | FSEarlyUE | Alan Law, Vodafone Ltd | Rel-5 | TSG |
| 416 | 41.4 | Note: Stage 3 RAN part not shown | 1d | 2000-01-03 | 2000-01-03 |  |  | 2000-01-03 | 2000-01-03 | 1d | 1087d |  |  |  |  |  | 96 |  |  |  |  |

Notes:
- 394: Not started
- 395: Not started
- 396: Not started
- 397: Not started
- 398: AWS, Nokia, Ericsson, Nortel, Siemens, Motorola
- 399: AWS, Nokia, Ericsson, Nortel, Siemens, Motorola
- 403: TERMINATED - NOT STANDARDIZED
- 404: TERMINATED - NOT STANDARDIZED
- 405: TERMINATED - NOT STANDARDIZED
- 406: TERMINATED - NOT STANDARDIZED
- 407: TERMINATED - NOT STANDARDIZED
- 408: TERMINATED - NOT STANDARDIZED
- 409: TERMINATED - NOT STANDARDIZED
- 410: TERMINATED - NOT STANDARDIZED
- 411: Needed to complete DTM (R99)
