# 3GPP_Release-2000

Schedule from MS Project, 2000-01-03 to 2007-06-06, A marks actual dates.

## Calendars

- Standard: Mon-Fri 08:00-12:00, 13:00-17:00; Sat-Sun off.

## Resources

| Resource |
| --- |
| NP |
| N1 |
| N2 |
| N3 |
| N4 |
| N5 |
| TP |
| T1 |
| T2 |
| T3 |
| RP |
| R1 |
| R2 |
| R3 |
| R4 |
| SP |
| S1 |
| S2 |
| S3 |
| S4 |
| S5 |
| PCG |
| GP |
| No |
| CN4 |
| ? |
| WG G2 |
| G2 |
| G1 |
| G4 |
| G3 |
| All |
| Generic |
| MLST |
| G5 |
| S3; G2 |
| WG T2 |
| GP;G1 |
| G4;G5 |
| OMA |
| GP-G2 |
| Yes |
| GP; |
| N4; |
| GP; N1 |
| CT5 |
| C5 |
| C1 |
| C4 |
| C3 |
| C6 |

## Schedule

| ID | WBS | Task | Type | Duration | Start | Finish | Complete | Remaining | Baseline start | Baseline finish | Baseline duration | Total slack | Constraint | Resources | Work | Actual work | Text9 | Text6 | Text1 | Text3 | Text4 | Text5 | Text7 | Text8 | Text2 | Text12 |
| --- | --- | --- | --- | --- | --- | --- | --- | --- | --- | --- | --- | --- | --- | --- | --- | --- | --- | --- | --- | --- | --- | --- | --- | --- | --- | --- |
| 1 | 1 | VERSION 2005 April 22nd |  | 1d | 2000-01-03 | 2000-01-03 |  |  | 2000-01-03 | 2000-01-03 | 1d | 1937d |  |  |  |  | 2044 |  |  |  |  |  |  |  |  |  |
| 2 | 2 | "CTRL + a" to display all the 3GPP fields |  | 1d | 2000-01-03 | 2000-01-03 |  |  | 2000-01-03 | 2000-01-03 | 1d | 1937d |  |  |  |  | 1462 |  |  |  |  |  |  |  |  |  |
| 3 | 3 | Content of Release 7, not frozen |  | 1d | 2000-01-03 | 2000-01-03 |  |  | 2000-01-03 | 2000-01-03 | 1d | 1937d |  |  |  |  | 2058 |  |  |  |  |  |  |  |  |  |
| 5 | 4 | Rel-7 Features listed below |  | 1d? | 2000-01-03 | 2000-01-03 |  |  | 2000-01-03 | 2000-01-03 | 1d? | 1937d |  |  |  |  |  | Rel-7 |  |  |  |  |  |  |  |  |
| 6 | 8.5 | **Multiple Input Multiple Output antennas (MIMO)** |  | 719d? | 2003-03-14 A | 2005-12-15 | 12% | 634.49d? | 2003-03-14 | 2005-12-15 | 719d? | 385d |  | R1 | 23544h | 4190.4h | 2468 | Rel-7 | MIMO | TR25.876,TR25.996 | Howard Huang, Lucent | hchuang@lucent.com | TSG | Cesar |  |  |
| 7 | 5.1 | Physical layer |  | 392d? | 2003-09-12 A | 2005-03-15 | 60% | 156.8d? | 2003-09-12 | 2005-03-15 | 392d? | 582d | finish no earlier than 2005-03-15 | R1 | 3136h | 1881.6h |  | Rel-7 | MIMO-Phys | 25.211, 25.212, 25.213, 25.214, 25.215, 25.221, 25 | Howard Huang, Lucent | hchuang@lucent.com | TSG | MCC RAN |  |  |
| 8 | 5.2 | Layer 2,3 aspects |  | 589d? | 2003-09-12 | 2005-12-15 |  |  | 2003-09-12 | 2005-12-15 | 589d? | 385d | finish no earlier than 2005-12-15 | R2 | 4712h |  |  | Rel-7 | MIMO-L23 | TR 25.876 | Howard Huang, Lucent | hchuang@lucent.com | TSG | MCC RAN |  |  |
| 9 | 5.3 | Iub/Iur Protocol Aspects |  | 719d? | 2003-03-14 | 2005-12-15 |  |  | 2003-03-14 | 2005-12-15 | 719d? | 385d | finish no earlier than 2005-12-15 | R3 | 5752h |  |  | Rel-7 | MIMO-IurIub |  | Howard Huang, Lucent | hchuang@lucent.com | TSG | MCC RAN |  |  |
| 10 | 5.4 | RF, Performance Req and Conf. Testing |  | 524d? | 2003-12-12 A | 2005-12-15 | 5% | 497.8d? | 2003-12-12 | 2005-12-15 | 524d? | 385d | finish no earlier than 2005-12-15 | R4 | 4192h | 209.6h |  | Rel-7 | MIMO-RF |  | Man Hung Ng, Lucent | ngm@lucent.com | TSG | MCC RAN |  |  |
| 11 | 6 | **PS domain and IMS impacts for supporting IMS Emergency calls** |  | 1389d? | 2000-08-14 A | 2005-12-08 | 34% | 910.11d? | 2000-08-14 | 2005-12-08 | 1389d? | 389d |  | S2 | 55848h | 15793.4h |  | Rel-7 | EMC1 |  | Rainer Liebhart |  | TSG | Sang-Ui |  |  |
| 12 | 10.1.1 | Service Requirements for IP-based emergency calls |  | 985d | 2000-09-18 A | 2004-06-25 A | 100% |  | 2000-09-18 | 2004-06-25 | 985d |  | finish no earlier than 2004-06-25 | S1 | 7880h | 7880h | 1314 | Rel-7 | EMC1 | 22.976 |  |  |  |  | CCaR |  |
| 13 | 6.2 | Stage 2 for IMS-level solution |  | 612d? | 2003-02-26 A | 2005-06-30 | 72% | 171.36d? | 2003-02-26 | 2005-06-30 | 612d? | 504d | finish no earlier than 2005-06-30 | S2 | 4896h | 3525.12h |  | Rel-7 | EMC1 | 23.228, 23.060, 23.002 | Rainer Liebhart, Siemenws |  | TSG |  |  |  |
| 14 | 6.3 | Stage 2 for GPRS-level solution |  | 301d? | 2004-10-14 A | 2005-12-08 | 26% | 222.74d? | 2004-10-14 | 2005-12-08 | 301d? | 389d | finish no earlier than 2005-12-08 | S2 | 2408h | 626.08h |  | Rel-7 | EMC1 |  |  |  |  |  |  |  |
| 15 | 10.1 | **Emergency Call Enhancements for IP& PS Based Calls – stage 3** |  | 1280.1d | 2000-08-14 A | 2005-07-11 |  | 1280.1d | 2000-08-14 | 2005-06-03 | 1255d | 497.9d |  | C1 | 29752h |  | 1653 | Rel-7 | EMC1 |  | Mr Atle Monrad, Ericsson | Atle.Monrad@eto.ericsson.se |  |  | CCaR |  |
| 16 | 10.1.2 | IMS aspects to support IMS Emergency sessions |  | 1209d | 2000-10-17 A | 2005-07-08 |  | 1209d | 2000-10-17 | 2005-06-03 | 1209d | 498.82d | finish no earlier than 2005-06-03 | C1 | 9672h |  | 1315 | Rel-7 | EMC1 | 24.229 | Mr Atle Monrad, Ericsson | Atle.Monrad@eto.ericsson.se |  |  | CCaR |  |
| 17 | 10.1.5 | PS domain aspects to support IMS Emergency sessions |  | 1255d | 2000-08-14 A | 2005-07-11 |  | 1255d | 2000-08-14 | 2005-06-03 | 1255d | 497.9d | finish no earlier than 2005-06-03 | C1 | 10040h |  | 1646 | Rel-7 | EMC1 | 24.008 | Mr Atle Monrad, Ericsson | Atle.Monrad@eto.ericsson.se |  |  | CCaR |  |
| 18 | 7 | **Access Class Barring and Overload Protection** |  | 274d? | 2004-03-15 A | 2005-03-31 | 49% | 139.29d? | 2004-03-15 | 2005-03-31 | 274d? | 569d |  | S2 | 4928h | 2422.79h |  | Rel-7 | ACBOP | 23.898 | Chris Pudney, Vodafone |  | TSG | Sang-Ui |  |  |
| 19 | 7.1 | TR on Stage 2 |  | 274d? | 2004-03-15 A | 2005-03-31 | 61% | 106.86d? | 2004-03-15 | 2005-03-31 | 274d? | 569d | finish no earlier than 2005-03-31 | S2 | 2192h | 1337.12h |  | Rel-7 | ACBOP |  |  |  | TSG |  |  |  |
| 20 | 7.2 | Extra ACBOP information in GERAN |  | 67d? | 2004-03-15 | 2004-06-15 |  |  | 2004-03-15 | 2004-06-15 | 67d? | 776d | start no earlier than 2004-03-15 | GP | 536h |  |  | Rel-7 | ACBOP | 44.018 |  |  | TSG |  |  |  |
| 21 | 7.3 | Stage 3 CN aspects of ACBOP |  | 1d? | 2004-12-08 A | 2004-12-08 A | 100% |  | 2004-12-08 | 2004-12-08 | 1d? |  | finish no earlier than 2004-12-08 | C1 | 8h | 8h |  | Rel-7 | ACBOP |  |  |  |  |  |  |  |
| 22 | 7.4 | Deleted - Potential impact on Iu interface Overload functionality | milestone | 0d? | 2004-03-15 A | 2004-03-15 A | 100% |  | 2004-03-15 | 2004-03-15 | 0d? |  | finish no earlier than 2004-03-15 | RP |  |  |  | Rel-7 | ACBOP | 25.413 |  |  |  |  |  | RP-25 |
| 23 | 7.5 | Deleted - Extra ACBOP information in RAN | milestone | 0d? | 2004-03-15 A | 2004-03-15 A | 100% |  | 2004-03-15 | 2004-03-15 | 0d? |  | finish no earlier than 2004-03-15 | RP |  |  |  | Rel-7 | ACBOP | 25.331 |  |  |  |  |  | RP-25 |
| 24 | 8 | **USSD message delivery and transfer to USIM** |  | 443.7d? | 2004-03-05 A | 2005-11-16 | 29% | 313.06d? | 2004-03-05 | 2005-03-04 | 261d? | 405.3d |  | S1 | 6781.6h | 1996.71h |  | Rel-7 | USSD-USIM | 22.090 |  |  | TSG | Michael |  |  |
| 25 | 8.1 | Stage 1 |  | 152d? | 2004-03-18 A | 2004-10-15 | 80% | 30.4d? | 2004-03-18 | 2004-10-15 | 152d? | 688d | start no earlier than 2004-03-18 | S1 | 1216h | 972.8h |  | Rel-7 | USSD-USIM | 22.090 |  |  | TSG | Michael |  |  |
| 26 | 8.2 | Alignment with requirements regarding USSD usage |  | 261d? | 2004-03-05 A | 2005-11-16 |  | 261d? | 2004-03-05 | 2005-03-04 | 261d? | 405.3d | finish no earlier than 2005-03-04 | C6 | 2088h |  |  | Rel-7 | USSD-USIM |  | Christophe Dubois (Axalto) | cdubois@axalto.com | TSG |  |  |  |

Notes:
- 21: NEW - inserted on 2/9/2004

| ID | WBS | Task | Type | Duration | Start | Finish | Complete | Remaining | Baseline start | Baseline finish | Baseline duration | Total slack | Constraint | Resources | Work | Actual work | Text1 | Text3 | Text6 | Text8 | Text4 | Text5 | Text7 |
| --- | --- | --- | --- | --- | --- | --- | --- | --- | --- | --- | --- | --- | --- | --- | --- | --- | --- | --- | --- | --- | --- | --- | --- |
| 27 | 9 | **Location Services enhancements Rel-7** |  | 513d? | 2004-06-28 A | 2006-06-15 | 19% | 413.95d? | 2004-06-28 | 2006-06-15 | 513d? | 255d |  | S2 | 17682.4h | 3328.81h | LCS3 | 23.271 | Rel-7 | Sang-Ui |  |  |  |
| 28 | 9.1 | Global Stage 2 for LCS3 |  | 321d? | 2004-12-31 A | 2006-03-24 | 10% | 288.9d? | 2005-03-15 | 2006-12-06 | 452d? | 313d | finish no earlier than 2006-03-24 | S2 | 2568h | 256.8h | LCS3 | 23.271 | Rel-7 | Maurice | Ben Rodilitz, SiRF | brodilitz@sirf.com | TSG |
| 29 | 9.2 | **LCS for 3GPP Interworking WLAN** |  | 135.3d? | 2004-06-28 A | 2005-01-03 | 65% | 47.35d? | 2004-06-28 | 2005-01-03 | 135.3d? | 632.7d |  | S1 | 2066.4h | 738h | LCS3-IWLAN | 22.935 | Rel-7 | Michael | Mike Loushine, (Telcordia) |  | TSG |
| 30 | 9.2.1 | FS on 3GPP system to WLAN Interworking with LCS |  | 123d? | 2004-06-28 A | 2005-01-03 | 65% | 43.05d? | 2004-06-28 | 2005-01-03 | 123d? | 632.7d | start no earlier than 2004-06-28 | S1 | 984h | 639.6h | LCS3-IWLAN | 22.935 | Rel-7 |  |  |  |  |
| 31 | 9.3 | **UE positioning Rel-7** |  | 456d? | 2004-09-15 A | 2006-06-15 | 20% | 364.8d? | 2004-09-15 | 2006-06-15 | 456d? | 255d |  | RP | 7296h | 1459.2h | LCS3-UEpos |  | Rel-7 | MCC_RAN |  |  | TSG |
| 32 | 9.3.1 | Inclusion of Uplink TDOA UE positioning method in the UTRAN specifications |  | 456d? | 2004-09-15 A | 2006-06-15 | 20% | 364.8d? | 2004-09-15 | 2006-06-15 | 456d? | 255d | finish no earlier than 2006-06-15 | R2 | 3648h | 729.6h | LCS3-UEPos-UTDOA | TS25.305, TS25.453 | Rel-7 | MCC_RAN | Robert Gross, TruePosition | rlgross@trueposition.com | TSG |
| 33 | 9.4 | LCS Enhancements Related to Location-Based Services |  | 206d? | 2005-01-28 A | 2005-11-11 | 5% | 195.7d? | 2005-01-28 | 2005-06-24 | 106d? | 408d | finish no earlier than 2005-11-11 | GP | 1648h | 82.4h | LCS3-LBS | 43.059, 44.031, 48.008, 49.031 | Rel-7 | Paolo | Kevin Judge, SiRF Technologies | kjudge@sirf.com | TSG |
| 34 | 10 | **FS on applicability of GALILEO for LCS** |  | 779d? | 2002-07-08 A | 2005-06-30 | 45% | 428.45d? | 2002-07-08 | 2005-06-30 | 779d? | 504d |  | S2 | 12464h | 3804.4h | Galileo |  | Rel-7 | David |  |  |  |
| 35 | 10.1 | TR on Stage 2 |  | 779d? | 2002-07-08 A | 2005-06-30 | 45% | 428.45d? | 2002-07-08 | 2005-06-30 | 779d? | 504d | finish no earlier than 2005-06-30 | S2 | 6232h | 2804.4h | Galileo |  | Rel-7 |  |  |  |  |
| 36 | 10.2 | deleted - GERAN review of the TR | milestone | 0d? | 2003-08-25 | 2003-08-25 |  |  | 2003-08-25 | 2003-08-25 | 0d? | 988d | finish no earlier than 2003-08-25 | GP |  |  | Galileo |  | Rel-7 |  |  |  |  |
| 37 | 11 | **Selective Disabling of UE Capabilities** |  | 489.36d? | 2005-01-24 A | 2006-12-08 | 11% | 436.61d? | 2004-06-28 | 2005-03-16 | 188d? | 128d |  | S1 | 8857.6h | 1017.98h | SDoUE | 22.xxx | Rel-7 | Michael | Nigel Barnes (Motorola Ltd) | Nigel.Barnes@motorola.com | TSG |
| 38 | 11.1 | Stage 1 |  | 393.6d? | 2005-01-24 A | 2006-12-08 | 18% | 322.75d? | 2004-06-28 | 2005-03-16 | 188d? | 128d | finish no earlier than 2006-12-08 | S1 | 3148.8h | 566.78h | SDoUE-CRs | 22.101 | Rel-7 | Michael | Nigel Barnes (Motorola Ltd) | Nigel.Barnes@motorola.com | TSG |
| 39 | 11.2 | TR on different possible architectures |  | 263.6d? | 2005-03-21 A | 2006-06-09 |  | 263.6d? | 2004-06-28 | 2005-03-16 | 188d? | 258d | finish no earlier than 2006-06-09 | S2 | 2108.8h |  |  | 22.xxx | Rel-7 | Maurice |  |  | TSG |
| 40 | 12 | **Combinational Services** |  | 205d? | 2005-01-17 A | 2005-10-28 | 7% | 191.68d? | 2005-01-17 | 2005-07-15 | 130d? | 418d |  | S1 | 4840h | 314.6h | IRTSD-IMSCSs1 ? |  | Rel-7 | Michael | Robert Frank, TeliaSonera | Robert.Frank@teliasonera.com | TSG |
| 41 | 12.1 | Stage 1 |  | 104d? | 2005-01-17 A | 2005-06-09 | 25% | 78d? | 2005-01-17 | 2005-06-09 | 104d? | 519d | start no earlier than 2005-01-17 | S1 | 832h | 208h | CSICS | 22.279 | Rel-7 |  |  |  | TSG |
| 42 | 12.2 | Stage 2 |  | 104d? | 2005-01-17 | 2005-07-15 |  |  | 2005-01-17 | 2005-07-15 | 104d? | 493d | start no earlier than 2005-01-17 | S2 | 832h |  | CSICS | 22.379 | Rel-7 |  |  |  | TSG |
| 43 | 12.3 | Stage 3 for CN aspects |  | 130d? | 2005-05-02 | 2005-10-28 |  |  |  |  |  | 418d | start no earlier than 2005-05-01 | C1 | 1040h |  | CSICS | 24.229, 24.008 | Rel-7 | Andrijana | Peter Dawes (Vodafone) |  | TSG |
| 44 | 12.4 | Stage 3 for codec aspects |  | 62d? | 2005-03-15 | 2005-06-08 |  |  |  |  |  | 520d | start no earlier than 2005-03-15 | S4 | 496h |  | CSICS-Codec | TS 26.141, 26.235, 26.236 | Rel-7 | Paolo | Per Fröjdh, Ericsson | Per.Frojdh@ericsson.com | TSG |
| 45 | 13 | **All-IP Network (AIPN)** |  | 448d? | 2004-06-28 A | 2006-03-15 | 41% | 262.18d? | 2004-06-28 | 2005-03-16 | 188d? | 320d |  | S1 | 8672h | 3596.97h | AIPN | 22.978 | Rel-7 | Michael | Chris Sachno (NTT DoCoMo) | c.masyu@nttdocomo.co.jp | TSG |
| 46 | 13.1 | All-IP Network Feasibility Study |  | 188d? | 2004-06-28 A | 2005-03-16 A | 100% |  | 2004-06-28 | 2005-03-16 | 188d? |  | start no earlier than 2004-06-28 | S1 | 1504h | 1504h | AIPFS | 22.978 | Rel-7 | Michael | Chris Sachno (NTT DoCoMo) | c.masyu@nttdocomo.co.jp | TSG |
| 47 | 13.2 | Stage1 |  | 448d? | 2004-06-28 A | 2006-03-15 | 17% | 372.2d? | 2004-06-28 | 2005-03-16 | 188d? | 320d | finish no earlier than 2006-03-15 | S1 | 3584h | 606.4h | AIPN | 22.978 | Rel-7 | Michael | Chris Sachno (NTT DoCoMo) | c.masyu@nttdocomo.co.jp | TSG |
| 48 | 14 | Enhancement of E2E QoS |  | 213.4d? | 2004-06-28 A | 2005-06-13 | 30% | 149.38d? | 2004-06-28 | 2005-06-13 | 213.4d? | 517d | finish no earlier than 2005-06-13 | S2 | 1707.2h | 512.16h | QoS7 | 23.802 | Rel-7 | Sang-Ui |  |  | TSG |
| 49 | 15 | **System enhancements for fixed broadband access to IMS** |  | 287d? | 2004-08-03 A | 2005-09-07 | 6% | 269.17d? | 2004-08-03 | 2005-09-07 | 287d? | 455d |  | S2 | 3849.6h | 239.11h | FBI |  | Rel-7 | Sang-Ui |  |  | TSG |
| 50 | 15.1 | Stage 2 |  | 235d? | 2004-10-14 A | 2005-09-07 | 7% | 218.55d? | 2004-10-14 | 2005-09-07 | 235d? | 455d | finish no earlier than 2005-09-07 | S2 | 1880h | 131.6h | FBI |  | Rel-7 | Sang-Ui |  |  | TSG |
| 51 | 15.2 | Protocol impact from providing IMS services via fixed broadband |  | 153d? | 2004-08-03 A | 2005-03-03 | 5% | 145.35d? | 2004-08-03 | 2005-03-03 | 153d? | 589d | finish no earlier than 2005-03-03 | C1 | 1224h | 61.2h | FBI | new TR, 24.229, 29.229, 29.163, 29.209 | Rel-7 | Andrijana | Siemens |  | TSG |

Notes:
- 28: Approved SA#27. Appropriate place forEmergency work to be found
- 30: DAB - Should be SA1
- 32: Approved at RP#25 as RP-040387
- 33: Linked SP-040682
- 48: DAB - pushed back to June
- 51: WI sent to NP#25 for approval

| ID | WBS | Task | Duration | Start | Finish | Complete | Remaining | Baseline start | Baseline finish | Baseline duration | Total slack | Constraint | Resources | Work | Actual work | Text1 | Text6 | Text4 | Text5 | Text8 | Text7 |
| --- | --- | --- | --- | --- | --- | --- | --- | --- | --- | --- | --- | --- | --- | --- | --- | --- | --- | --- | --- | --- | --- |
| 52 | 16.7 | **IMS Local services (CN WID needed)** | 1158d? | 2001-01-01 A | 2005-06-08 | 29% | 821.97d? | 2001-01-01 | 2005-06-08 | 1158d? | 520d |  | S2 | 18224h | 5192.02h | IMSLocal | Rel-7 |  |  |  |  |
| 53 | 16.7.1 | Deleted - Stage 2 (SA2 propose delete this) | 325d | 2001-01-01 A | 2002-03-29 A | 100% |  | 2001-01-01 | 2002-03-29 | 325d |  | start no earlier than 2001-01-01 | S2 | 2600h | 2600h | IMSLocal | Rel-7 |  |  |  |  |
| 54 | 16.2 | Stage 3 for IMS Local services | 151d? | 2004-11-10 | 2005-06-08 |  |  | 2004-11-10 | 2005-06-08 | 151d? | 520d | finish no earlier than 2005-06-08 | C1 | 1208h |  | IMSLocal | Rel-7 | Keith Drage, Lucent | drage@lucent.com |  |  |
| 55 | 16.3 | Mp (MRFC - MRFP) interface - CN4 Part (check supporting companies) | 644d | 2002-12-13 | 2005-06-01 |  |  | 2002-12-13 | 2005-06-01 | 644d | 525d | finish no earlier than 2005-06-01 | C4 | 5152h |  | IMSLocal | Rel-7 |  |  |  |  |
| 56 | 17 | IMS Stage 3 IETF Protocol alignment | 261d? | 2004-12-10 | 2005-12-09 |  |  | 2004-12-10 | 2005-12-09 | 261d? | 388d | finish no earlier than 2005-12-09 | C1 | 2088h |  | IMSProtoc | Rel-7 |  |  |  |  |
| 57 | 18 | **Rel-7 Improvements of the Radio Interface** | 326d? | 2004-09-15 A | 2005-12-15 | 18% | 268.5d? | 2004-09-15 | 2005-12-15 | 326d? | 385d |  | RP | 11496h | 2027.58h | RInImp | Rel-7 |  |  | Cesar |  |
| 58 | 18.1 | UMTS 2.6 GHz | 196d? | 2004-09-15 A | 2005-06-15 | 60% | 78.4d? | 2004-09-15 | 2005-06-15 | 196d? | 515d | finish no earlier than 2005-06-15 | R4 | 1568h | 940.8h | RInImp-UMTS2600 | Rel-7 | Jussi Numminen, Nokia | jussi.numminen@nokia.com | MCC_RAN | TSG |
| 59 | 18.2 | UMTS 2.6 GHz TDD | 261d? | 2004-12-15 A | 2005-12-15 | 5% | 247.95d? | 2004-12-15 | 2005-12-15 | 261d? | 385d | finish no earlier than 2005-12-15 | R4 | 2088h | 104.4h | RInImp-UMTS2600TDD | Rel-7 | Shin Horng Wong (IPWireless) | shwong@IPWIRELESS.COM | MCC_RAN | TSG |
| 60 | 18.3 | UMTS 900 MHz | 261d? | 2004-12-15 A | 2005-12-15 | 10% | 234.9d? | 2004-12-15 | 2005-09-15 | 196d? | 385d | finish no earlier than 2005-12-15 | R4 | 2088h | 208.8h | RInImp-UMTS900 | Rel-7 | Yannick Li (Nortel) |  | MCC_RAN | TSG |
| 61 | 18.4 | UE Antenna Performance Evaluation Method and Requirements | 196d? | 2004-12-15 A | 2005-09-15 | 20% | 156.8d? | 2004-12-15 | 2005-09-15 | 196d? | 450d | finish no earlier than 2005-09-15 | R4 | 1568h | 313.6h | RInImp-UEAnt | Rel-7 | Christian Bergljung (TeliaSonera) | Christian.Bergljung@TeliaSonera.com | MCC_RAN | TSG |
| 62 | 18.5 | Improved support of IMS Realtime Services using HSDPA/HSUPA | 197d? | 2005-03-15 | 2005-12-15 |  |  |  |  |  | 385d | finish no earlier than 2005-12-15 | R2 | 1576h |  |  | Rel-7 | Don Zelmer | don.zelmer@CINGULAR.COM | MCC_RAN | TSG |
| 63 | 19 | **7.68Mcps TDD option** | 390d? | 2004-09-15 A | 2006-03-15 | 5% | 368.75d? | 2004-09-15 | 2006-03-15 | 390d? | 321d |  | RP | 14592h | 795.23h | VHCRTDD | Rel-7 | Martin Beale, IPWireless | mbeale@ipwireless.com | Cesar | TSG |
| 64 | 19.1 | Stage 2 | 261d? | 2004-09-15 A | 2005-09-15 | 5% | 247.95d? | 2004-09-15 | 2005-09-15 | 261d? | 450d | finish no earlier than 2005-09-15 | R1 | 2088h | 104.4h | VHCRTDD-Stage2 | Rel-7 | Martin Beale, IPWireless | mbeale@ipwireless.com | MCC_RAN | TSG |
| 65 | 19.2 | Physical Layer | 261d? | 2004-09-15 A | 2005-09-15 | 5% | 247.95d? | 2004-09-15 | 2005-09-15 | 261d? | 450d | finish no earlier than 2005-09-15 | R1 | 2088h | 104.4h | VHCRTDD-Phys | Rel-7 | Martin Beale, IPWireless | mbeale@ipwireless.com | MCC_RAN | TSG |
| 66 | 19.3 | Layer 2 and layer 3 protocol aspects | 261d? | 2004-09-15 | 2005-09-15 |  |  | 2004-09-15 | 2005-09-15 | 261d? | 450d | finish no earlier than 2005-09-15 | R2 | 2088h |  | VHCRTDD-L23 | Rel-7 | Derek Richards, IPWireless | drichards@ipwireless.com | MCC_RAN | TSG |
| 67 | 19.4 | UTRAN Iub/Iur Protocol Aspects | 261d? | 2004-09-15 A | 2005-09-15 | 5% | 247.95d? | 2004-09-15 | 2005-09-15 | 261d? | 450d | finish no earlier than 2005-09-15 | R3 | 2088h | 104.4h | VHCRTDD-IurIub | Rel-7 | Peter Legg, IPWireless | plegg@ipwireless.com | MCC_RAN | TSG |
| 68 | 19.5 | RF, Performance Req and Conf. Testing | 390d? | 2004-09-15 A | 2006-03-15 | 10% | 351d? | 2004-09-15 | 2006-03-15 | 390d? | 321d | finish no earlier than 2006-03-15 | R4 | 3120h | 312h | VHCRTDD-RF | Rel-7 | Shin Horng Wong | shwong@ipwireless.com | MCC_RAN | TSG |
| 69 | 20 | **Rel-7 RAN improvements** | 261d? | 2004-12-15 A | 2005-12-15 | 9% | 238.25d? | 2004-12-15 | 2005-09-14 | 196d? | 385d |  | RP | 8384h | 730.8h | RANimp | Rel-7 |  |  | Cesar | TSG |
| 70 | 20.1 | Optimisation of channelisation code utilisation for 1.28 Mcps TDD | 196d? | 2004-12-15 A | 2005-09-14 | 35% | 127.4d? | 2004-12-15 | 2005-09-14 | 196d? | 450d | finish no earlier than 2005-09-14 | R1 | 1568h | 548.8h | RANimp-RABSE-CodOptLCRTDD | Rel-7 | Ka Leong Lo | kaleong.lo@utstar.com |  | TSG |
| 71 | 20.2 | CS and PS Call Setup Delay Improvement | 197d? | 2005-03-15 | 2005-12-15 |  |  |  |  |  | 385d | finish no earlier than 2005-12-15 | R2 | 1576h |  |  | Rel-7 | Juho Pirskanen | juho.pirskanen@nokia.com | MCC_RAN | TSG |
| 72 | 20.3 | UE Performance Requirements for MBMS (TDD) | 197d? | 2005-03-15 | 2005-12-14 |  |  |  |  |  | 385d | start no earlier than 2005-03-15 | R4 | 1576h |  | MBMS-RAN-RF-TDD | Rel-7 | Shin Horng Wong | shwong@ipwireless.com | MCC_RAN | TSG |
| 73 | 20.4 | FS on Perf Eval of the UE behaviour with speeds up to 350 kmph | 197d? | 2005-03-15 | 2005-12-14 |  |  |  |  |  | 385d | start no earlier than 2005-03-15 | R4 | 1576h |  |  | Rel-7 | Mike Vogel | Mike.vogel@vodafone.com | MCC_RAN | TSG |
| 74 | 21 | **3.84 Mcps TDD Enhanced Uplink** | 327d? | 2005-03-15 | 2006-06-15 |  |  |  |  |  | 255d |  | RP | 13072h |  | EDCHTDD | Rel-7 | Nicholas Anderson | nanderson@ipwireless.com | MCC_RAN | TSG |
| 75 | 21.1 | Stage 2 | 197d? | 2005-03-15 | 2005-12-15 |  |  |  |  |  | 385d | finish no earlier than 2005-12-15 | R2 | 1576h |  | EDCHTDD-Stage2 | Rel-7 | Nicholas Anderson | nanderson@ipwireless.com | MCC_RAN | TSG |
| 76 | 21.2 | Physical Layer | 261d? | 2005-03-15 | 2006-03-15 |  |  |  |  |  | 321d | finish no earlier than 2006-03-15 | R1 | 2088h |  | EDCHTDD-Phys | Rel-7 | Nicholas Anderson | nanderson@ipwireless.com | MCC_RAN | TSG |
| 77 | 21.3 | Layer 2 and 3 Protocol Aspects | 261d? | 2005-03-15 | 2006-03-15 |  |  |  |  |  | 321d | finish no earlier than 2006-03-15 | R2 | 2088h |  | EDCHTDD-L23 | Rel-7 | Derek Richards | drichards@ipwireless.com | MCC_RAN | TSG |
| 78 | 21.4 | UTRAN Iub/Iur Protocol Aspects | 261d? | 2005-03-15 | 2006-03-15 |  |  |  |  |  | 321d | finish no earlier than 2006-03-15 | R3 | 2088h |  | EDCHTDD-IurIub | Rel-7 | Jim Miller | jim.miller@interdigital.com | MCC_RAN | TSG |
| 79 | 21.5 | RF, Performance Req and Conf. Testing | 327d? | 2005-03-15 | 2006-06-15 |  |  |  |  |  | 255d | finish no earlier than 2006-06-15 | R4 | 2616h |  | EDCHTDD-RF | Rel-7 | Shin Horng Wong | shwong@ipwireless.com | MCC_RAN | TSG |
| 80 | 22 | Support of SMS and MMS over generic 3GPP IP access | 173d? | 2004-10-14 A | 2005-06-13 | 46% | 93.42d? | 2004-10-14 | 2005-06-13 | 173d? | 517d | finish no earlier than 2005-06-13 | S2 | 1384h | 636.64h | SMSIP | Rel-7 |  |  |  | TSG |
| 81 | 23 | Evolution of Policy Control and Charging | 315d? | 2004-10-14 A | 2005-12-28 | 8% | 289.8d? | 2004-10-14 | 2005-12-28 | 315d? | 375d | finish no earlier than 2005-12-28 | S2 | 2520h | 201.6h | PCC | Rel-7 |  |  | David | TSG |

Notes:
- 52: Text3: 23.228
- 53: DAB - Not yet required in SA2 as it exists in previous releases
- 55: 27/11/2002 KK: WID approved at CN#18 (NP-020601)........
- 58: Approved at RP#25 as RP-040377 / Text3: TS25.101, TS25.104, TS25.133, TS25.141, TS25.331, TS25.942, TS25.306, TS25.307, TS34.121
- 59: Text3: 25.102, 25.105, 25.113, 25.123, 25.142, 25.331, 25.942, 25.306, 25.307, 34.122, 34.124
- 60: Text3: 25.101, 25.104, 25.113, 25.133, 25.141, 25.331, 25.942, 25.306, 25.307, 34.121
- 61: Text3: TS25.101
- 63: Approved at RP#25 as RP-040365
- 64: Approved at RP#25 as RP-040365 / Text3: New specification
- 65: Approved at RP#25 as RP-040365 / Text3: TS25.221, TS25.222, TS25.223, TS25.224,TS25.225
- 66: Approved at RP#25 as RP-040365 / Text3: TS25.301, TS25.302, TS25.305, TS25.306, TS25.321, TS25.331
- 67: Approved at RP#25 as RP-040365 / Text3: TS25.401, TS25.420, TS25.423, TS25.425, TS25.427, TS25.430, TS25.433, TS25.435
- 68: Approved at RP#25 as RP-040365 / Text3: TS25.102, TS25.105, TS25.123, TS25.133, TS25.142
- 69: Generic feature
- 71: Text3: TS25.321, TS25.322, TS25.331
- 72: Text3: TS25.102, TS25.123
- 76: Text3: TS25.201, TS25.221,TS25.222, TS25.223, TS25.224, TS25.225
- 77: Text3: TS25.301, TS25.302, TS25.306, TS25.321, TS25.331
- 78: Text3: TS25.401, TS25.420, TS25.423, TS25.427, TS25.430, TS25.433, TS25.435
- 79: Text3: TS25.102, TS25.105, TS25.123, TS25.142
- 80: DAB - pushed back to June

| ID | WBS | Task | Type | Duration | Start | Finish | Complete | Remaining | Baseline start | Baseline finish | Baseline duration | Total slack | Constraint | Resources | Work | Actual work | Text1 | Text4 | Text5 | Text6 | Text7 | Text8 |
| --- | --- | --- | --- | --- | --- | --- | --- | --- | --- | --- | --- | --- | --- | --- | --- | --- | --- | --- | --- | --- | --- | --- |
| 82 | 24 | **Advanced Global Navigation Satellite System (A-GNSS) concept** |  | 310d? | 2004-06-28 A | 2005-09-02 | 7% | 287.93d? | 2004-06-28 | 2005-04-12 | 206.8d? | 458d |  | S1 | 6097.6h | 408h | LCS3-AGNSS | Michel MONNERAT | Michel.monnerat@space.alcatel.fr | Rel-7 | TSG | Michael |
| 83 | 24.1 | Support for GNSS in GERAN |  | 291.2d? | 2004-06-28 | 2005-09-02 |  |  | 2004-06-28 | 2005-04-12 | 188d? | 458d | finish no earlier than 2005-09-02 | GP | 2329.6h |  | AGNSS-GP | Richard Couty, ALCATEL SA | richard.couty@space.alcatel.fr | Rel-7 | TSG | Paolo |
| 84 | 24.2 | Towards A-GNSS Concept |  | 161d? | 2004-08-27 A | 2005-04-08 | 20% | 128.8d? | 2004-08-27 | 2005-04-08 | 161d? | 563d | start no earlier than 2004-08-27 | S1 | 1288h | 257.6h | GNSS | Richard Couty, ALCATEL SA | richard.couty@space.alcatel.fr | Rel-7 | TSG | Paolo |
| 85 | 25 | Video Codec Performance Requirements |  | 314d? | 2005-01-03 A | 2006-03-16 | 10% | 282.6d? | 2005-01-03 | 2006-03-16 | 314d? | 319d | finish no earlier than 2006-03-16 | S4 | 2512h | 251.2h | VICPer | Juergen Pandel (Siemens AG) | juergen.pandel@siemens.com | Rel-7 | TSG | Paolo |
| 86 | 26 | DIAMETER on the GGSN Gi interface |  | 266d? | 2004-09-10 | 2005-09-16 |  |  | 2004-09-10 | 2005-09-16 | 266d? | 448d | finish no earlier than 2005-09-16 | C3 | 2128h |  | DIAMGi | Stefan Koppenborg (T-Mobile) | stefan.koppenborg@t-mobile.de | Rel-7 | TSG | Seung Don |
| 87 | 27 | **CAMEL Trunk Triggers** |  | 251d? | 2004-12-17 A | 2005-12-05 | 15% | 213.35d? | 2004-12-17 | 2005-12-05 | 251d? | 392.5d |  | S1 | 6024h | 903.6h | TTCAMEL | Amar Deol, Nortel Networks | deola@nortelnetworks.com | Rel-7 | TSG | Michael |
| 88 | 27.1 | CAMEL Trunk Triggers Stage1 |  | 251d? | 2004-12-17 A | 2005-12-05 | 20% | 200.8d? | 2004-12-17 | 2005-12-05 | 251d? | 392.5d |  | S1 | 2008h | 401.6h | TTCAMEL | Amar Deol, Nortel Networks | deola@nortelnetworks.com | Rel-7 | TSG | Michael |
| 89 | 27.2 | CAMEL Trunk Originated Trigger Detection Points |  | 251d? | 2004-12-17 A | 2005-12-05 | 10% | 225.9d? | 2004-12-17 | 2005-12-05 | 251d? | 392.5d | start no earlier than 2004-12-17 | C4 | 2008h | 200.8h | CamelR7 | David Hutton, Nortel Networks | dhutton@nortel.com | Rel-7 | TSG | Kimmo |
| 90 | 28 | MS Antenna Performance Evaluation Method and Requirements |  | 206d? | 2005-01-28 | 2005-11-11 |  |  | 2005-01-28 | 2005-11-11 | 206d? | 408d | finish no earlier than 2005-11-11 | G1 | 1648h |  | APEMR | Ulf.Tegth (TeliaSonera) | Ulf.Tegth@teliasonera.com | Rel-7 | TSG | Paolo |
| 91 | 29 | Lower 700 MHz Inclusion in the GERAN Specifications |  | 106d? | 2005-01-28 A | 2005-06-24 | 70% | 31.8d? | 2005-01-28 | 2005-06-24 | 106d? | 508d | finish no earlier than 2005-06-24 | GP | 848h | 593.6h | GSM710 | Dave Cotton (UTC) | dcotton@mtview.union-tel.com | Rel-7 | TSG | Paolo |
| 92 | 30 | **3GPP System Architecture Evolution** |  | 654d? | 2004-12-03 A | 2007-06-06 | 2% | 639.26d? | 2004-12-03 | 2007-06-06 | 654d? | 0d |  | S2 | 13608h | 306.73h | Evol |  |  | Rel-7 | TSG |  |
| 93 | 30.1 | Stage 2 description of Interim conclusion |  | 393d? | 2004-12-03 A | 2006-06-06 | 3% | 381.2d? | 2004-12-03 | 2006-06-06 | 393d? | 261d | finish no earlier than 2006-06-06 | S2 | 3144h | 94.4h | Evol |  |  | Rel-7 |  |  |
| 94 | 30.2 | Stage 2 Feasibility study on 3GPP architectural development |  | 654d? | 2004-12-03 A | 2007-06-06 | 2% | 642.2d? | 2004-12-03 | 2007-06-06 | 654d? | 0d | finish no earlier than 2007-06-06 | S2 | 5232h | 94.4h | Evol |  |  | Rel-7 |  |  |
| 95 | 31 | **Deleted - Enhancements of VGCS for public authority officials** |  | 0d? | 2004-08-27 | 2004-08-27 |  |  | 2004-08-03 | 2005-03-03 | 153d? | 724d |  | C1 |  |  | EGCS | Siemens |  | Rel-7 | TSG | Andrijana |
| 96 | 31.1 | deleted -Stage 1 | milestone | 0d? | 2004-08-27 | 2004-08-27 |  |  | 2004-06-28 | 2004-12-16 | 123d? | 724d | finish no earlier than 2004-08-27 | S1 |  |  | EGCS | Joerg Swetina (Siemens AG) | joerg.swetina@SIEMENS.COM | Rel-7 | TSG | Michael |
| 97 | 31.2 | deleted - GERAN2 aspects | milestone | 0d? | 2004-08-27 | 2004-08-27 |  |  | 2004-08-27 | 2005-04-08 | 161d? | 724d | finish no earlier than 2004-08-27 | G2 |  |  | EVGCS | Ken Isaacs (Siemens) | kenneth.isaacs@roke.co.uk | Rel-7 | TSG | Paolo |
| 98 | 32 | **Improvements of VGCS for parallel use of services** |  | 337d? | 2004-06-28 A | 2005-10-11 | 9% | 306.65d? | 2005-03-11 | 2005-09-16 | 136d? | 431d |  | C1 | 8312.02h | 748.68h | IVGCS |  |  | Rel-7 |  |  |
| 99 | 32.1 | Deleted - Enhancements of VGCS |  | 337d? | 2004-06-28 A | 2005-10-11 | 19% | 273.77d? | 2004-06-28 | 2005-09-16 | 320d? | 431d |  | S1 | 2696.02h | 505.85h | EGCS | Joerg Swetina (Siemens AG) | joerg.swetina@SIEMENS.COM | Rel-7 | TSG | Michael |
| 100 | 32.2 | Deleted- Stage 1 |  | 161d? | 2005-03-01 | 2005-10-11 |  |  | 2005-03-15 | 2005-09-28 | 142d? | 431d | start no earlier than 2005-03-01 | S1 | 1288h |  | IVGCS | Kurt Bischinger (T-Mobile) | kurt.bischinger@t-mobile.at | Rel-7 | TSG | Michael |
| 101 | 32.3 | Service Requirements for VGCS improvements |  | 62d? | 2005-03-15 | 2005-06-08 |  |  | 2005-03-15 | 2005-06-08 | 62d? | 520d | finish no earlier than 2005-06-08 | S1 | 496h |  | IVGCS | Kurt Bischinger (T-Mobile) | kurt.bischinger@t-mobile.at | Rel-7 | TSG | Michael |
| 102 | 32.4 | Stage 2 modifications for VGCS improvements |  | 142d? | 2005-03-15 | 2005-09-28 |  |  | 2005-03-15 | 2005-09-28 | 142d? | 440d | finish no earlier than 2005-09-28 | S2 | 1136h |  | IVGCS | Kurt Bischinger (T-Mobile) | kurt.bischinger@t-mobile.at | Rel-7 | TSG | Maurice |
| 103 | 33 | **Rel-7 OSA Service broker** |  | 142d? | 2005-03-15 | 2005-09-28 |  |  | 2005-03-15 | 2005-09-28 | 142d? | 440d |  | S1 | 2768h |  | OSA7-SB | Eamonn Murray (AePONA) | eamonn.murray@aepona.com | Rel-7 | TSG | Michael |
| 104 | 33.1 | Service Requirements for Service Broker |  | 62d? | 2005-03-15 | 2005-06-08 |  |  | 2005-03-15 | 2005-06-08 | 62d? | 520d | finish no earlier than 2005-06-08 | S1 | 496h |  | OSA7-SB | Eamonn Murray (AePONA) | eamonn.murray@aepona.com | Rel-7 | TSG | Michael |
| 105 | 33.2 | Stage 2 modifications for Service Broker |  | 142d? | 2005-03-15 | 2005-09-28 |  |  | 2005-03-15 | 2005-09-28 | 142d? | 440d | finish no earlier than 2005-09-28 | CT5 | 1136h |  | OSA7-SB | Eamonn Murray (AePONA) | eamonn.murray@aepona.com | Rel-7 | TSG | Adrian |
| 106 | 34 | Dynamic and interactive multimedia scenes |  | 194d? | 2005-03-15 | 2005-12-09 |  |  |  |  |  | 388d | finish no earlier than 2005-12-09 | S4 | 1552h |  | DIMS | Gaëlle MARTIN-COCHER (Streamezzo) | gaelle.martin-cocher@streamezzo.com | Rel-7 | TSG | Paolo |
| 107 | 35 | Performance Characterization of VoIMS over HSDPA\EUL channels |  | 262d? | 2005-03-15 | 2006-03-15 |  |  |  |  |  | 320d | finish no earlier than 2006-03-15 | S4 | 2096h |  | PCVoIMS | Dimitris Vasilaras (Lucent Technologies) | dvasilaras@lucent.com | Rel-7 | TSG | Paolo |
| 108 | 36 | Liberty Alliance and 3GPP Security Interworking |  | 147d? | 2005-03-10 | 2005-09-30 |  |  |  |  |  | 438d | finish no earlier than 2005-09-30 | S3 | 1176h |  | LibSec | Silke Holtmanns, Nokia | Silke.Holtmanns@NOKIA.COM | Rel-7 | TSG | Maurice |

Notes:
- 83: Not started
- 84: To become a BB under 31051 !
- 85: Text3: 26.234, 26.235, 26.346, 26.140
- 86: Not started
- 89: Not started
- 90: Started / Text3: 25.9xx, 45.005
- 91: Started / Text3: 24.008, 43.022, 44.018, 44.118, 45, 001, 45.005, 51.010, 51.021
- 93: Text3: 23.8xx
- 94: Text3: 23.8xx
- 95: moved to Rel6 / Text3: 43.068, 44.068, 24.008, 29.002
- 96: Text3: 42.068, 43.068
- 99: covered by Rel6's UID 11045 / Text3: 42.068, 43.068
- 100: covered by UID 31070 / Text3: 42.068
- 101: Text3: 42.068
- 102: Text3: 42.068
- 104: Text3: 22.127
- 105: Text3: 23.127
- 106: Text3: 26.234, 23.346, 26.140, 26.244
- 107: Text3: 26.935
- 108: WID approved SA#27.

| ID | WBS | Task | Type | Duration | Start | Finish | Complete | Remaining | Baseline start | Baseline finish | Baseline duration | Total slack | Constraint | Resources | Work | Actual work | Text1 | Text6 | Text7 | Text8 | Text3 | Text4 | Text5 | Text10 |
| --- | --- | --- | --- | --- | --- | --- | --- | --- | --- | --- | --- | --- | --- | --- | --- | --- | --- | --- | --- | --- | --- | --- | --- | --- |
| 109 | 37 | **FS on IMS with real time services deployment** |  | 384d? | 2004-06-28 A | 2005-12-15 | 70% | 114.47d? | 2004-06-28 | 2005-12-15 | 384d? | 384d |  | S1 | 10680h | 6044.24h | IRTSD | Rel-7 | TSG | Michael |  |  |  |  |
| 110 | 37.1 | Feasibility Study on Combining CS calls and IMS sessions |  | 384d? | 2004-06-28 A | 2005-12-15 A | 100% |  | 2004-06-28 | 2005-12-15 | 384d? |  | start no earlier than 2004-06-28 | S1 | 3072h | 3072h | IRTSD-CS_IMS | Rel-7 | TSG | Michael | 22.979, 23.899 |  |  |  |
| 111 | 37.2 | TR on Stage 2 (IMS services using CS bearers) |  | 316d? | 2004-06-28 A | 2005-09-12 | 50% | 158d? | 2004-06-28 | 2005-09-12 | 316d? | 452d | finish no earlier than 2005-09-12 | S2 | 2528h | 1264h | IRTSD-IMSCS | Rel-7 | TSG | Sang-Ui | 23.899 | Mark Watson (Nortel Networks) |  |  |
| 112 | 37.3 | Deleted - TS on Stage 2 (IMS services using CS bearers) |  | 251d? | 2004-06-28 A | 2005-06-13 | 50% | 125.5d? | 2004-06-28 | 2005-06-13 | 251d? | 517d | finish no earlier than 2005-06-13 | S2 | 2008h | 1004h | IRTSD-IMSCS | Rel-7 | TSG | Sang-Ui |  | Mark Watson (Nortel Networks) |  |  |
| 113 | 38 | FS of enhanced support of Video Telephony |  | 266d? | 2004-08-27 A | 2005-09-02 | 35% | 172.9d? | 2004-08-27 | 2005-04-08 | 161d? | 458d | finish no earlier than 2005-09-02 | GP | 2128h | 744.8h | VIDGER | Rel-7 | TSG | Paolo |  | Stefan Eriksson, Ericsson | stefan.g.eriksson@ericsson.com |  |
| 114 | 39 | FS on Evolved UTRA and UTRAN |  | 130d? | 2004-12-15 A | 2005-06-15 | 5% | 123.5d? | 2004-12-15 | 2005-06-15 | 130d? | 516d | finish no earlier than 2005-06-15 | RP | 1040h | 52h | RANFS-Evo | Rel-7 | TSG | MCC_RAN |  | Takehiro Nakamura (NTT DoCoMo) | nakamurata@NTTDOCOMO.CO.JP |  |
| 115 | 40 | **Study on Videotelephony teleservice** |  | 452d? | 2005-03-15 | 2006-12-06 |  |  | 2005-03-15 | 2006-12-06 | 452d? | 130d |  | S1 | 7232h |  | VidTel | Rel-7 | TSG | Michael |  | Kurt Bischinger (T-Mobile) | kurt.bischinger@t-mobile.at |  |
| 116 | 40.1 | Study on Videotelephony service requirements |  | 452d? | 2005-03-15 | 2006-12-06 |  |  | 2005-03-15 | 2006-12-06 | 452d? | 130d | finish no earlier than 2006-12-06 | S1 | 3616h |  | VidTel | Rel-7 | TSG | Michael | 22.9xx | Kurt Bischinger (T-Mobile) | kurt.bischinger@t-mobile.at |  |
| 117 | 41 | **Study of Network Selection Principles** |  | 509d? | 2004-06-28 A | 2006-06-08 | 15% | 434.09d? | 2005-03-15 | 2006-06-08 | 323d? | 259d |  | S1 | 8160h | 1200.85h | NetSel | Rel-7 | TSG | Michael |  | Chris Friel (O2) | chris.friel@o2.com |  |
| 118 | 41.1 | Behaviour of Multi system UEs |  | 188d? | 2004-06-28 A | 2005-03-16 | 40% | 112.8d? | 2004-06-28 | 2005-03-16 | 188d? | 580d | start no earlier than 2004-06-28 | S1 | 1504h | 601.6h | BMSU | Rel-7 | TSG | Michael | 22.936 | D Williams (QUALCOMM) | dwilliams@qualcomm.com |  |
| 119 | 41.2 | Review of Network Selection Principles |  | 323d? | 2005-03-15 | 2006-06-08 |  |  | 2005-03-15 | 2006-06-08 | 323d? | 259d | finish no earlier than 2006-06-08 | S1 | 2584h |  | NetSel | Rel-7 | TSG | Michael | 22.8xx | Chris Friel (O2) | chris.friel@o2.com |  |
| 120 | 42 | **WLAN-UMTS Interworking Phase 2** |  | 451d? | 2004-01-05 A | 2005-09-26 | 17% | 372.47d? | 2004-01-05 | 2005-09-16 | 445d? | 442d |  | S1 | 8360h | 3204.8h |  | Rel-7 | TSG | Michael |  | Fredric Paint, Telenor | frederic.paint@telenor.com |  |
| 121 | 42.1 | Stage 1 on Session Continuity |  | 115d? | 2004-01-05 A | 2004-06-11 A | 100% |  | 2004-01-05 | 2004-06-11 | 115d? |  | start no earlier than 2004-01-05 | S1 | 920h | 920h | WLAN-SC | Rel-7 |  |  |  |  |  | SP-24 |
| 122 | 42.2 | DIAMETER on the PDG Wi inteface |  | 266d? | 2004-09-10 | 2005-09-16 |  |  | 2004-09-10 | 2005-09-16 | 266d? | 448d | finish no earlier than 2005-09-16 | C3 | 2128h |  | DIAMWi | Rel-7 | TSG | Seung Don |  | Stefan Koppenborg (T-Mobile) | stefan.koppenborg@t-mobile.de |  |
| 123 | 42.3 | Enhancements to support QoS provisioning over 3GPP/WLAN Interworking |  | 392d? | 2004-03-26 A | 2005-09-26 | 5% | 372.4d? | 2004-01-05 | 2004-06-11 | 115d? | 442d | start no earlier than 2004-01-05 | S2 | 3136h | 156.8h | WLAN-SC | Rel-7 |  | Maurice |  | Osok Song, Samsung | osok.song@samsung.com | SP-24 |
| 124 | 43 | **TBC: OAM&P Rel-7** |  | 474d? | 2004-02-16 A | 2005-12-08 | 2% | 466.66d? | 2004-02-16 | 2005-12-08 | 474d? | 389d |  | S5 | 10080h | 3889.42h |  | Rel-7 | TSG | Adrian | 32-series | Michael TRUSS (Motorola) | Michael.Truss@MOTOROLA.COM |  |
| 125 | 44.5 | **Trace Management Rel-7** |  | 474d? | 2004-02-16 A | 2005-12-08 | 2% | 466.66d? | 2004-02-16 | 2005-12-08 | 474d? | 389d |  | S5 | 6288h | 97.42h | OAM-Trace | Rel-7 | TSG |  |  | Christian TOCHE (Nortel) | toche@NORTEL.COM |  |
| 126 | 43.1.1 | Trace Management for IMS |  | 154d? | 2005-05-09 A | 2005-12-08 | 5% | 146.3d? | 2005-05-09 | 2005-12-08 | 154d? | 389d | finish no earlier than 2005-12-08 | S5 | 1232h | 61.6h | OAM-Trace-IMS | Rel-7 | TSG |  | 32.421/2/3 |  |  |  |
| 127 | 43.1.2 | SIP enhancements for trace |  | 343d? | 2004-02-16 A | 2005-06-17 |  | 343d? | 2004-02-16 | 2005-06-08 | 343d? | 513.14d | finish no earlier than 2005-06-08 | C1 | 2744h |  | Trace-SIP | Rel-7 |  |  |  |  |  |  |
| 128 | 44 | **TBC: Generic User Profile Phase 2** |  | 820.4d | 2002-01-01 A | 2005-02-22 |  | 820.4d | 2002-12-05 | 2005-03-03 | 586d | 596.6d |  | C4 | 9376h |  |  | Rel-7 |  |  |  |  |  |  |
| 129 | 30.4 | Stage 3 - Common objects |  | 586d | 2002-01-01 A | 2005-02-22 |  | 586d | 2002-12-05 | 2005-03-03 | 586d | 596.6d | finish no earlier than 2005-03-03 | C4 | 4688h |  |  | Rel-7 | TSG | Friedhelm | 24.241 |  |  |  |
| 130 | 45 | Deleted - IMS Phase 3 | milestone | 0d? | 2005-06-08 A | 2005-06-08 A | 100% |  | 2005-06-08 | 2005-06-08 | 0d? |  | finish no earlier than 2005-06-08 | S2 |  |  |  | Rel-7 |  |  |  |  |  |  |
| 131 | 46 | Deleted - Improvements of Radio Interface | milestone | 0d? | 2004-09-15 A | 2004-09-15 A | 100% |  | 2004-09-15 | 2004-09-15 | 0d? |  | start no earlier than 2004-09-15 | RP |  |  | RInImp | Rel-7 | TSG | Cesar |  |  |  |  |
| 132 | 47 | Trust Requirements for Open Platforms in 3GPP |  | 115d? | 2005-01-03 A | 2005-06-10 | 10% | 103.5d? |  |  |  | 518d | finish no earlier than 2005-06-10 | S3 | 920h | 92h | TrustOP | Rel-7 | TSG | Michael |  | Selim Aissi, Sundeep Bajikar, Intel Corporation | selim.aissi@intel.com; sundeep.bajikar@intel.com |  |
| 133 | 48 | Development of UEA2 and UIA2 |  | 268d? | 2004-12-01 A | 2005-12-09 | 50% | 134d? |  |  |  | 388d | finish no earlier than 2005-12-09 | S3 | 2144h | 1072h | AlgUEA2 | Rel-7 | TSG | Michael | 33.102 | Per Christoffersson, Teliasonera | per.christoffersson@teliasonera.com |  |
| 134 | 49 | Access Security Enhancements |  | 195d? | 2005-01-03 A | 2005-09-30 | 30% | 136.5d? |  |  |  | 438d | finish no earlier than 2005-09-30 | S3 | 1560h | 468h | ACCSEC2 | Rel-7 | TSG | Michael | 33.102, 43.020 | Bengt Sahlin, Ericsson | Bengt.Sahlin@ericsson.com |  |
| 135 | 50 | Voice call continuity between CS and IMS (incl. I-WLAN) |  | 321d? | 2004-12-31 A | 2006-03-24 | 26% | 236.3d? | 2004-12-03 | 2007-06-06 | 654d? | 313d |  | S2 | 2152h | 261.6h | VCC | Rel-7 | TSG | Maurice | 22.101, 22.228, 23.228 | Andy Bennett, Lucent; Roger Bunting, Cingular | andybennett@lucent.com |  |

Notes:
- 112: covered by 32084
- 113: FS started
- 114: vice rapporteur Don Zelmar (Cingular)
- 120: Created at TSG#27 by A. Sultan because of WLAN items belonging to Rel-7
- 122: Not started
- 123: Approved SA#27. BB Position in Work Plan to be confirmed
- 124: Created at TSG#27 by A. Sultan due to the split of the OAM BB Trace Rel-6/Rel-7
- 125: TSG#27: SA5 BB WID to add Trace for IMS (SIP) CN1 24.229 has IETF dependency
- 128: Created at TSG#27 by A. Sultan because of the move to Rel-7 of "Common Objects".
- 129: No progress in CN4#26. This have to be moved to Rel-7. It was deleted from WID
- 131: This is a generic feature without particular end date
- 132: WID approved SA#26. Record created after SA#27
- 133: WID approved SA#26, Dependant on Funding Availability. Record created after SA#27
- 134: WID approved SA#26. Record created after SA#27
- 135: WID approved SA#27

| ID | WBS | Task | Duration | Start | Finish | Complete | Remaining | Total slack | Constraint | Resources | Work | Actual work | Text1 | Text4 | Text5 | Text6 | Text8 |
| --- | --- | --- | --- | --- | --- | --- | --- | --- | --- | --- | --- | --- | --- | --- | --- | --- | --- |
| 136 | 51 | **Support of Conversational Services in A/Gb mode via the PS domain** | 276d? | 2005-04-08 A | 2006-04-28 | 10% | 248.4d? | 288d |  | GP | 8611.2h | 861.12h | SCSAGB | Gunnar Hedby, Ericsson | gunnar.hedby@ericsson.com | Rel-7 | Paolo |
| 137 | 51.1 | Definition of radio resource management functionality | 276d? | 2005-04-08 A | 2006-04-28 | 10% | 248.4d? | 288d | finish no earlier than 2006-04-28 | G1 | 2208h | 220.8h | SCSAGB-RRM | Gunnar Hedby, Ericsson | gunnar.hedby@ericsson.com | Rel-7 | Paolo |
| 138 | 51.2 | Radio Channel Support | 276d? | 2005-04-08 A | 2006-04-28 | 10% | 248.4d? | 288d | finish no earlier than 2006-04-28 | G2 | 2208h | 220.8h | SCSAGB-RCHS | Gunnar Hedby, Ericsson | gunnar.hedby@ericsson.com | Rel-7 | Gert |
| 139 | 51.3 | Modifications to FLO | 276d? | 2005-04-08 A | 2006-04-28 | 10% | 248.4d? | 288d | finish no earlier than 2006-04-28 | G2 | 2208h | 220.8h | SCSAGB-FLO | Gunnar Hedby, Ericsson | gunnar.hedby@ericsson.com | Rel-7 | Gert |
| 140 | 52 | **Addition of new frequency band to GSM (T-GSM810)** | 106d? | 2005-04-08 | 2005-09-02 |  |  | 458d |  | GP | 2992h |  | T-GSM810 | Chen De, Huawei | chende@huawei.com | Rel-7 | Paolo |
| 141 | 52.1 | Changes to core specification | 56d? | 2005-04-08 | 2005-06-24 |  |  | 508d | finish no earlier than 2005-06-24 | GP | 448h |  | T-GSM810-Core | Chen De, Huawei | chende@huawei.com | Rel-7 | Paolo |
| 142 | 52.2 | Changes to MS testing specification | 106d? | 2005-04-08 | 2005-09-02 |  |  | 458d | finish no earlier than 2005-09-02 | G3 | 848h |  | T-GSM810-Mstest | Chen De, Huawei | chende@huawei.com | Rel-7 | Stoyan |
| 143 | 52.3 | Changes to BTS testing specification | 106d? | 2005-04-08 | 2005-09-02 |  |  | 458d | finish no earlier than 2005-09-02 | G1 | 848h |  | T-GSM810-BTStest | Chen De, Huawei | chende@huawei.com | Rel-7 | Paolo |
| 144 | 53 | **Handover of dedicated and shared resources while in dual transfer mode** | 421d? | 2005-04-08 | 2006-11-17 |  |  | 143d |  | GP | 10104h |  | HO-DSRDTM | Rami Vaittinen, Nokia | rami.vaittinen@nokia.com | Rel-7 | Paolo |
| 145 | 53.1 | MS conformance testing | 421d? | 2005-04-08 | 2006-11-17 |  |  | 143d | finish no earlier than 2006-11-17 | G3 | 3368h |  | HO-DSRDTM-MStest | Rami Vaittinen, Nokia | rami.vaittinen@nokia.com | Rel-7 | Stoyan |
| 146 | 53.2 | BTS conformance testing | 421d? | 2005-04-08 | 2006-11-17 |  |  | 143d | finish no earlier than 2006-11-17 | G1 | 3368h |  | HO-DSRDTM-BTStest | Rami Vaittinen, Nokia | rami.vaittinen@nokia.com | Rel-7 | Paolo |
| 147 | 54 | Future GERAN Evolution | 156d? | 2005-04-08 A | 2005-11-11 | 5% | 148.2d? | 408d | finish no earlier than 2005-11-11 | GP | 1248h | 62.4h | FGE | Eddie Riddington, Nokia Corporation | eddie.riddington@nokia.com | Rel-7 | Paolo |

Notes:
- 140: Text3: 45.005, 45.050, 24.008, 45.008, 45.001, 43.022, 43.030, 44.018, 44.060, 51.010-1, 51.021
- 141: Text3: 45.005, 45.050, 24.008, 45.008, 45.001, 43.022, 43.030, 44.018, 44.060
- 142: Text3: 51010-1
- 143: Text3: 51021
- 144: Not started / Text3: 43.055, 44.018, 44.060
- 145: Not started / Text3: 51010-1
- 146: Not started
- 147: FS started
